# DIQUES PAQUETE 4 - PARTE ALTA_ r2

Schedule from Primavera P6, 2024-06-22 to 2025-10-14, data date 2024-06-22.

## Calendars

- 1 T - L-V: Mon-Sat 08:00-16:00; Sun off. Exceptions (off unless hours are given): 2024-06-29, 2024-07-23, 2024-07-29, 2024-08-06, 2024-08-30, 2024-10-08, 2024-11-01, 2024-12-09, 2024-12-25, 2025-01-01, 2025-04-17 to 2025-04-18, 2025-05-01, 2025-06-07, 2025-07-23, 2025-07-28 to 2025-07-29, 2025-08-06, 2025-08-30, 2025-10-08.

## Resources

| Resource | Group | Unit |
| --- | --- | --- |
| Capataz | labor |  |
| Peon | labor |  |
| Operador equipo Pesado | labor |  |
| Excavadora Cat 336 | equipment |  |
| Tractor D6 | equipment |  |
| Petroleo | material | gln |
| Tractor D8 | equipment |  |
| Operador equipo Liviano | labor |  |
| Retroexcavadora sobre llantas 94 hp | equipment |  |
| Cisterna 5000 gln | equipment |  |
| Motoniveladora 140K | equipment |  |
| Rodillo liso vibratorio 10 - 12 ton | equipment |  |
| Operario | labor |  |
| Oficial | labor |  |
| Peon - Vigia | labor |  |
| Volquete 15 m3 | equipment |  |
| Cargador Frontal 966 | equipment |  |
| Chancadora Primaria | equipment |  |
| Retroexcavadora sobre llantas 58 hp | equipment |  |
| Rodillo liso vibratorio 0.80 - 1.10 ton | equipment |  |
| Chancadora LT200 | equipment |  |
| Zaranda Metso ST 4.8 168 HP | equipment |  |
| CANON POR EXTRACCION CANTERA | material |  |
| Camion grua 20 ton | equipment |  |
| Geotextil de 400 gr/m2 | material | m2 |
| Carmix 4.0 m3 | equipment |  |
| PIEDRA CHANCADA | material |  |
| ARENA GRUESA | material |  |
| CEMENTO PORTLAND TIPO I (42.5 kg) | material |  |
| PLASTIMENT TM-40 - PLASTIFICANTE | material |  |
| Volquete 22 m3 | equipment |  |
| Peaje local | material |  |
| Topografo | labor |  |
| GPS | equipment |  |
| MADERA TORNILLO | material |  |
| PINTURA ESMALTE | material |  |
| Zaranda estatica | equipment |  |
| TECNOPOR DE 1/2"X4X8' | material |  |
| SELLADOR ELASTICO POLIURETANO SIKAFLEX 1A | material |  |
| TUBERIA CORRUGADA HDPE D=630 mm | material |  |
| ADITIVO CURADOR DE CONCRETO | material |  |
| ALAMBRE NEGRO #8 | material |  |
| CLAVOS PARA MADERA CON CABEZA DE 3" | material |  |
| LACA DESMOLDEADORA | material |  |
| MADERA TORNILLO INCLUYE CORTE PARA ENCOFRADO | material |  |
| TRIPLAY DE 19 mm PARA ENCOFRADO | material |  |
| ALAMBRE NEGRO #16 | material |  |
| ACERO CORRUGADO fy = 4200 kg/cm2 GRADO 60 | material |  |
| Tubería HDPE Corrugado de 900 mm | material |  |
| WATER STOP (anillos de estanqueidad); DN=900mm | material |  |
| PINTURA ASFALTICA | material |  |
| IMPRIMANTE ASFALTICO | material |  |
| Geotextil no tejido 200gr/m2 | material |  |
| GAVION COLCHON 8x10 cm | material |  |
| GAVION TIPO CAJA DE 1x1x5 m | material |  |
| Suministro de Compuerta plana tipo tarjeta 1.00 x 1.00m | material |  |
| Suministro de Compuerta tipo CHARNELA, D=900mm | material |  |
| MATERIAL DE RESPALDO 1/2" PARA JUNTAS 10 mm | material |  |
| Cost | material |  |
| Cerco perimétrico de Obra | material |  |
| ALMACEN PROVISIONAL | material |  |
| TALLER MECANICO | material |  |
| CARPA COMEDOR (CAMPO) | material |  |
| CONTENEDOR DE OFICINAS | material |  |
| ADITIVO CONTROLADOR DE POLVO | material |  |
| Tubería HDPE Corrugado de 600 mm | material |  |
| TUBERIA CORRUGADA HDPE D=1000 mm | material |  |
| ESTACAS DE MADERA | material |  |

## Schedule

| ID | WBS | Activity | Type | Duration | Start | Finish | Predecessors | Total float | Free float | Resources | RCuad | Metrado | Unidad |
| --- | --- | --- | --- | --- | --- | --- | --- | --- | --- | --- | --- | --- | --- |
|  | 1 | **HITOS** |  |  | 2024-06-22 | 2025-10-13 |  |  |  |  |  |  |  |
| A10470 |  | Inicio de Obra - Acceso al Sitio | milestone | 0d | 2024-06-22 | 2024-06-22 |  | 0d |  |  | 0 |  |  |
| A10480 |  | Inicio de habilitación y Mejoramiento de Accesos | milestone | 0d | 2024-07-12 | 2024-07-12 | A10470 SS+16d | 0d |  |  | 0 |  |  |
| A10490 |  | Inicio - Mov. Tierras - Diques paquete 4 - Parte Alta | milestone | 0d | 2024-08-01 | 2024-08-01 | A10480 SS+15d | 0d |  |  | 0 |  |  |
| A1720 |  | Fin - Mov. Tierras - Diques Paquete 4 - Parte Alta | milestone | 0d | 2025-10-13 | 2025-10-13 | A10520 FF, A10860 FF, A10421 FF, A10461 FF | 0d |  |  | 0 |  |  |
|  | 2 | **OBRAS PROVISIONALES** |  |  | 2024-07-04 | 2025-10-14 |  |  |  |  |  |  |  |
| A10380 |  | Movilizacion de Maquinaria Pesada 1 |  | 25d | 2024-07-04 | 2024-08-03 | A10470 SS+9d | 339d | 0d |  | 0 | 1 | glb |
| A10400 |  | Mejoramiento y Habilitacion de Caminos de Acceso |  | 138d | 2024-07-12 | 2024-12-28 | A10480 SS | 1d | 0d | Capataz [187.2 h]; Oficial [374.4 h]; Peon [621.17 h]; Peon - Vigia [36.97 h]; Operador equipo Pesado [1537.85 h]; Operador equipo Liviano [275.77 h]; Cisterna 5000 gln [92.32 h]; Volquete 15 m3 [183.46 h]; Cargador Frontal 966 [78.16 h]; Chancadora LT200 [78.16 h]; Excavadora Cat 336 [333.22 h]; Motoniveladora 140K [187.2 h]; Rodillo liso vibratorio 10 - 12 ton [374.4 h]; Tractor D6 [408.56 h]; Zaranda Metso ST 4.8 168 HP [78.16 h]; Petroleo [10056.9 gln]; CANON POR EXTRACCION CANTERA [4680] | 0 | 11.7 | km |
| A10420 |  | Mantenimiento de Caminos de Acceso - F1 |  | 138d | 2024-07-12 | 2024-12-28 | A10400 SS | 1d | 0d | Capataz [97.76 h]; Oficial [488.8 h]; Peon [488.8 h]; Operador equipo Pesado [488.8 h]; Operador equipo Liviano [1163.72 h]; Cisterna 5000 gln [1163.72 h]; Motoniveladora 140K [244.4 h]; Rodillo liso vibratorio 10 - 12 ton [244.4 h]; Petroleo [13492.8 gln]; ADITIVO CONTROLADOR DE POLVO [39000] | 0 | 13 | mes |
| A10370 |  | Campamento Provisional de Obra |  | 12d | 2024-07-19 | 2024-08-03 | A10380 FF | 339d | 0d | Cost [96]; Operador equipo Liviano [551.72 h]; Cisterna 5000 gln [551.72 h]; Petroleo [32827.6 gln]; Cerco perimétrico de Obra [200]; ALMACEN PROVISIONAL [16]; TALLER MECANICO [16]; CARPA COMEDOR (CAMPO) [16]; CONTENEDOR DE OFICINAS [96] | 0 | 1 | glb |
| A10430 |  | Habilitacion de Plataformas |  | 15d | 2024-07-19 | 2024-08-08 | A10370 SS | 339d | 33d | Capataz [49.64 h]; Oficial [33.33 h]; Peon [135.53 h]; Peon - Vigia [13.61 h]; Operador equipo Pesado [262.56 h]; Operador equipo Liviano [99.31 h]; Cisterna 5000 gln [31.7 h]; Volquete 22 m3 [23.51 h]; Volquete 15 m3 [44.1 h]; Cargador Frontal 966 [41.29 h]; Chancadora LT200 [18.79 h]; Chancadora Primaria [14.96 h]; Excavadora Cat 336 [60.52 h]; Motoniveladora 140K [33.33 h]; Rodillo liso vibratorio 10 - 12 ton [33.33 h]; Tractor D6 [41.55 h]; Zaranda Metso ST 4.8 168 HP [18.79 h]; Petroleo [1987.73 gln]; CANON POR EXTRACCION CANTERA [1125] | 0 | 0.75 | ha |
| A10410 |  | Limpieza Manual de Material Vegetal y de Residuos - F1 |  | 124d | 2024-08-01 | 2024-12-30 | A10490 SS | 16d | 0d | Capataz [23.89 h]; Oficial [477.02 h]; Peon [954.03 h]; Operador equipo Pesado [178.77 h]; Excavadora Cat 336 [59.3 h]; Tractor D6 [119.47 h]; Petroleo [1515.25 gln] | 0 | 67344.31 | m2 |
| A10440 |  | Tuberia HDPE Corrugada f=600mm, para Caminos de Acceso (o similar) |  | 80d | 2024-08-01 | 2024-11-06 | A10400 SS+15d | 134d | 0d | Capataz [31.91 h]; Operario [46.32 h]; Oficial [74.91 h]; Peon [108.05 h]; Peon - Vigia [0.55 h]; Operador equipo Pesado [26.94 h]; Operador equipo Liviano [28.79 h]; Cisterna 5000 gln [1.64 h]; Camion grua 20 ton [6.66 h]; Volquete 22 m3 [2.75 h]; Cargador Frontal 966 [2.45 h]; Chancadora Primaria [1.62 h]; Excavadora Cat 336 [22.86 h]; Rodillo liso vibratorio 0.80 - 1.10 ton [17.74 h]; Petroleo [292.5 gln]; ARENA GRUESA [10.56]; Tubería HDPE Corrugado de 600 mm [88] | 0 | 80 | m |
| A10450 |  | Tuberia HDPE Corrugada f=1000mm, para Caminos de Acceso (o similar) |  | 80d | 2024-08-01 | 2024-11-06 | A10440 SS | 134d | 133d | Capataz [52.46 h]; Operario [148.58 h]; Oficial [154.66 h]; Peon [603.53 h]; Peon - Vigia [2.41 h]; Operador equipo Pesado [81.68 h]; Operador equipo Liviano [114.17 h]; Cisterna 5000 gln [7.12 h]; Camion grua 20 ton [15.83 h]; Volquete 22 m3 [12.03 h]; Cargador Frontal 966 [10.93 h]; Chancadora Primaria [7.28 h]; Excavadora Cat 336 [63.48 h]; Rodillo liso vibratorio 0.80 - 1.10 ton [79.17 h]; Petroleo [918.17 gln]; ARENA GRUESA [33.44]; TUBERIA CORRUGADA HDPE D=1000 mm [199.5] | 0 | 190 | m |
| A10389 |  | Desmovilizacion de Maquinaria Pesada 1 |  | 15d | 2024-12-30 | 2025-01-16 | A10400 | 132d | 0d |  |  |  |  |
| A10381 |  | Movilizacion de Maquinaria Pesada 2 |  | 15d | 2025-03-28 | 2025-04-14 | A10389 FS+60d | 132d |  |  |  |  |  |
| A10411 |  | Limpieza Manual de Material Vegetal y de Residuos - F2 |  | 116d | 2025-04-15 | 2025-09-06 | A10410 FS+89d | 16d |  | Capataz [3.1 h]; Oficial [61.98 h]; Peon [123.97 h]; Operador equipo Pesado [23.23 h]; Excavadora Cat 336 [7.71 h]; Tractor D6 [15.53 h] | 0 | 67344.31 | m2 |
| A10421 |  | Mantenimiento de Caminos de Acceso - F2 |  | 145d | 2025-04-15 | 2025-10-11 | A10420 FS+90d, A10450 | 1d |  | Capataz [110.24 h]; Oficial [551.2 h]; Peon [551.2 h]; Operador equipo Pesado [551.2 h]; Operador equipo Liviano [1312.28 h]; Cisterna 5000 gln [1312.28 h]; Motoniveladora 140K [275.6 h]; Rodillo liso vibratorio 10 - 12 ton [275.6 h] | 0 | 13 | mes |
| A10390 |  | Desmovilizacion de Maquinaria Pesada 2 |  | 15d | 2025-09-26 | 2025-10-14 | A1720 FF+1d, A10411, A10381 | 0d |  |  | 0 | 1 | glb |
|  | 3 | **TOPOGRAFIA** |  |  | 2024-07-12 | 2025-10-11 |  |  |  |  |  |  |  |
| A10460 |  | Trazo y Replanteo Inicial - F1 |  | 138d | 2024-07-12 | 2024-12-28 | A10480 SS | 1d | 0d | Peon [241.5 h]; Topografo [241.5 h]; GPS [241.5 h]; CEMENTO PORTLAND TIPO I (42.5 kg) [5]; ESTACAS DE MADERA [300]; PINTURA ESMALTE [10] | 0 | 1 | glb |
| A10461 |  | Trazo y Replanteo Inicial - F2 |  | 145d | 2025-04-15 | 2025-10-11 | A10460 FS+90d | 1d |  | Peon [258.5 h]; Topografo [258.5 h]; GPS [258.5 h] | 0 | 1 | glb |
|  | 4 | **DIQUES** |  |  | 2024-08-01 | 2025-10-13 |  |  |  |  |  |  |  |
| A10510 |  | Inicio - DIQUES | milestone | 0d | 2024-08-01 | 2024-08-01 | A10490 SS | 0d |  |  | 0 |  |  |
| A10520 |  | Fin - DIQUES | milestone | 0d | 2025-10-13 | 2025-10-13 | A10540 FF, A10570 FF, A10820 FF, A10600 FF, A10620 FF, A10640 FF, A10670 FF, A10700 FF, A10730 FF, A10760 FF, A10790 FF, A10840 FF | 0d |  |  | 0 |  |  |

| ID | WBS | Activity | Type | Duration | Start | Finish | Predecessors | Total float | Free float | Resources | RCuad | Cuadrilla | Rendimiento | Metrado | Unidad | Turno | DurCal | Dur. Cal. | AGrupo |
| --- | --- | --- | --- | --- | --- | --- | --- | --- | --- | --- | --- | --- | --- | --- | --- | --- | --- | --- | --- |
|  | 2 | **DE-PR-39-I** |  |  | 2024-08-01 | 2024-09-17 |  |  |  |  |  |  |  |  |  |  |  |  |  |
| A10530 |  | Inicio - DE-PR-39-I | milestone | 0d | 2024-08-01 | 2024-08-01 | A10510 SS | 254d | 0d |  | 0 |  |  |  |  |  |  |  |  |
| A10540 |  | Fin - DE-PR-39-I | milestone | 0d | 2024-09-17 | 2024-09-17 | A2010 FF, A1380 FF, A10430 FF, A1050 FF, A1060 FF, A1070 FF, A1090 FF, A1110 FF, A1120 FF, A1220 FF | 306d | 0d |  | 0 |  |  |  |  |  |  |  |  |
|  | 1 | **EXCAVACIONES** |  |  | 2024-08-01 | 2024-08-29 |  |  |  |  |  |  |  |  |  |  |  |  |  |
| A1000 |  | Desbroce |  | 15d | 2024-08-01 | 2024-08-19 | A10530 SS | 254d | 0d | Capataz [0.04 h]; Peon [7.8 h]; Operador equipo Pesado [5.85 h]; Excavadora Cat 336 [1.95 h]; Tractor D6 [3.9 h]; Petroleo [43.88 gln] | 1 | 1 | 0.8 | 0.39 | ha | 1 | 0.39 | 0.4875 | Excavacion |
| A1060 |  | Conformacion de Material Excedente en DMO |  | 15d | 2024-08-01 | 2024-08-19 | A1000 SS | 330d | 24d | Capataz [0.97 h]; Peon [9.18 h]; Operador equipo Pesado [10.15 h]; Excavadora Cat 336 [0.97 h]; Tractor D6 [9.18 h]; Petroleo [72.49 gln] | 1 | 1 | 1050 | 1208.11 | m3 | 1 | 1208.11 | 1.15058095238095 | Excavacion |
| A1010 |  | Remocion de Dique Existente |  | 21d | 2024-08-03 | 2024-08-28 | A1000 SS+2d | 254d | 0d | Capataz [3.07 h]; Peon [15.37 h]; Operador equipo Pesado [23.06 h]; Excavadora Cat 336 [15.37 h]; Tractor D8 [7.69 h]; Petroleo [203.68 gln] | 1 | 1 | 800 | 1537.22 | m3 | 1 | 1537.22 | 1.921525 | Excavacion |
| A1020 |  | Excavacion de Cimentacion |  | 21d | 2024-08-03 | 2024-08-28 | A1010 SS | 306d | 0d | Capataz [12.91 h]; Peon [129.06 h]; Operador equipo Pesado [86.04 h]; Operador equipo Liviano [71.7 h]; Excavadora Cat 336 [57.36 h]; Retroexcavadora sobre llantas 94 hp [71.7 h]; Tractor D8 [28.68 h]; Petroleo [937.84 gln] | 1 | 1 | 900 | 7170.05 | m3 | 1 | 7170.05 | 7.96672222222222 | Excavacion |
| A1040 |  | Excavacion de Uña |  | 21d | 2024-08-03 | 2024-08-28 | A1020 SS | 306d | 0d | Capataz [7.81 h]; Peon [39.06 h]; Operador equipo Pesado [39.06 h]; Excavadora Cat 336 [39.06 h]; Petroleo [441.43 gln] | 1 | 1 | 500 | 2441.53 | m3 | 1 | 2441.53 | 4.88306 | Excavacion |
| A1050 |  | Conformacion de Material Excedente en DME |  | 21d | 2024-08-03 | 2024-08-28 | A1010 SS | 322d | 16d | Capataz [8.58 h]; Peon [81.5 h]; Operador equipo Pesado [90.07 h]; Excavadora Cat 336 [8.58 h]; Tractor D6 [81.5 h]; Petroleo [643.39 gln] | 1 | 1 | 1050 | 10723.18 | m3 | 1 | 10723.18 | 10.2125523809524 | Excavacion |
| A1070 |  | Excavacion Localizada - Sobreexcavacion |  | 21d | 2024-08-03 | 2024-08-28 | A1040 SS | 322d | 16d | Capataz [13.05 h]; Peon [64.87 h]; Operador equipo Pesado [64.87 h]; Excavadora Cat 336 [64.87 h]; Petroleo [551.49 gln] | 1 | 1 | 240 | 1948.04 | m3 | 1 | 1948.04 | 8.11683333333333 | Excavacion |
| A1030 |  | Perfilado y Conformacion de Plataforma de Fundacion |  | 10d | 2024-08-19 | 2024-08-29 | A1020 SS+12d | 310d | 0d | Capataz [1.32 h]; Peon [16.31 h]; Operador equipo Pesado [29.09 h]; Operador equipo Liviano [6.17 h]; Cisterna 5000 gln [6.17 h]; Motoniveladora 140K [14.54 h]; Rodillo liso vibratorio 10 - 12 ton [14.54 h]; Petroleo [125.16 gln] | 1 | 1 | 2400 | 4407.13 | m2 | 1 | 4407.13 | 1.83630416666667 | Excavacion |
|  | 2 | **RELLENOS** |  |  | 2024-08-24 | 2024-09-11 |  |  |  |  |  |  |  |  |  |  |  |  |  |
| A1080 |  | Relleno con Material Granular (incluye extraccion de material, zarandeo y combinado) |  | 9d | 2024-08-24 | 2024-09-04 | A1030 SS+5d | 310d | 0d | Capataz [43.1 h]; Operario [10.81 h]; Oficial [31.52 h]; Peon [112.99 h]; Peon - Vigia [6.7 h]; Operador equipo Pesado [166.29 h]; Operador equipo Liviano [65.02 h]; Cisterna 5000 gln [21.32 h]; Volquete 15 m3 [32.74 h]; Cargador Frontal 966 [49.64 h]; Chancadora Primaria [24.52 h]; Excavadora Cat 336 [38.37 h]; Retroexcavadora sobre llantas 58 hp [5.48 h]; Rodillo liso vibratorio 10 - 12 ton [20.71 h]; Rodillo liso vibratorio 0.80 - 1.10 ton [10.81 h]; Tractor D6 [27.56 h]; Petroleo [1179.11 gln] | 1 | 1 | 560 | 1522.81 | m3 | 1 | 1522.81 | 2.71930357142857 | Relleno |
| A1120 |  | Relleno con Material Seleccionado (incluye extraccion de material, zarandeo y combinado) |  | 9d | 2024-08-24 | 2024-09-04 | A1080 SS | 317d | 11d | Capataz [13.05 h]; Oficial [64.87 h]; Peon [133.25 h]; Operador equipo Pesado [194.61 h]; Operador equipo Liviano [13.64 h]; Cisterna 5000 gln [13.64 h]; Excavadora Cat 336 [129.74 h]; Rodillo liso vibratorio 10 - 12 ton [64.87 h]; Petroleo [1983.88 gln] | 1 | 1 | 240 | 1948.04 | m3 | 1 | 1948.04 | 8.11683333333333 | Relleno |
| A1110 |  | Perfilado de Talud Dique |  | 7d | 2024-08-28 | 2024-09-05 | A1080 SS+3d | 316d | 10d | Capataz [2.66 h]; Peon [13.18 h]; Operador equipo Pesado [3.93 h]; Excavadora Cat 336 [3.93 h]; Petroleo [33.42 gln] | 1 | 1 | 700 | 1156.26 | m2 | 1 | 1156.26 | 1.6518 | Relleno |
| A1130 |  | Grava para Drenaje |  | 3d | 2024-09-05 | 2024-09-07 | A1080 | 311d | 0d | Capataz [9.34 h]; Peon [30.3 h]; Peon - Vigia [0.95 h]; Operador equipo Pesado [12.43 h]; Operador equipo Liviano [27.94 h]; Volquete 15 m3 [4.75 h]; Cargador Frontal 966 [5.33 h]; Chancadora Primaria [3.55 h]; Excavadora Cat 336 [3.55 h]; Retroexcavadora sobre llantas 94 hp [23.19 h]; Tractor D6; Petroleo [158.57 gln] | 1 | 1 | 80 | 231.86 | m3 | 1 | 231.86 | 2.89825 | Relleno |
| A1100 |  | Relleno Afirmado |  | 1d | 2024-09-09 | 2024-09-09 | A1130 | 311d | 0d | Capataz [4.98 h]; Oficial [4.09 h]; Peon [12.85 h]; Peon - Vigia [1.37 h]; Operador equipo Pesado [23.55 h]; Operador equipo Liviano [8.68 h]; Cisterna 5000 gln [1.87 h]; Volquete 15 m3 [6.81 h]; Cargador Frontal 966 [2.89 h]; Chancadora LT200 [2.89 h]; Excavadora Cat 336 [5.42 h]; Motoniveladora 140K [4.09 h]; Rodillo liso vibratorio 10 - 12 ton [4.09 h]; Tractor D6 [1.27 h]; Zaranda Metso ST 4.8 168 HP [2.89 h]; Petroleo [165.89 gln]; CANON POR EXTRACCION CANTERA [173.66] | 1 | 1 | 324 | 165.39 | m3 | 1 | 165.39 | 0.510462962962963 | Relleno |
| A1090 |  | Relleno sin Compactar |  | 2d | 2024-09-10 | 2024-09-11 | A1100 | 311d | 5d | Capataz [2.18 h]; Oficial [10.77 h]; Peon [10.77 h]; Operador equipo Pesado [10.77 h]; Tractor D6 [10.77 h]; Petroleo [75.38 gln] | 1 | 1 | 900 | 1210.03 | m3 | 1 | 1210.03 | 1.34447777777778 | Relleno |
|  | 3 | **GEOTEXTIL** |  |  | 2024-08-21 | 2024-09-16 |  |  |  |  |  |  |  |  |  |  |  |  |  |
| A1140 |  | Instalacion de Geotextil 400gr/m2 |  | 22d | 2024-08-21 | 2024-09-16 | A1170 SS | 307d | 0d | Capataz [13.33 h]; Oficial [131.83 h]; Peon [197.5 h]; Operador equipo Liviano [16.29 h]; Camion grua 20 ton [16.29 h]; Petroleo [65.18 gln]; Geotextil de 400 gr/m2 [5678.21 m2] | 1 | 1 | 600 | 4937.57 | m2 | 1 | 4937.57 | 8.22928333333333 | Geotextil |
| A1150 |  | Zanja de Anclaje |  | 8d | 2024-09-07 | 2024-09-16 | A1140 FF | 307d | 0d | Capataz [1.67 h]; Oficial [8.32 h]; Peon [25.03 h]; Operador equipo Pesado [8.32 h]; Operador equipo Liviano [0.23 h]; Cisterna 5000 gln [0.23 h]; Retroexcavadora sobre llantas 58 hp [8.32 h]; Petroleo [29.66 gln] | 1 | 1 | 32 | 33.3 | m3 | 1 | 33.3 | 1.040625 | Geotextil |
|  | 4 | **COLOCACION DE ROCA** |  |  | 2024-08-03 | 2024-09-17 |  |  |  |  |  |  |  |  |  |  |  |  |  |
| A1190 |  | Extraccion de Rocas Reutilizables |  | 21d | 2024-08-03 | 2024-08-28 | A1010 SS | 308d | 2d | Capataz [58.21 h]; Peon [116.33 h]; Operador equipo Pesado [116.33 h]; Excavadora Cat 336 [116.33 h]; Petroleo [988.81 gln] | 1 | 1 | 160 | 1034 | m3 | 1 | 1034 | 6.4625 | Roca |
| A10550 |  | Suministro de Roca |  | 22d | 2024-08-21 | 2024-09-16 | A1170 SS | 306d | 0d |  | 0 |  |  |  |  |  |  |  | Roca |
| A1170 |  | Colocacion de Roca en Uña |  | 9d | 2024-08-21 | 2024-08-31 | A1040 SS+14d | 306d | 0d | Capataz [34.91 h]; Oficial [69.83 h]; Peon [69.83 h]; Operador equipo Pesado [76.91 h]; Excavadora Cat 336 [69.83 h]; Tractor D6 [7.08 h]; Petroleo [643.1 gln] | 1 | 1 | 280 | 2441.53 | m3 | 1 | 2441.53 | 8.71975 | Roca |
| A1180 |  | Colocacion de Roca en Talud |  | 13d | 2024-09-02 | 2024-09-16 | A1170, A1190 | 306d | 0d | Capataz [49.36 h]; Oficial [98.97 h]; Peon [98.97 h]; Operador equipo Pesado [207.66 h]; Excavadora Cat 336 [197.69 h]; Tractor D6 [9.97 h]; Petroleo [1750.29 gln] | 1 | 1 | 192 | 2373.27 | m3 | 1 | 2373.27 | 12.36078125 | Roca |
| A1220 |  | Enrocado Talud Encachado con Concreto |  | 1d | 2024-09-17 | 2024-09-17 | A1180, A1320, A1340, A1360 | 306d | 0d | Capataz [4.96 h]; Operario [5.92 h]; Oficial [17.57 h]; Peon [63.5 h]; Operador equipo Pesado [2.48 h]; Operador equipo Liviano [5.92 h]; Carmix 4.0 m3 [5.92 h]; Excavadora Cat 336 [2.25 h]; Tractor D8 [0.23 h]; Petroleo [50.9 gln]; PIEDRA CHANCADA [9.62]; ARENA GRUESA [8.14]; CEMENTO PORTLAND TIPO I (42.5 kg) [140.56]; PLASTIMENT TM-40 - PLASTIFICANTE [31.81] | 1 | 1 | 100 | 40.26 | m3 | 1 | 40.26 | 0.4026 | Roca |

| ID | WBS | Activity | Duration | Start | Finish | Predecessors | Total float | Free float | Resources | Cuadrilla | Metrado | Unidad | Turno | RCuad | DurCal | AGrupo |
| --- | --- | --- | --- | --- | --- | --- | --- | --- | --- | --- | --- | --- | --- | --- | --- | --- |
|  | 5 | **TRANSPORTES** |  | 2024-08-01 | 2024-09-16 |  |  |  |  |  |  |  |  |  |  |  |
| A1270 |  | Transporte de Material Organico (a DMO) D<=1km | 15d | 2024-08-01 | 2024-08-19 | A1000 SS | 322d | 0d | Peon - Vigia [6.77 h]; Operador equipo Liviano [33.59 h]; Volquete 15 m3 [33.59 h]; Petroleo [93.99 gln] | 1 | 1208.11 | m3k | 1 | 1 | 1208.11 | Transportes |
| A1280 |  | Transporte de Material Organico (a DMO) D>1km | 15d | 2024-08-01 | 2024-08-19 | A1270 SS | 322d | 15d | Operador equipo Liviano [132.45 h]; Volquete 15 m3 [132.45 h]; Petroleo [370.86 gln] | 1 | 12040.75 | m3k | 1 | 1 | 12040.75 | Transportes |
| A1290 |  | Transporte de Material Excedente D<=1km | 21d | 2024-08-03 | 2024-08-28 | A1010 SS | 314d | 0d | Peon - Vigia [54.69 h]; Operador equipo Liviano [272.37 h]; Volquete 22 m3 [116.88 h]; Volquete 15 m3 [155.49 h]; Petroleo [912.54 gln] | 1 | 10723.18 | m3k | 1 | 1 | 10723.18 | Transportes |
| A1300 |  | Transporte de Material Excedente D>1km | 21d | 2024-08-03 | 2024-08-28 | A1290 SS | 314d | 7d | Operador equipo Liviano [1066.16 h]; Volquete 22 m3 [453.91 h]; Volquete 15 m3 [612.25 h]; Petroleo [3567.94 gln] | 1 | 105560.37 | m3k | 1 | 1 | 105560.37 | Transportes |
| A1330 |  | Transporte de Roca D<=1km | 22d | 2024-08-21 | 2024-09-16 | A10550 SS | 306d | 0d | Peon [62.25 h]; Peon - Vigia [28.88 h]; Operador equipo Pesado [62.25 h]; Operador equipo Liviano [144.42 h]; Volquete 22 m3 [144.42 h]; Excavadora Cat 336 [62.25 h]; Petroleo [1121.5 gln]; Peaje local [226.59] | 1 | 4980.02 | m3k | 1 | 1 | 4980.02 | Transportes |
| A1340 |  | Transporte de Roca D>1km | 22d | 2024-08-21 | 2024-09-16 | A1330 SS | 306d | 0d | Operador equipo Liviano [76.6 h]; Volquete 22 m3 [76.6 h]; Petroleo [313.78 gln] | 1 | 7365.68 | m3k | 1 | 1 | 7365.68 | Transportes |
| A1310 |  | Transporte de Material de Prestamo (Afirmado) D<=1km | 15d | 2024-08-24 | 2024-09-11 | A1080 SS | 310d | 0d | Peon - Vigia [10.16 h]; Operador equipo Liviano [50.57 h]; Volquete 22 m3 [50.57 h]; Petroleo [207.36 gln] | 1 | 2419.55 | m3k | 1 | 1 | 2419.55 | Transportes |
| A1320 |  | Transporte de Material de Prestamo (Afirmado) D>1km | 15d | 2024-08-24 | 2024-09-11 | A1310 SS | 310d | 4d | Operador equipo Liviano [77.37 h]; Volquete 22 m3 [77.37 h]; Petroleo [316.94 gln] | 1 | 9321.89 | m3k | 1 | 1 | 9321.89 | Transportes |
| A1350 |  | Transporte de Material de Prestamo Cantera de Rio (Cuerpo de Terraplen) D<=1km | 15d | 2024-08-24 | 2024-09-11 | A1080 SS | 310d | 0d | Peon - Vigia [16.48 h]; Operador equipo Liviano [82.01 h]; Volquete 22 m3 [82.01 h]; Petroleo [336.27 gln] | 1 | 3923.75 | m3k | 1 | 1 | 3923.75 | Transportes |
| A1360 |  | Transporte de Material de Prestamo Cantera de Rio (Cuerpo de Terraplen) D>1km | 15d | 2024-08-24 | 2024-09-11 | A1350 SS | 310d | 4d | Operador equipo Liviano [195.94 h]; Volquete 22 m3 [195.94 h]; Petroleo [802.66 gln] | 1 | 23607.66 | m3k | 1 | 1 | 23607.66 | Transportes |
| A1370 |  | Transporte de Material Seleccionado para Zanja D<=1km | 8d | 2024-09-07 | 2024-09-16 | A1150 SS, A1280, A1300 | 307d | 0d | Peon - Vigia [0.19 h]; Operador equipo Liviano [0.93 h]; Volquete 15 m3 [0.93 h]; Petroleo [2.59 gln] | 1 | 33.3 | m3k | 1 | 1 | 33.3 | Transportes |
| A1380 |  | Transporte de Material Seleccionado para Zanja D>1km | 8d | 2024-09-07 | 2024-09-16 | A1370 SS | 307d | 1d | Operador equipo Liviano [2.2 h]; Volquete 15 m3 [2.2 h]; Petroleo [6.17 gln] | 1 | 200.38 | m3k | 1 | 1 | 200.38 | Transportes |
|  | 6 | **INTERFERENCIAS** |  | 2024-08-02 | 2024-09-05 |  |  |  |  |  |  |  |  |  |  |  |
|  | 1 | **CANAL DE-PR-39-I-CAN01** |  | 2024-08-02 | 2024-08-16 |  |  |  |  |  |  |  |  |  |  |  |
| A1390 |  | Trazo y replanteo de interferencia | 12d | 2024-08-02 | 2024-08-16 | A1000 SS+1d | 316d | 0d | Capataz [0.39 h]; Peon [7.81 h]; Topografo [3.91 h]; GPS [3.91 h]; MADERA TORNILLO [3.91]; PINTURA ESMALTE [0.39] |  | 195.35 | m2 |  | 0 |  | Interferencias |
| A1410 |  | Desvío provisional en tierras | 12d | 2024-08-02 | 2024-08-16 | A1390 SS | 316d | 0d | Capataz [2.67 h]; Peon [13.33 h]; Operador equipo Pesado [13.33 h]; Excavadora Cat 336 [13.33 h]; Petroleo [113.31 gln] |  | 100 | m |  | 0 |  | Interferencias |
| A1420 |  | Limpieza de terreno manual | 12d | 2024-08-02 | 2024-08-16 | A1410 SS | 316d | 0d | Capataz [0.08 h]; Oficial [1.56 h]; Peon [3.13 h]; Operador equipo Pesado [0.59 h]; Excavadora Cat 336 [0.2 h]; Tractor D6 [0.39 h]; Petroleo [4.4 gln] |  | 195.35 | m2 |  | 0 |  | Interferencias |
| A1440 |  | Excavacion no clasificada de zanja | 12d | 2024-08-02 | 2024-08-16 | A1420 SS | 316d | 0d | Capataz [0.46 h]; Peon [4.64 h]; Operador equipo Pesado [4.64 h]; Excavadora Cat 336 [4.64 h]; Petroleo [39.45 gln] |  | 92.83 | m3 |  | 0 |  | Interferencias |
| A1550 |  | Emboquillado de piedra e=0.20m | 12d | 2024-08-02 | 2024-08-16 | A1440 SS | 316d | 0d | Capataz [1.02 h]; Operario [2.95 h]; Oficial [5.91 h]; Peon [9.66 h]; Peon - Vigia [0.01 h]; Operador equipo Pesado [0.01 h]; Operador equipo Liviano [2.08 h]; Cisterna 5000 gln [0.03 h]; Volquete 15 m3 [0.09 h]; Excavadora Cat 336 [0.01 h]; Retroexcavadora sobre llantas 94 hp [1.97 h]; Zaranda estatica [0.2 h]; Petroleo [5.39 gln]; ARENA GRUESA [0.85]; CEMENTO PORTLAND TIPO I (42.5 kg) [8.31] |  | 10.6 | m2 |  | 0 |  | Interferencias |
| A1620 |  | Sello en juntas | 12d | 2024-08-02 | 2024-08-16 | A1550 SS | 316d | 0d | Capataz [0.44 h]; Operario [1.77 h]; Peon [0.44 h]; TECNOPOR DE 1/2"X4X8' [0.3]; SELLADOR ELASTICO POLIURETANO SIKAFLEX 1A [1.52] |  | 5.3 | m |  | 0 |  | Interferencias |
|  | 2 | **DI-PR-39-D-INT01** |  | 2024-08-17 | 2024-09-05 |  |  |  |  |  |  |  |  |  |  |  |
| A1750 |  | Trazo y replanteo de interferencia | 16d | 2024-08-17 | 2024-09-05 | A1620 | 316d | 0d | Capataz [0.42 h]; Peon [8.44 h]; Topografo [4.22 h]; GPS [4.22 h]; MADERA TORNILLO [4.22]; PINTURA ESMALTE [0.42] |  | 210.9 | m2 |  | 0 |  | Interferencias |
| A1760 |  | Desvío provisional con tubería | 16d | 2024-08-17 | 2024-09-05 | A1750 SS | 316d | 0d | Capataz [6.29 h]; Operario [10.83 h]; Oficial [10.83 h]; Peon [69.33 h]; Operador equipo Pesado [4.33 h]; Operador equipo Liviano [2.71 h]; Camion grua 20 ton [2.71 h]; Excavadora Cat 336 [4.33 h]; Petroleo [47.65 gln]; TUBERIA CORRUGADA HDPE D=630 mm [34.12] |  | 32.5 | m |  | 0 |  | Interferencias |
| A1780 |  | Limpieza de terreno manual | 16d | 2024-08-17 | 2024-09-05 | A1760 SS | 316d | 0d | Capataz [0.08 h]; Oficial [1.69 h]; Peon [3.37 h]; Operador equipo Pesado [0.63 h]; Excavadora Cat 336 [0.21 h]; Tractor D6 [0.42 h]; Petroleo [4.75 gln] |  | 210.9 | m2 |  | 0 |  | Interferencias |
| A1790 |  | Excavaciones no clasificada para estructuras | 16d | 2024-08-17 | 2024-09-05 | A1780 SS | 316d | 0d | Capataz [0.34 h]; Peon [1.7 h]; Operador equipo Pesado [1.7 h]; Excavadora Cat 336 [1.7 h]; Petroleo [14.48 gln] |  | 53.24 | m3 |  | 0 |  | Interferencias |
| A1800 |  | Excavacion no clasificada de zanja | 16d | 2024-08-17 | 2024-09-05 | A1790 SS | 316d | 0d | Capataz [0.07 h]; Peon [0.65 h]; Operador equipo Pesado [0.65 h]; Excavadora Cat 336 [0.65 h]; Petroleo [5.55 gln] |  | 13.06 | m3 |  | 0 |  | Interferencias |
| A1810 |  | Relleno estructural | 16d | 2024-08-17 | 2024-09-05 | A1800 SS | 316d | 0d | Capataz [7.13 h]; Operario [25.74 h]; Oficial [25.74 h]; Peon [61.58 h]; Peon - Vigia [0.79 h]; Operador equipo Pesado [27.22 h]; Operador equipo Liviano [33.44 h]; Cisterna 5000 gln [3.8 h]; Volquete 15 m3 [3.89 h]; Cargador Frontal 966 [5.96 h]; Chancadora Primaria [2.9 h]; Excavadora Cat 336 [4.63 h]; Retroexcavadora sobre llantas 58 hp [12.86 h]; Rodillo liso vibratorio 0.80 - 1.10 ton [25.74 h]; Tractor D6 [0.86 h]; Petroleo [191.86 gln] |  | 180.15 | m3 |  | 0 |  | Interferencias |
| A1820 |  | Suministro de roca (Alcantarillas) | 16d | 2024-08-17 | 2024-09-05 | A1810 SS | 316d | 0d | Capataz [3.91 h]; Peon [9.37 h]; Peon - Vigia [0.72 h]; Operador equipo Pesado [9.37 h]; Operador equipo Liviano [14.5 h]; Volquete 22 m3 [14.5 h]; Excavadora Cat 336 [9.37 h]; Petroleo [139.09 gln]; Peaje local [5.69] |  | 124.96 | m3 |  | 0 |  | Interferencias |
| A1830 |  | Colocación de roca en uña (Alcantarillas) | 16d | 2024-08-17 | 2024-09-05 | A1820 SS | 316d | 0d | Capataz [2.6 h]; Oficial [5.21 h]; Peon [5.21 h]; Operador equipo Pesado [6.25 h]; Excavadora Cat 336 [5.21 h]; Tractor D6 [1.04 h]; Petroleo [51.56 gln] |  | 124.96 | m3 |  | 0 |  | Interferencias |
| A1840 |  | Concreto de Nivelacion (f'c=100 kg/cm2) | 16d | 2024-08-17 | 2024-09-05 | A1830 SS | 316d | 0d | Capataz [0.43 h]; Operario [0.47 h]; Oficial [0.75 h]; Peon [3.97 h]; Operador equipo Liviano [0.5 h]; Cisterna 5000 gln [0.03 h]; Carmix 4.0 m3 [0.47 h]; Petroleo [2.49 gln]; PIEDRA CHANCADA [0.77]; ARENA GRUESA [0.65]; CEMENTO PORTLAND TIPO I (42.5 kg) [7.12] |  | 1.13 | m3 |  | 0 |  | Interferencias |
| A1850 |  | Concreto Clase F (f'c=140 kg/cm2) | 16d | 2024-08-17 | 2024-09-05 | A1840 SS | 316d | 0d | Capataz [10.13 h]; Operario [15.65 h]; Oficial [40.5 h]; Peon [162 h]; Operador equipo Liviano [15.65 h]; Carmix 4.0 m3 [15.65 h]; Petroleo [78.27 gln]; PIEDRA CHANCADA [25.44]; ARENA GRUESA [21.52]; CEMENTO PORTLAND TIPO I (42.5 kg) [273.93]; PLASTIMENT TM-40 - PLASTIFICANTE [84.14] |  | 37.27 | m3 |  | 0 |  | Interferencias |
| A1860 |  | Concreto Clase C (f'c=280 kg/cm2) Premezclado - Cimientos reforzados | 16d | 2024-08-17 | 2024-09-05 | A1850 SS | 316d | 0d | Capataz [5.67 h]; Operario [16.34 h]; Oficial [22.69 h]; Peon [52.68 h]; Operador equipo Liviano [10 h]; Carmix 4.0 m3 [10 h]; Petroleo [53.15 gln]; PIEDRA CHANCADA [16.24]; ARENA GRUESA [13.74]; CEMENTO PORTLAND TIPO I (42.5 kg) [262.39]; PLASTIMENT TM-40 - PLASTIFICANTE [53.73]; ADITIVO CURADOR DE CONCRETO [3.57] |  | 23.8 | m3 |  | 0 |  | Interferencias |
| A1870 |  | Concreto Clase C (f'c=280 kg/cm2) Premezclado - Muros de contencion | 16d | 2024-08-17 | 2024-09-05 | A1860 SS | 316d | 0d | Capataz [6.76 h]; Operario [19.47 h]; Oficial [27.04 h]; Peon [70.33 h]; Operador equipo Liviano [11.91 h]; Carmix 4.0 m3 [11.91 h]; Petroleo [63.34 gln]; PIEDRA CHANCADA [19.36]; ARENA GRUESA [16.38]; CEMENTO PORTLAND TIPO I (42.5 kg) [312.67]; PLASTIMENT TM-40 - PLASTIFICANTE [64.02]; ADITIVO CURADOR DE CONCRETO [4.25] |  | 28.36 | m3 |  | 0 |  | Interferencias |
| A1880 |  | Encofrado y Desencofrado Caravista | 16d | 2024-08-17 | 2024-09-05 | A1870 SS | 316d | 0d | Capataz [5.14 h]; Operario [25.73 h]; Oficial [25.73 h]; Peon [51.45 h]; ALAMBRE NEGRO #8 [10.29]; CLAVOS PARA MADERA CON CABEZA DE 3" [10.29]; LACA DESMOLDEADORA [1.54]; MADERA TORNILLO INCLUYE CORTE PARA ENCOFRADO [154.35]; TRIPLAY DE 19 mm PARA ENCOFRADO [4.48] |  | 51.45 | m2 |  | 0 |  | Interferencias |
| A1890 |  | Encofrado y Desencofrado Cara Oculta | 16d | 2024-08-17 | 2024-09-05 | A1880 SS | 316d | 0d | Capataz [6.09 h]; Operario [60.88 h]; Oficial [60.88 h]; ALAMBRE NEGRO #8 [27.39]; CLAVOS PARA MADERA CON CABEZA DE 3" [19.18]; MADERA TORNILLO INCLUYE CORTE PARA ENCOFRADO [456.55] |  | 91.31 | m2 |  | 0 |  | Interferencias |
| A1900 |  | Acero de refuerzo f'y=4200kg/cm2 | 16d | 2024-08-17 | 2024-09-05 | A1890 SS | 316d | 0d | Capataz [6.89 h]; Operario [69.45 h]; Oficial [69.45 h]; Peon [34.73 h]; ALAMBRE NEGRO #16 [143.5]; ACERO CORRUGADO fy = 4200 kg/cm2 GRADO 60 [3013.44] |  | 2869.94 | kg |  | 0 |  | Interferencias |
| A1920 |  | Emboquillado de piedra e=0.30m | 16d | 2024-08-17 | 2024-09-05 | A1900 SS | 316d | 0d | Capataz [4.04 h]; Operario [11.66 h]; Oficial [23.32 h]; Peon [38.13 h]; Peon - Vigia [0.04 h]; Operador equipo Pesado [0.06 h]; Operador equipo Liviano [8.22 h]; Cisterna 5000 gln [0.1 h]; Volquete 15 m3 [0.36 h]; Excavadora Cat 336 [0.06 h]; Retroexcavadora sobre llantas 94 hp [7.76 h]; Zaranda estatica [0.78 h]; Petroleo [21.28 gln]; ARENA GRUESA [3.37]; CEMENTO PORTLAND TIPO I (42.5 kg) [32.81] |  | 27.9 | m2 |  | 0 |  | Interferencias |
| A1940 |  | Cama de arena e=0.20m | 16d | 2024-08-17 | 2024-09-05 | A1920 SS | 316d | 0d | Capataz [0.08 h]; Operario [0.39 h]; Oficial [0.77 h]; Peon [1.56 h]; Peon - Vigia [0.01 h]; Operador equipo Liviano [0.07 h]; Cisterna 5000 gln [0.03 h]; Volquete 22 m3 [0.04 h]; Petroleo [0.62 gln]; ARENA GRUESA [2.13] |  | 9.68 | m2 |  | 0 |  | Interferencias |
| A1950 |  | Tubería HDPE Corrugada Ø=900mm (Suministro e instalación) | 16d | 2024-08-17 | 2024-09-05 | A1940 SS | 316d | 0d | Capataz [2.83 h]; Operario [2.83 h]; Oficial [5.67 h]; Peon [5.67 h]; Operador equipo Pesado [1.42 h]; Operador equipo Liviano [0.71 h]; Camion grua 20 ton [0.71 h]; Excavadora Cat 336 [1.42 h]; Petroleo [14.88 gln]; Tubería HDPE Corrugado de 900 mm [9.35] |  | 8.5 | m |  | 0 |  | Interferencias |
| A1980 |  | Sello en juntas | 16d | 2024-08-17 | 2024-09-05 | A1950 SS | 316d | 0d | Capataz [1 h]; Operario [4 h]; Peon [1 h]; TECNOPOR DE 1/2"X4X8' [0.68]; SELLADOR ELASTICO POLIURETANO SIKAFLEX 1A [3.43] |  | 12 | m |  | 0 |  | Interferencias |
| A1990 |  | Waterstop (anillos de estanqueidad) | 16d | 2024-08-17 | 2024-09-05 | A1980 SS | 316d | 0d | Capataz [0.2 h]; Operario [2 h]; Peon [4 h]; WATER STOP (anillos de estanqueidad); DN=900mm [1.82] |  | 2 | und |  | 0 |  | Interferencias |
| A2000 |  | Pintura bituminosa | 16d | 2024-08-17 | 2024-09-05 | A1990 SS | 316d | 0d | Capataz [1.83 h]; Operario [18.26 h]; Peon [36.52 h]; PINTURA ASFALTICA [36.52]; IMPRIMANTE ASFALTICO [15.98] |  | 91.31 | m2 |  | 0 |  | Interferencias |
| A2010 |  | Suministro e Instalación de geotextil | 16d | 2024-08-17 | 2024-09-05 | A2000 SS | 316d | 10d | Capataz [0.13 h]; Oficial [1.28 h]; Peon [1.92 h]; Operador equipo Liviano [0.16 h]; Camion grua 20 ton [0.16 h]; Petroleo [0.63 gln]; Geotextil no tejido 200gr/m2 [57.6] |  | 48 | m2 |  | 0 |  | Interferencias |

| ID | WBS | Activity | Type | Duration | Start | Finish | Predecessors | Total float | Free float | Resources | RCuad | Cuadrilla | Rendimiento | Metrado | Unidad | Turno | DurCal | Dur. Cal. | AGrupo |
| --- | --- | --- | --- | --- | --- | --- | --- | --- | --- | --- | --- | --- | --- | --- | --- | --- | --- | --- | --- |
|  | 3 | **DI-PR-42-I (Tramo 1)** |  |  | 2024-08-29 | 2024-12-05 |  |  |  |  |  |  |  |  |  |  |  |  |  |
| A10560 |  | Inicio - DE-PR-42-I | milestone | 0d | 2024-08-29 | 2024-08-29 | A1010 | 254d | 0d |  | 0 |  |  |  |  |  |  |  |  |
| A10570 |  | Fin - DE-PR-42-I | milestone | 0d | 2024-12-05 | 2024-12-05 | A3040 FF, A10360 FF, A3070 FF, A3170 FF, A3210 FF | 254d |  |  | 0 |  |  |  |  |  |  |  |  |
|  | 1 | **EXCAVACIONES** |  |  | 2024-08-29 | 2024-09-27 |  |  |  |  |  |  |  |  |  |  |  |  |  |
| A2830 |  | Desbroce |  | 15d | 2024-08-29 | 2024-09-16 | A10560 SS | 254d | 0d | Capataz [0.14 h]; Peon [28.6 h]; Operador equipo Pesado [21.45 h]; Excavadora Cat 336 [7.15 h]; Tractor D6 [14.3 h]; Petroleo [160.88 gln] | 1 | 1 | 0.8 | 1.43 | ha | 1 | 1.43 | 1.7875 | Excavacion |
| A2890 |  | Conformacion de Material Excedente en DMO |  | 15d | 2024-08-29 | 2024-09-16 | A2830 SS | 277d | 23d | Capataz [3.74 h]; Peon [35.56 h]; Operador equipo Pesado [39.3 h]; Excavadora Cat 336 [3.74 h]; Tractor D6 [35.56 h]; Petroleo [280.71 gln] | 1 | 1 | 1050 | 4678.48 | m3 | 1 | 4678.48 | 4.45569523809524 | Excavacion |
| A2840 |  | Remocion de Dique Existente |  | 23d | 2024-09-02 | 2024-09-27 | A2830 SS+2d | 254d | 0d | Capataz [11.68 h]; Peon [58.42 h]; Operador equipo Pesado [87.63 h]; Excavadora Cat 336 [58.42 h]; Tractor D8 [29.21 h]; Petroleo [774.09 gln] | 1 | 1 | 800 | 5842.21 | m3 | 1 | 5842.21 | 7.3027625 | Excavacion |
| A2850 |  | Excavacion de Cimentacion |  | 23d | 2024-09-02 | 2024-09-27 | A2840 SS | 254d | 0d | Capataz [37.59 h]; Peon [375.87 h]; Operador equipo Pesado [250.58 h]; Operador equipo Liviano [208.82 h]; Excavadora Cat 336 [167.05 h]; Retroexcavadora sobre llantas 94 hp [208.82 h]; Tractor D8 [83.53 h]; Petroleo [2731.34 gln] | 1 | 1 | 900 | 20881.83 | m3 | 1 | 20881.83 | 23.2020333333333 | Excavacion |
| A2870 |  | Excavacion de Uña |  | 23d | 2024-09-02 | 2024-09-27 | A2850 SS | 254d | 0d | Capataz [28.12 h]; Peon [140.6 h]; Operador equipo Pesado [140.6 h]; Excavadora Cat 336 [140.6 h]; Petroleo [1588.83 gln] | 1 | 1 | 500 | 8787.77 | m3 | 1 | 8787.77 | 17.57554 | Excavacion |
| A2880 |  | Conformacion de Material Excedente en DME |  | 23d | 2024-09-02 | 2024-09-27 | A2840 SS | 267d | 13d | Capataz [24.91 h]; Peon [236.68 h]; Operador equipo Pesado [261.6 h]; Excavadora Cat 336 [24.91 h]; Tractor D6 [236.68 h]; Petroleo [1868.56 gln] | 1 | 1 | 1050 | 31142.68 | m3 | 1 | 31142.68 | 29.6596952380952 | Excavacion |
| A2860 |  | Perfilado y Conformacion de Plataforma de Fundacion |  | 10d | 2024-09-16 | 2024-09-26 | A2850 SS+12d | 276d | 0d | Capataz [3.37 h]; Peon [41.53 h]; Operador equipo Pesado [74.08 h]; Operador equipo Liviano [15.71 h]; Cisterna 5000 gln [15.71 h]; Motoniveladora 140K [37.04 h]; Rodillo liso vibratorio 10 - 12 ton [37.04 h]; Petroleo [318.77 gln] | 1 | 1 | 2400 | 11224.2 | m2 | 1 | 11224.2 | 4.67675 | Excavacion |
|  | 2 | **RELLENOS** |  |  | 2024-09-21 | 2024-10-30 |  |  |  |  |  |  |  |  |  |  |  |  |  |
| A2910 |  | Relleno con Material Granular (incluye extraccion de material, zarandeo y combinado) |  | 31d | 2024-09-21 | 2024-10-28 | A2860 SS+5d | 278d | 0d | Capataz [32.97 h]; Operario [8.27 h]; Oficial [24.12 h]; Peon [86.45 h]; Peon - Vigia [5.13 h]; Operador equipo Pesado [127.23 h]; Operador equipo Liviano [49.75 h]; Cisterna 5000 gln [16.31 h]; Volquete 15 m3 [25.05 h]; Cargador Frontal 966 [37.98 h]; Chancadora Primaria [18.76 h]; Excavadora Cat 336 [29.36 h]; Retroexcavadora sobre llantas 58 hp [4.19 h]; Rodillo liso vibratorio 10 - 12 ton [15.85 h]; Rodillo liso vibratorio 0.80 - 1.10 ton [8.27 h]; Tractor D6 [21.09 h]; Petroleo [902.17 gln] | 1 | 1 | 560 | 1165.14 | m3 | 1 | 1165.14 | 2.08060714285714 | Relleno |
| A2950 |  | Relleno con Material Seleccionado (incluye extraccion de material, zarandeo y combinado) |  | 31d | 2024-09-21 | 2024-10-28 | A2910 SS | 278d | 8d | Capataz [49.62 h]; Oficial [246.6 h]; Peon [506.53 h]; Operador equipo Pesado [739.8 h]; Operador equipo Liviano [51.84 h]; Cisterna 5000 gln [51.84 h]; Excavadora Cat 336 [493.2 h]; Rodillo liso vibratorio 10 - 12 ton [246.6 h]; Petroleo [7541.67 gln] | 1 | 1 | 240 | 7405.41 | m3 | 1 | 7405.41 | 30.855875 | Relleno |
| A3220 |  | Relleno Estructural |  | 31d | 2024-09-21 | 2024-10-28 | A2910 SS | 278d | 8d | Capataz [29.96 h]; Operario [108.1 h]; Oficial [108.1 h]; Peon [258.56 h]; Peon - Vigia [3.33 h]; Operador equipo Pesado [114.3 h]; Operador equipo Liviano [140.4 h]; Cisterna 5000 gln [15.96 h]; Volquete 15 m3 [16.34 h]; Cargador Frontal 966 [25.04 h]; Chancadora Primaria [12.18 h]; Excavadora Cat 336 [19.44 h]; Retroexcavadora sobre llantas 58 hp [54.01 h]; Rodillo liso vibratorio 0.80 - 1.10 ton [108.1 h]; Tractor D6 [3.63 h]; Petroleo [805.64 gln] | 1 | 1 | 56 | 756.47 | m3 | 1 | 756.47 | 13.5083928571429 | Relleno |
| A2940 |  | Perfilado de Talud Dique |  | 28d | 2024-09-27 | 2024-10-30 | A2910 SS+3d, A2860 | 276d | 6d | Capataz [1.99 h]; Peon [9.85 h]; Operador equipo Pesado [2.94 h]; Excavadora Cat 336 [2.94 h]; Petroleo [24.96 gln] | 1 | 1 | 700 | 863.84 | m2 | 1 | 863.84 | 1.23405714285714 | Relleno |
|  | 3 | **GEOTEXTIL** |  |  | 2024-09-06 | 2024-11-16 |  |  |  |  |  |  |  |  |  |  |  |  |  |
| A2970 |  | Instalacion de Geotextil 400gr/m2 |  | 60d | 2024-09-06 | 2024-11-16 | A3000 SS | 270d | 0d | Capataz [42.13 h]; Oficial [416.66 h]; Peon [624.21 h]; Operador equipo Liviano [51.5 h]; Camion grua 20 ton [51.5 h]; Petroleo [205.99 gln]; Geotextil de 400 gr/m2 [17946 m2] | 1 | 1 | 600 | 15605.19 | m2 | 1 | 15605.19 | 26.00865 | Geotextil |
| A2980 |  | Zanja de Anclaje |  | 8d | 2024-11-08 | 2024-11-16 | A2970 FF, A2940, A2950, A3220 | 270d | 0d | Capataz [3.88 h]; Oficial [19.38 h]; Peon [58.26 h]; Operador equipo Pesado [19.38 h]; Operador equipo Liviano [0.54 h]; Cisterna 5000 gln [0.54 h]; Retroexcavadora sobre llantas 58 hp [19.38 h]; Petroleo [69.03 gln] | 1 | 1 | 32 | 77.5 | m3 | 1 | 77.5 | 2.421875 | Geotextil |
|  | 4 | **COLOCACION DE ROCA** |  |  | 2024-09-02 | 2024-11-29 |  |  |  |  |  |  |  |  |  |  |  |  |  |
| A3020 |  | Extraccion de Rocas Reutilizables |  | 21d | 2024-09-02 | 2024-09-25 | A2840 SS | 269d | 15d | Capataz [111.14 h]; Peon [222.07 h]; Operador equipo Pesado [222.07 h]; Excavadora Cat 336 [222.07 h]; Petroleo [1887.74 gln] | 1 | 1 | 160 | 1974 | m3 | 1 | 1974 | 12.3375 | Roca |
| A10580 |  | Suministro de Roca |  | 66d | 2024-09-06 | 2024-11-23 | A3000 SS | 264d | 0d |  | 0 |  |  |  |  |  |  |  | Roca |
| A3000 |  | Colocacion de Roca en Uña |  | 32d | 2024-09-06 | 2024-10-14 | A2870 SS+4d | 254d | 0d | Capataz [125.67 h]; Oficial [251.33 h]; Peon [251.33 h]; Operador equipo Pesado [276.81 h]; Excavadora Cat 336 [251.33 h]; Tractor D6 [25.48 h]; Petroleo [2314.7 gln] | 1 | 1 | 280 | 8787.77 | m3 | 1 | 8787.77 | 31.3848928571429 | Roca |
| A3010 |  | Colocacion de Roca en Talud |  | 34d | 2024-10-15 | 2024-11-23 | A3000, A2880, A2890, A3020 | 254d | 0d | Capataz [135.22 h]; Oficial [271.09 h]; Peon [271.09 h]; Operador equipo Pesado [568.83 h]; Excavadora Cat 336 [541.52 h]; Tractor D6 [27.3 h]; Petroleo [4794.39 gln] | 1 | 1 | 192 | 6500.87 | m3 | 1 | 6500.87 | 33.8586979166667 | Roca |
| A3090 |  | Rehabilitacion de Enrocados de Proteccion Existentes |  | 5d | 2024-10-15 | 2024-10-19 | A3000 | 288d | 29d |  | 1 | 1 |  | 4244.67 | m3 | 1 | 4244.67 |  | Roca |
| A3030 |  | Proteccion de Talud con Colchon Reno 6m Largo x e=0.30cm |  | 13d | 2024-11-09 | 2024-11-23 | A3040 SS | 259d | 0d | Capataz [7.37 h]; Oficial [60.62 h]; Peon [376.69 h]; Peon - Vigia [0.58 h]; Operador equipo Pesado [0.85 h]; Operador equipo Liviano [48.07 h]; Volquete 15 m3 [5.64 h]; Excavadora Cat 336 [0.85 h]; Retroexcavadora sobre llantas 94 hp [42.43 h]; Zaranda estatica [12.12 h]; Petroleo [129.09 gln]; ALAMBRE NEGRO #8 [454.65]; GAVION COLCHON 8x10 cm [303.1] | 2 | 2 | 40 | 303.1 | m2 | 1 | 151.55 | 3.78875 | Roca |
| A3040 |  | Malla Gavion de 1m x 1m x 5m |  | 13d | 2024-11-09 | 2024-11-23 | A3010 FF | 259d | 0d | Capataz [46.7 h]; Operario [200 h]; Peon [1267.15 h]; Peon - Vigia [3.15 h]; Operador equipo Pesado [4.65 h]; Operador equipo Liviano [193.55 h]; Volquete 15 m3 [31.05 h]; Excavadora Cat 336 [4.65 h]; Retroexcavadora sobre llantas 94 hp [162.5 h]; Petroleo [532.8 gln]; ALAMBRE NEGRO #8 [500]; GAVION TIPO CAJA DE 1x1x5 m [100] | 2 | 2 | 4 | 100 | und | 1 | 50 | 12.5 | Roca |
| A3070 |  | Colocación de Roca en Corona |  | 5d | 2024-11-25 | 2024-11-29 | A3010, A3030, A3090 | 259d | 5d | Capataz [18.34 h]; Oficial [36.57 h]; Peon [36.57 h]; Operador equipo Pesado [40.19 h]; Excavadora Cat 336 [36.57 h]; Tractor D6 [3.62 h]; Petroleo [404.14 gln] | 1 | 1 | 280 | 1098.21 | m3 | 1 | 1098.21 | 3.92217857142857 | Roca |

| ID | WBS | Activity | Duration | Start | Finish | Predecessors | Total float | Free float | Resources | Cuadrilla | Metrado | Unidad | Turno | RCuad | DurCal | AGrupo |
| --- | --- | --- | --- | --- | --- | --- | --- | --- | --- | --- | --- | --- | --- | --- | --- | --- |
|  | 5 | **TRANSPORTES** |  | 2024-08-29 | 2024-11-23 |  |  |  |  |  |  |  |  |  |  |  |
| A3100 |  | Transporte de Material Organico (a DMO) D<=1km | 15d | 2024-08-29 | 2024-09-16 | A2830 SS | 313d | 0d | Peon - Vigia [26.2 h]; Operador equipo Liviano [130.06 h]; Volquete 15 m3 [130.06 h]; Petroleo [363.99 gln] | 1 | 4678.48 | m3k | 1 | 1 | 4678.48 | Transportes |
| A3110 |  | Transporte de Material Organico (a DMO) D>1km | 15d | 2024-08-29 | 2024-09-16 | A3100 SS | 313d | 43d | Operador equipo Liviano [523.75 h]; Volquete 15 m3 [523.75 h]; Petroleo [1466.49 gln] | 1 | 47613.32 | m3k | 1 | 1 | 47613.32 | Transportes |
| A3120 |  | Transporte de Material Excedente D<=1km | 23d | 2024-09-02 | 2024-09-27 | A2840 SS | 303d | 0d | Peon - Vigia [158.83 h]; Operador equipo Liviano [791.02 h]; Volquete 22 m3 [339.46 h]; Volquete 15 m3 [451.57 h]; Petroleo [2650.24 gln] | 1 | 31142.68 | m3k | 1 | 1 | 31142.68 | Transportes |
| A3130 |  | Transporte de Material Excedente D>1km | 23d | 2024-09-02 | 2024-09-27 | A3120 SS | 303d | 33d | Operador equipo Liviano [3103.74 h]; Volquete 22 m3 [1321.39 h]; Volquete 15 m3 [1782.35 h]; Petroleo [10386.8 gln] | 1 | 307300.95 | m3k | 1 | 1 | 307300.95 | Transportes |
| A3160 |  | Transporte de Roca D<=1km | 66d | 2024-09-06 | 2024-11-23 | A10580 SS | 264d | 0d | Peon [220.75 h]; Peon - Vigia [102.43 h]; Operador equipo Pesado [220.75 h]; Operador equipo Liviano [512.15 h]; Volquete 22 m3 [512.15 h]; Excavadora Cat 336 [220.75 h]; Petroleo [3977.09 gln]; Peaje local [803.54] | 1 | 17660.25 | m3k | 1 | 1 | 17660.25 | Transportes |
| A3170 |  | Transporte de Roca D>1km | 66d | 2024-09-06 | 2024-11-23 | A3160 SS | 264d | 10d | Operador equipo Liviano [342.24 h]; Volquete 22 m3 [342.24 h]; Petroleo [1401.88 gln] | 1 | 32907.96 | m3k | 1 | 1 | 32907.96 | Transportes |
| A3140 |  | Transporte de Material de Prestamo (Afirmado) D<=1km | 31d | 2024-09-21 | 2024-10-28 | A3180 SS | 278d | 0d | Peon - Vigia [19.75 h]; Operador equipo Liviano [98.28 h]; Volquete 22 m3 [98.28 h]; Petroleo [402.98 gln] | 1 | 4702.26 | m3k | 1 | 1 | 4702.26 | Transportes |
| A3150 |  | Transporte de Material de Prestamo (Afirmado) D>1km | 31d | 2024-09-21 | 2024-10-28 | A3140 SS | 278d | 8d | Operador equipo Liviano [109.07 h]; Volquete 22 m3 [109.07 h]; Petroleo [446.81 gln] | 1 | 13141.41 | m3k | 1 | 1 | 13141.41 | Transportes |
| A3180 |  | Transporte de Material de Prestamo Cantera de Rio (Cuerpo de Terraplen) D<=1km | 31d | 2024-09-21 | 2024-10-28 | A2910 SS | 278d | 0d | Peon - Vigia [53.8 h]; Operador equipo Liviano [267.7 h]; Volquete 22 m3 [267.7 h]; Petroleo [1097.68 gln] | 1 | 12808.41 | m3k | 1 | 1 | 12808.41 | Transportes |
| A3190 |  | Transporte de Material de Prestamo Cantera de Rio (Cuerpo de Terraplen) D>1km | 31d | 2024-09-21 | 2024-10-28 | A3180 SS | 278d | 8d | Operador equipo Liviano [662.91 h]; Volquete 22 m3 [662.91 h]; Petroleo [2715.55 gln] | 1 | 79869.02 | m3k | 1 | 1 | 79869.02 | Transportes |
| A3200 |  | Transporte de Material Seleccionado para Zanja D<=1km | 8d | 2024-11-08 | 2024-11-16 | A2980 SS, A3110, A3130, A3150 | 270d | 0d | Peon - Vigia [0.43 h]; Operador equipo Liviano [2.15 h]; Volquete 15 m3 [2.15 h]; Petroleo [6.03 gln] | 1 | 77.5 | m3k | 1 | 1 | 77.5 | Transportes |
| A3210 |  | Transporte de Material Seleccionado para Zanja D>1km | 8d | 2024-11-08 | 2024-11-16 | A3200 SS, A3190 | 270d | 16d | Operador equipo Liviano [5.33 h]; Volquete 15 m3 [5.33 h]; Petroleo [14.93 gln] | 1 | 484.76 | m3k | 1 | 1 | 484.76 | Transportes |
|  | 6 | **INTERFERENCIAS** |  | 2024-09-11 | 2024-09-18 |  |  |  |  |  |  |  |  |  |  |  |
|  | 1 | **CRUCE DI-PR-42-5-I-INT01** |  | 2024-09-11 | 2024-09-18 |  |  |  |  |  |  |  |  |  |  |  |
| A3230 |  | Trazo y replanteo de interferencia | 7d | 2024-09-11 | 2024-09-18 | A2830 SS+10d | 284d | 0d | Capataz [0.06 h]; Peon [1.26 h]; Topografo [0.63 h]; GPS [0.63 h]; MADERA TORNILLO [0.63]; PINTURA ESMALTE [0.06] |  | 31.5 | m2 |  | 0 |  | Interferencias |
| A3240 |  | Desvío provisional con tubería | 7d | 2024-09-11 | 2024-09-18 | A3230 SS | 284d | 0d | Capataz [2.32 h]; Operario [4 h]; Oficial [4 h]; Peon [25.6 h]; Operador equipo Pesado [1.6 h]; Operador equipo Liviano [1 h]; Camion grua 20 ton [1 h]; Excavadora Cat 336 [1.6 h]; Petroleo [17.6 gln]; TUBERIA CORRUGADA HDPE D=630 mm [12.6] |  | 12 | m |  | 0 |  | Interferencias |
| A3260 |  | Limpieza de terreno manual | 7d | 2024-09-11 | 2024-09-18 | A3240 SS | 284d | 0d | Capataz [0.01 h]; Oficial [0.25 h]; Peon [0.5 h]; Operador equipo Pesado [0.09 h]; Excavadora Cat 336 [0.03 h]; Tractor D6 [0.06 h]; Petroleo [0.71 gln] |  | 31.5 | m2 |  | 0 |  | Interferencias |
| A3270 |  | Excavaciones no clasificada para estructuras | 7d | 2024-09-11 | 2024-09-18 | A3260 SS | 284d | 0d | Capataz [0.02 h]; Peon [0.1 h]; Operador equipo Pesado [0.1 h]; Excavadora Cat 336 [0.1 h]; Petroleo [0.82 gln] |  | 3.03 | m3 |  | 0 |  | Interferencias |
| A3320 |  | Concreto de Nivelacion (f'c=100 kg/cm2) | 7d | 2024-09-11 | 2024-09-18 | A3270 SS | 284d | 0d | Capataz [0.6 h]; Operario [0.67 h]; Oficial [1.06 h]; Peon [5.59 h]; Operador equipo Liviano [0.71 h]; Cisterna 5000 gln [0.04 h]; Carmix 4.0 m3 [0.67 h]; Petroleo [3.51 gln]; PIEDRA CHANCADA [1.09]; ARENA GRUESA [0.92]; CEMENTO PORTLAND TIPO I (42.5 kg) [10.02] |  | 1.59 | m3 |  | 0 |  | Interferencias |
| A3340 |  | Concreto Clase C (f'c=280 kg/cm2) Premezclado - Cimientos reforzados | 7d | 2024-09-11 | 2024-09-18 | A3320 SS | 284d | 0d | Capataz [1.22 h]; Operario [3.52 h]; Oficial [4.89 h]; Peon [11.35 h]; Operador equipo Liviano [2.15 h]; Carmix 4.0 m3 [2.15 h]; Petroleo [11.46 gln]; PIEDRA CHANCADA [3.5]; ARENA GRUESA [2.96]; CEMENTO PORTLAND TIPO I (42.5 kg) [56.56]; PLASTIMENT TM-40 - PLASTIFICANTE [11.58]; ADITIVO CURADOR DE CONCRETO [0.77] |  | 5.13 | m3 |  | 0 |  | Interferencias |
| A3350 |  | Concreto Clase C (f'c=280 kg/cm2) Premezclado - Muros de contencion | 7d | 2024-09-11 | 2024-09-18 | A3340 SS | 284d | 0d | Capataz [1.12 h]; Operario [3.23 h]; Oficial [4.49 h]; Peon [11.68 h]; Operador equipo Liviano [1.98 h]; Carmix 4.0 m3 [1.98 h]; Petroleo [10.52 gln]; PIEDRA CHANCADA [3.21]; ARENA GRUESA [2.72]; CEMENTO PORTLAND TIPO I (42.5 kg) [51.93]; PLASTIMENT TM-40 - PLASTIFICANTE [10.63]; ADITIVO CURADOR DE CONCRETO [0.71] |  | 4.71 | m3 |  | 0 |  | Interferencias |
| A3360 |  | Encofrado y Desencofrado Caravista | 7d | 2024-09-11 | 2024-09-18 | A3350 SS | 284d | 0d | Capataz [1.86 h]; Operario [9.3 h]; Oficial [9.3 h]; Peon [18.61 h]; ALAMBRE NEGRO #8 [3.72]; CLAVOS PARA MADERA CON CABEZA DE 3" [3.72]; LACA DESMOLDEADORA [0.56]; MADERA TORNILLO INCLUYE CORTE PARA ENCOFRADO [55.83]; TRIPLAY DE 19 mm PARA ENCOFRADO [1.62] |  | 18.61 | m2 |  | 0 |  | Interferencias |
| A3370 |  | Encofrado y Desencofrado Cara Oculta | 7d | 2024-09-11 | 2024-09-18 | A3360 SS | 284d | 0d | Capataz [1.14 h]; Operario [11.42 h]; Oficial [11.42 h]; ALAMBRE NEGRO #8 [5.14]; CLAVOS PARA MADERA CON CABEZA DE 3" [3.6]; MADERA TORNILLO INCLUYE CORTE PARA ENCOFRADO [85.65] |  | 17.13 | m2 |  | 0 |  | Interferencias |
| A3380 |  | Acero de refuerzo f'y=4200kg/cm2 | 7d | 2024-09-11 | 2024-09-18 | A3370 SS | 284d | 0d | Capataz [1.46 h]; Operario [14.75 h]; Oficial [14.75 h]; Peon [7.38 h]; ALAMBRE NEGRO #16 [30.48]; ACERO CORRUGADO fy = 4200 kg/cm2 GRADO 60 [640.15] |  | 609.67 | kg |  | 0 |  | Interferencias |
| A3400 |  | Emboquillado de piedra e=0.30m | 7d | 2024-09-11 | 2024-09-18 | A3380 SS | 284d | 0d | Capataz [2.61 h]; Operario [7.54 h]; Oficial [15.09 h]; Peon [24.67 h]; Peon - Vigia [0.02 h]; Operador equipo Pesado [0.04 h]; Operador equipo Liviano [5.32 h]; Cisterna 5000 gln [0.07 h]; Volquete 15 m3 [0.23 h]; Excavadora Cat 336 [0.04 h]; Retroexcavadora sobre llantas 94 hp [5.02 h]; Zaranda estatica [0.51 h]; Petroleo [13.77 gln]; ARENA GRUESA [2.18]; CEMENTO PORTLAND TIPO I (42.5 kg) [21.23] |  | 18.05 | m2 |  | 0 |  | Interferencias |
| A3460 |  | Sello en juntas | 7d | 2024-09-11 | 2024-09-18 | A3400 SS | 284d | 0d | Capataz [0.57 h]; Operario [2.27 h]; Peon [0.57 h]; TECNOPOR DE 1/2"X4X8' [0.39]; SELLADOR ELASTICO POLIURETANO SIKAFLEX 1A [1.95] |  | 6.82 | m |  | 0 |  | Interferencias |
| A3480 |  | Pintura bituminosa | 7d | 2024-09-11 | 2024-09-18 | A3460 SS | 284d | 21d | Capataz [0.34 h]; Operario [3.43 h]; Peon [6.85 h]; PINTURA ASFALTICA [6.85]; IMPRIMANTE ASFALTICO [3] |  | 17.13 | m2 |  | 0 |  | Interferencias |

| ID | WBS | Activity | Type | Duration | Start | Finish | Predecessors | Total float | Free float | Resources | Metrado | Unidad | RCuad | AGrupo | Cuadrilla | Rendimiento | Turno | DurCal | Dur. Cal. |
| --- | --- | --- | --- | --- | --- | --- | --- | --- | --- | --- | --- | --- | --- | --- | --- | --- | --- | --- | --- |
|  | 7 | **OBRAS CIVILES** |  |  | 2024-10-15 | 2024-11-13 |  |  |  |  |  |  |  |  |  |  |  |  |  |
| A10170 |  | Concreto de Nivelacion (f'c=100 kg/cm2) |  | 25d | 2024-10-15 | 2024-11-13 | A3000, A3480 | 263d | 0d | Capataz [9.06 h]; Operario [10.11 h]; Oficial [16.04 h]; Peon [84.53 h]; Operador equipo Liviano [10.75 h]; Cisterna 5000 gln [0.64 h]; Carmix 4.0 m3 [10.11 h]; Petroleo [53.09 gln]; PIEDRA CHANCADA [16.42]; ARENA GRUESA [13.89]; CEMENTO PORTLAND TIPO I (42.5 kg) [151.58] | 24.06 | m3 | 0 | Obras Civiles |  |  |  |  |  |
| A10180 |  | Concreto Clase C (f'c=280 kg/cm2) Premezclado - Cimientos reforzados |  | 25d | 2024-10-15 | 2024-11-13 | A10170 SS | 263d | 0d | Capataz [35.98 h]; Operario [103.67 h]; Oficial [143.92 h]; Peon [334.14 h]; Operador equipo Liviano [63.41 h]; Carmix 4.0 m3 [63.41 h]; Petroleo [337.16 gln]; PIEDRA CHANCADA [103.04]; ARENA GRUESA [87.19]; CEMENTO PORTLAND TIPO I (42.5 kg) [1664.44]; PLASTIMENT TM-40 - PLASTIFICANTE [340.81]; ADITIVO CURADOR DE CONCRETO [22.65] | 150.97 | m3 | 0 | Obras Civiles |  |  |  |  |  |
| A10190 |  | Concreto Clase C (f'c=280 kg/cm2) Premezclado - Muros de contencion |  | 25d | 2024-10-15 | 2024-11-13 | A10180 SS | 263d | 0d | Capataz [30.21 h]; Operario [87.07 h]; Oficial [120.87 h]; Peon [314.44 h]; Operador equipo Liviano [53.25 h]; Carmix 4.0 m3 [53.25 h]; Petroleo [283.16 gln]; PIEDRA CHANCADA [86.53]; ARENA GRUESA [73.22]; CEMENTO PORTLAND TIPO I (42.5 kg) [1397.86]; PLASTIMENT TM-40 - PLASTIFICANTE [286.23]; ADITIVO CURADOR DE CONCRETO [19.02] | 126.79 | m3 | 0 | Obras Civiles |  |  |  |  |  |
| A10200 |  | Encofrado y Desencofrado Caravista |  | 25d | 2024-10-15 | 2024-11-13 | A10190 SS | 263d | 0d | Capataz [58.96 h]; Operario [294.82 h]; Oficial [294.82 h]; Peon [589.64 h]; ALAMBRE NEGRO #8 [117.93]; CLAVOS PARA MADERA CON CABEZA DE 3" [117.93]; LACA DESMOLDEADORA [17.69]; MADERA TORNILLO INCLUYE CORTE PARA ENCOFRADO [1768.92]; TRIPLAY DE 19 mm PARA ENCOFRADO [51.3] | 589.64 | m2 | 1 | Obras Civiles | 1 | 16 | 1 | 589.64 | 36.8525 |
| A10210 |  | Encofrado y Desencofrado Cara Oculta |  | 25d | 2024-10-15 | 2024-11-13 | A10200 SS | 263d | 0d | Capataz [12.5 h]; Operario [124.97 h]; Oficial [124.97 h]; ALAMBRE NEGRO #8 [56.23]; CLAVOS PARA MADERA CON CABEZA DE 3" [39.36]; MADERA TORNILLO INCLUYE CORTE PARA ENCOFRADO [937.25] | 187.45 | m2 | 1 | Obras Civiles | 1 | 12 | 1 | 187.45 | 15.6208333333333 |
| A10220 |  | Acero de refuerzo f'y=4200kg/cm2 |  | 25d | 2024-10-15 | 2024-11-13 | A10210 SS | 263d | 0d | Capataz [37.86 h]; Operario [381.77 h]; Oficial [381.77 h]; Peon [190.88 h]; ALAMBRE NEGRO #16 [788.78]; ACERO CORRUGADO fy = 4200 kg/cm2 GRADO 60 [16564.4] | 15775.58 | kg | 1 | Obras Civiles | 1 | 330 | 1 | 15775.58 | 47.8047878787879 |
| A10230 |  | Junta de dilatación |  | 25d | 2024-10-15 | 2024-11-13 | A10220 SS | 263d | 0d | Capataz [5.31 h]; Operario [21.26 h]; Peon [21.26 h]; MATERIAL DE RESPALDO 1/2" PARA JUNTAS 10 mm [63.8]; TECNOPOR DE 1/2"X4X8' [3.64]; SELLADOR ELASTICO POLIURETANO SIKAFLEX 1A [18.25] | 63.8 | m | 0 | Obras Civiles |  |  |  |  |  |
| A10240 |  | Pintura bituminosa |  | 25d | 2024-10-15 | 2024-11-13 | A10230 SS | 263d | 9d | Capataz [12.45 h]; Operario [124.51 h]; Peon [249.01 h]; PINTURA ASFALTICA [249.01]; IMPRIMANTE ASFALTICO [108.94] | 622.53 | m2 | 0 | Obras Civiles |  |  |  |  |  |
|  | 8 | **VIA CARROZABLE** |  |  | 2024-11-25 | 2024-12-05 |  |  |  |  |  |  |  |  |  |  |  |  |  |
| A10350 |  | Material de Base para pavimento |  | 10d | 2024-11-25 | 2024-12-05 | A3010, A10180, A10240 | 254d | 0d |  | 131.47 | m3 | 0 | Via |  |  |  |  |  |
| A10360 |  | Pavimento Emboquillado e=0.25m |  | 10d | 2024-11-25 | 2024-12-05 | A10350 SS | 254d | 0d |  | 219.11 | m3 | 1 | Via | 1 | 30 | 1 | 219.11 | 7.30366666666667 |
|  | 12 | **ENR-PTE-42-39** |  |  | 2024-09-18 | 2024-10-03 |  |  |  |  |  |  |  |  |  |  |  |  |  |
| A10810 |  | Inicio - ENR-PTE-42-39 | milestone | 0d | 2024-09-18 | 2024-09-18 | A10540 | 306d | 0d |  |  |  | 0 |  |  |  |  |  |  |
| A10820 |  | Fin - ENR-PTE-42-39 | milestone | 0d | 2024-10-03 | 2024-10-03 | A9810 FF, A9520 FF, A9530 FF, A9750 FF, A9770 FF | 306d |  |  |  |  | 0 |  |  |  |  |  |  |
|  | 1 | **EXCAVACIONES** |  |  | 2024-09-18 | 2024-09-20 |  |  |  |  |  |  |  |  |  |  |  |  |  |
| A9470 |  | Desbroce |  | 1d | 2024-09-18 | 2024-09-18 | A10810 SS | 306d | 0d | Capataz [0.01 h]; Peon [1.6 h]; Operador equipo Pesado [1.2 h]; Excavadora Cat 336 [0.4 h]; Tractor D6 [0.8 h]; Petroleo [9 gln] | 0.08 | ha | 1 | Excavacion | 1 | 0.8 | 1 | 0.08 | 0.1 |
| A9530 |  | Conformacion de Material Excedente en DMO |  | 1d | 2024-09-18 | 2024-09-18 | A9470 SS | 319d | 13d | Capataz [0.2 h]; Peon [1.93 h]; Operador equipo Pesado [2.13 h]; Excavadora Cat 336 [0.2 h]; Tractor D6 [1.93 h]; Petroleo [15.25 gln] | 254.16 | m3 | 1 | Excavacion | 1 | 1050 | 1 | 254.16 | 0.242057142857143 |
| A9490 |  | Excavacion de Cimentacion |  | 2d | 2024-09-19 | 2024-09-20 | A9470 | 306d | 0d | Capataz [1.96 h]; Peon [19.61 h]; Operador equipo Pesado [13.07 h]; Operador equipo Liviano [10.89 h]; Excavadora Cat 336 [8.71 h]; Retroexcavadora sobre llantas 94 hp [10.89 h]; Tractor D8 [4.36 h]; Petroleo [142.47 gln] | 1089.2 | m3 | 1 | Excavacion | 1 | 900 | 1 | 1089.2 | 1.21022222222222 |
| A9520 |  | Conformacion de Material Excedente en DME |  | 2d | 2024-09-19 | 2024-09-20 | A9490 SS | 317d | 11d | Capataz [0.87 h]; Peon [8.28 h]; Operador equipo Pesado [9.15 h]; Excavadora Cat 336 [0.87 h]; Tractor D6 [8.28 h]; Petroleo [65.35 gln] | 1089.2 | m3 | 1 | Excavacion | 1 | 1050 | 1 | 1089.2 | 1.03733333333333 |
|  | 4 | **COLOCACION DE ROCA** |  |  | 2024-09-21 | 2024-10-03 |  |  |  |  |  |  |  |  |  |  |  |  |  |
| A9690 |  | Enrocado Talud Encachado con Concreto |  | 11d | 2024-09-21 | 2024-10-03 | A9490 | 306d | 0d | Capataz [137.63 h]; Operario [164.35 h]; Oficial [487.81 h]; Peon [1763.5 h]; Operador equipo Pesado [68.87 h]; Operador equipo Liviano [164.35 h]; Carmix 4.0 m3 [164.35 h]; Excavadora Cat 336 [62.61 h]; Tractor D8 [6.26 h]; Petroleo [1413.44 gln]; PIEDRA CHANCADA [267.1]; ARENA GRUESA [225.96]; CEMENTO PORTLAND TIPO I (42.5 kg) [3903.34]; PLASTIMENT TM-40 - PLASTIFICANTE [883.37] | 1077.79 | m3 | 1 | Roca | 1 | 100 | 1 | 1077.79 | 10.7779 |
|  | 5 | **TRANSPORTES** |  |  | 2024-09-18 | 2024-10-03 |  |  |  |  |  |  |  |  |  |  |  |  |  |
| A9740 |  | Transporte de Material Organico (a DMO) D<=1km |  | 1d | 2024-09-18 | 2024-09-18 | A9470 SS | 319d | 0d | Peon - Vigia [1.42 h]; Operador equipo Liviano [7.07 h]; Volquete 15 m3 [7.07 h]; Petroleo [19.77 gln] | 254.16 | m3k | 1 | Transportes | 1 |  | 1 | 254.16 |  |
| A9750 |  | Transporte de Material Organico (a DMO) D>1km |  | 1d | 2024-09-18 | 2024-09-18 | A9740 SS | 319d | 13d | Operador equipo Liviano [27.74 h]; Volquete 15 m3 [27.74 h]; Petroleo [77.68 gln] | 2522.02 | m3k | 1 | Transportes | 1 |  | 1 | 2522.02 |  |
| A9760 |  | Transporte de Material Excedente D<=1km |  | 2d | 2024-09-19 | 2024-09-20 | A9490 SS | 317d | 0d | Peon - Vigia [5.55 h]; Operador equipo Liviano [27.67 h]; Volquete 22 m3 [11.87 h]; Volquete 15 m3 [15.79 h]; Petroleo [92.69 gln] | 1089.2 | m3k | 1 | Transportes | 1 |  | 1 | 1089.2 |  |
| A9770 |  | Transporte de Material Excedente D>1km |  | 2d | 2024-09-19 | 2024-09-20 | A9760 SS | 317d | 11d | Operador equipo Liviano [109.16 h]; Volquete 22 m3 [46.47 h]; Volquete 15 m3 [62.69 h]; Petroleo [365.31 gln] | 10808.1 | m3k | 1 | Transportes | 1 |  | 1 | 10808.1 |  |
| A9800 |  | Transporte de Roca D<=1km |  | 11d | 2024-09-21 | 2024-10-03 | A9690 SS | 306d | 0d | Peon [13.47 h]; Peon - Vigia [6.25 h]; Operador equipo Pesado [13.47 h]; Operador equipo Liviano [31.26 h]; Volquete 22 m3 [31.26 h]; Excavadora Cat 336 [13.47 h]; Petroleo [242.72 gln]; Peaje local [49.04] | 1077.79 | m3k | 1 | Transportes | 1 |  | 1 | 1077.79 |  |
| A9810 |  | Transporte de Roca D>1km |  | 11d | 2024-09-21 | 2024-10-03 | A9800 SS | 306d | 0d | Operador equipo Liviano [20.43 h]; Volquete 22 m3 [20.43 h]; Petroleo [83.7 gln] | 1964.78 | m3k | 1 | Transportes | 1 |  | 1 | 1964.78 |  |

| ID | WBS | Activity | Type | Duration | Start | Finish | Predecessors | Total float | Free float | Resources | RCuad | Cuadrilla | Rendimiento | Metrado | Unidad | Turno | DurCal | Dur. Cal. | AGrupo |
| --- | --- | --- | --- | --- | --- | --- | --- | --- | --- | --- | --- | --- | --- | --- | --- | --- | --- | --- | --- |
|  | 1 | **DI-PR-40A-D** |  |  | 2024-08-01 | 2024-10-21 |  |  |  |  |  |  |  |  |  |  |  |  |  |
| A10590 |  | Inicio - DE-PR-40-D | milestone | 0d | 2024-08-01 | 2024-08-01 | A10510 SS | 0d |  |  | 0 |  |  |  |  |  |  |  |  |
| A10600 |  | Fin - DE-PR-40-D | milestone | 0d | 2024-10-21 | 2024-10-21 | A2392 FF, A2221 FF, A2160 FF, A2290 FF, A2410 FF, A2430 FF | 292d |  |  | 0 |  |  |  |  |  |  |  |  |
|  | 1 | **EXCAVACIONES** |  |  | 2024-08-01 | 2024-09-13 |  |  |  |  |  |  |  |  |  |  |  |  |  |
| A2050 |  | Desbroce |  | 15d | 2024-08-01 | 2024-08-19 | A10590 SS | 0d |  | Capataz [0.05 h]; Peon [10.2 h]; Operador equipo Pesado [7.65 h]; Excavadora Cat 336 [2.55 h]; Tractor D6 [5.1 h]; Petroleo [57.38 gln] | 1 | 1 | 0.8 | 0.51 | ha | 1 | 0.51 | 0.6375 | Excavacion |
| A2110 |  | Conformacion de Material Excedente en DMO |  | 15d | 2024-08-01 | 2024-08-19 | A2050 SS | 311d | 19d | Capataz [1.26 h]; Peon [11.95 h]; Operador equipo Pesado [13.21 h]; Excavadora Cat 336 [1.26 h]; Tractor D6 [11.95 h]; Petroleo [94.37 gln] | 1 | 1 | 1050 | 1572.9 | m3 | 1 | 1572.9 | 1.498 | Excavacion |
| A2060 |  | Remocion de Dique Existente |  | 24d | 2024-08-03 | 2024-09-02 | A2050 SS+2d | 0d |  | Capataz [2.53 h]; Peon [12.65 h]; Operador equipo Pesado [18.97 h]; Excavadora Cat 336 [12.65 h]; Tractor D8 [6.32 h]; Petroleo [167.57 gln] | 1 | 1 | 800 | 1264.67 | m3 | 1 | 1264.67 | 1.5808375 | Excavacion |
| A2070 |  | Excavacion de Cimentacion |  | 24d | 2024-08-03 | 2024-09-02 | A2060 SS | 0d |  | Capataz [19 h]; Peon [190.04 h]; Operador equipo Pesado [126.69 h]; Operador equipo Liviano [105.58 h]; Excavadora Cat 336 [84.46 h]; Retroexcavadora sobre llantas 94 hp [105.58 h]; Tractor D8 [42.23 h]; Petroleo [1380.94 gln] | 1 | 1 | 900 | 10557.67 | m3 | 1 | 10557.67 | 11.7307444444444 | Excavacion |
| A2090 |  | Excavacion de Uña |  | 24d | 2024-08-03 | 2024-09-02 | A2070 SS | 292d | 0d | Capataz [15.92 h]; Peon [79.58 h]; Operador equipo Pesado [79.58 h]; Excavadora Cat 336 [79.58 h]; Petroleo [899.21 gln] | 1 | 1 | 500 | 4973.5 | m3 | 1 | 4973.5 | 9.947 | Excavacion |
| A2100 |  | Conformacion de Material Excedente en DME |  | 24d | 2024-08-03 | 2024-09-02 | A2060 SS | 300d | 8d | Capataz [12.6 h]; Peon [119.72 h]; Operador equipo Pesado [132.33 h]; Excavadora Cat 336 [12.6 h]; Tractor D6 [119.72 h]; Petroleo [945.19 gln] | 1 | 1 | 1050 | 15753.23 | m3 | 1 | 15753.23 | 15.0030761904762 | Excavacion |
| A2080 |  | Perfilado y Conformacion de Plataforma de Fundacion |  | 10d | 2024-09-03 | 2024-09-13 | A2070 | 0d |  | Capataz [1.89 h]; Peon [23.32 h]; Operador equipo Pesado [41.59 h]; Operador equipo Liviano [8.82 h]; Cisterna 5000 gln [8.82 h]; Motoniveladora 140K [20.8 h]; Rodillo liso vibratorio 10 - 12 ton [20.8 h]; Petroleo [178.98 gln] | 1 | 1 | 2400 | 6302.21 | m2 | 1 | 6302.21 | 2.62592083333333 | Excavacion |
|  | 2 | **RELLENOS** |  |  | 2024-09-12 | 2024-10-04 |  |  |  |  |  |  |  |  |  |  |  |  |  |
| A2130 |  | Relleno con Material Granular (incluye extraccion de material, zarandeo y combinado) |  | 18d | 2024-09-12 | 2024-10-02 | A2080 SS+5d, A2220, A2100, A2110 | 292d | 0d | Capataz [7.35 h]; Operario [1.84 h]; Oficial [5.37 h]; Peon [19.26 h]; Peon - Vigia [1.14 h]; Operador equipo Pesado [28.34 h]; Operador equipo Liviano [11.08 h]; Cisterna 5000 gln [3.63 h]; Volquete 15 m3 [5.58 h]; Cargador Frontal 966 [8.46 h]; Chancadora Primaria [4.18 h]; Excavadora Cat 336 [6.54 h]; Retroexcavadora sobre llantas 58 hp [0.93 h]; Rodillo liso vibratorio 10 - 12 ton [3.53 h]; Rodillo liso vibratorio 0.80 - 1.10 ton [1.84 h]; Tractor D6 [4.7 h]; Petroleo [200.99 gln] | 1 | 1 | 560 | 259.47 | m3 | 1 | 259.47 | 0.463339285714286 | Relleno |
| A2170 |  | Relleno con Material Seleccionado (incluye extraccion de material, zarandeo y combinado) |  | 18d | 2024-09-12 | 2024-10-02 | A2130 SS | 292d | 0d | Capataz [28.48 h]; Oficial [141.56 h]; Peon [290.78 h]; Operador equipo Pesado [424.69 h]; Operador equipo Liviano [29.76 h]; Cisterna 5000 gln [29.76 h]; Excavadora Cat 336 [283.13 h]; Rodillo liso vibratorio 10 - 12 ton [141.56 h]; Petroleo [4329.35 gln] | 1 | 1 | 240 | 4251.13 | m3 | 1 | 4251.13 | 17.7130416666667 | Relleno |
| A2160 |  | Perfilado de Talud Dique |  | 17d | 2024-09-16 | 2024-10-04 | A2130 SS+3d | 305d | 13d | Capataz [0.22 h]; Peon [1.08 h]; Operador equipo Pesado [0.32 h]; Excavadora Cat 336 [0.32 h]; Petroleo [2.75 gln] | 1 | 1 | 700 | 95.1 | m2 | 1 | 95.1 | 0.135857142857143 | Relleno |
|  | 3 | **GEOTEXTIL** |  |  | 2024-08-21 | 2024-10-19 |  |  |  |  |  |  |  |  |  |  |  |  |  |
| A2190 |  | Instalacion de Geotextil 400gr/m2 |  | 50d | 2024-08-21 | 2024-10-19 | A2220 SS | 293d | 0d | Capataz [19.64 h]; Oficial [194.23 h]; Peon [290.98 h]; Operador equipo Liviano [24.01 h]; Camion grua 20 ton [24.01 h]; Petroleo [96.02 gln]; Geotextil de 400 gr/m2 [8365.71 m2] | 1 | 1 | 600 | 7274.53 | m2 | 1 | 7274.53 | 12.1242166666667 | Geotextil |
| A2200 |  | Zanja de Anclaje |  | 8d | 2024-10-11 | 2024-10-19 | A2190 FF | 293d | 0d | Capataz [1.86 h]; Oficial [9.32 h]; Peon [28.04 h]; Operador equipo Pesado [9.32 h]; Operador equipo Liviano [0.26 h]; Cisterna 5000 gln [0.26 h]; Retroexcavadora sobre llantas 58 hp [9.32 h]; Petroleo [33.22 gln] | 1 | 1 | 32 | 37.3 | m3 | 1 | 37.3 | 1.165625 | Geotextil |
|  | 4 | **COLOCACION DE ROCA** |  |  | 2024-08-03 | 2024-10-21 |  |  |  |  |  |  |  |  |  |  |  |  |  |
| A2240 |  | Extraccion de Rocas Reutilizables |  | 21d | 2024-08-03 | 2024-08-28 | A2060 SS | 321d | 0d | Capataz [42.34 h]; Peon [84.6 h]; Operador equipo Pesado [84.6 h]; Excavadora Cat 336 [84.6 h]; Petroleo [719.14 gln] | 1 | 1 | 160 | 752 | m3 | 1 | 752 | 4.7 | Roca |
| A2280 |  | Desmontaje y Recolocacion de Enrocado |  | 21d | 2024-08-03 | 2024-08-28 | A2240 SS | 321d | 29d | Capataz [9.25 h]; Oficial [5 h]; Peon [18.5 h]; Operador equipo Pesado [24.49 h]; Excavadora Cat 336 [23.5 h]; Tractor D6 [1 h]; Petroleo [206.7 gln] | 1 | 1 | 192 | 120 | m3 | 1 | 120 | 0.625 | Roca |
| A2219 |  | Suministro de Roca 1 |  | 18d | 2024-08-21 | 2024-09-11 | A2220 SS | 310d | 0d |  | 0 |  |  |  |  |  |  |  | Roca |
| A2220 |  | Colocacion de Roca en Uña |  | 18d | 2024-08-21 | 2024-09-11 | A2090 SS+14d | 292d | 0d | Capataz [71.12 h]; Oficial [142.24 h]; Peon [142.24 h]; Operador equipo Pesado [156.67 h]; Excavadora Cat 336 [142.24 h]; Tractor D6 [14.42 h]; Petroleo [1310.02 gln] | 1 | 1 | 280 | 4973.5 | m3 | 1 | 4973.5 | 17.7625 | Roca |
| A2221 |  | Suministro de Roca 2 |  | 15d | 2024-10-03 | 2024-10-21 | A2230 SS, A2390 | 292d | 0d |  | 0 |  |  |  |  |  |  |  | Roca |
| A2230 |  | Colocacion de Roca en Talud |  | 12d | 2024-10-03 | 2024-10-17 | A2220, A2130, A2280 | 292d | 0d | Capataz [45.48 h]; Oficial [91.18 h]; Peon [91.18 h]; Operador equipo Pesado [191.33 h]; Excavadora Cat 336 [182.14 h]; Tractor D6 [9.18 h]; Petroleo [1612.62 gln] | 1 | 1 | 192 | 2186.6 | m3 | 1 | 2186.6 | 11.3885416666667 | Roca |
| A2290 |  | Colocación de Roca en Corona |  | 3d | 2024-10-18 | 2024-10-21 | A2230 | 292d | 0d | Capataz [10.96 h]; Oficial [21.85 h]; Peon [21.85 h]; Operador equipo Pesado [24.01 h]; Excavadora Cat 336 [21.85 h]; Tractor D6 [2.16 h]; Petroleo [241.41 gln] | 1 | 1 | 280 | 656.01 | m3 | 1 | 656.01 | 2.34289285714286 | Roca |

| ID | WBS | Activity | Type | Duration | Start | Finish | Predecessors | Total float | Free float | Resources | Cuadrilla | Metrado | Unidad | Turno | RCuad | DurCal | AGrupo | Rendimiento | Dur. Cal. |
| --- | --- | --- | --- | --- | --- | --- | --- | --- | --- | --- | --- | --- | --- | --- | --- | --- | --- | --- | --- |
|  | 5 | **TRANSPORTES** |  |  | 2024-08-01 | 2024-10-21 |  |  |  |  |  |  |  |  |  |  |  |  |  |
| A2320 |  | Transporte de Material Organico (a DMO) D<=1km |  | 15d | 2024-08-01 | 2024-08-19 | A2050 SS | 311d | 0d | Peon - Vigia [8.81 h]; Operador equipo Liviano [43.73 h]; Volquete 15 m3 [43.73 h]; Petroleo [122.37 gln] | 1 | 1572.9 | m3k | 1 | 1 | 1572.9 | Transportes |  |  |
| A2330 |  | Transporte de Material Organico (a DMO) D>1km |  | 15d | 2024-08-01 | 2024-08-19 | A2320 SS | 311d | 19d | Operador equipo Liviano [164.2 h]; Volquete 15 m3 [164.2 h]; Petroleo [459.77 gln] | 1 | 14927.56 | m3k | 1 | 1 | 14927.56 | Transportes |  |  |
| A2340 |  | Transporte de Material Excedente D<=1km |  | 21d | 2024-08-03 | 2024-08-28 | A2060 SS | 303d | 0d | Peon - Vigia [80.34 h]; Operador equipo Liviano [400.13 h]; Volquete 22 m3 [171.71 h]; Volquete 15 m3 [228.42 h]; Petroleo [1340.6 gln] | 1 | 15753.23 | m3k | 1 | 1 | 15753.23 | Transportes |  |  |
| A2350 |  | Transporte de Material Excedente D>1km |  | 21d | 2024-08-03 | 2024-08-28 | A2340 SS | 303d | 11d | Operador equipo Liviano [1497.42 h]; Volquete 22 m3 [637.52 h]; Volquete 15 m3 [859.91 h]; Petroleo [5011.18 gln] | 1 | 148259.75 | m3k | 1 | 1 | 148259.75 | Transportes |  |  |
| A2380 |  | Transporte de Roca D<=1km |  | 18d | 2024-08-21 | 2024-09-11 | A2219 SS | 310d | 0d | Peon [62.17 h]; Peon - Vigia [28.85 h]; Operador equipo Pesado [62.17 h]; Operador equipo Liviano [144.23 h]; Volquete 22 m3 [144.23 h]; Excavadora Cat 336 [62.17 h]; Petroleo [1120.03 gln]; Peaje local [226.29] | 1 | 7816.11 | m3k | 1 | 1 | 7816.11 | Transportes |  |  |
| A2390 |  | Transporte de Roca D>1km |  | 18d | 2024-08-21 | 2024-09-11 | A2380 SS | 310d | 18d | Operador equipo Liviano [65 h]; Volquete 22 m3 [65 h]; Petroleo [266.26 gln] | 1 | 9822.44 | m3k | 1 | 1 | 9822.44 | Transportes |  |  |
| A2360 |  | Transporte de Material de Prestamo (Afirmado) D<=1km |  | 18d | 2024-09-12 | 2024-10-02 | A2170 SS, A2330, A2350 | 292d | 0d | Peon - Vigia [9.55 h]; Operador equipo Liviano [47.53 h]; Volquete 22 m3 [47.53 h]; Petroleo [194.89 gln] | 1 | 2274.05 | m3k | 1 | 1 | 2274.05 | Transportes |  |  |
| A2370 |  | Transporte de Material de Prestamo (Afirmado) D>1km |  | 18d | 2024-09-12 | 2024-10-02 | A2360 SS | 292d | 0d | Operador equipo Liviano [51.73 h]; Volquete 22 m3 [51.73 h]; Petroleo [211.89 gln] | 1 | 6231.97 | m3k | 1 | 1 | 6231.97 | Transportes |  |  |
| A2400 |  | Transporte de Material de Prestamo Cantera de Rio (Cuerpo de Terraplen) D<=1km |  | 18d | 2024-09-12 | 2024-10-02 | A2130 SS | 307d | 0d | Peon - Vigia [20.88 h]; Operador equipo Liviano [103.91 h]; Volquete 22 m3 [103.91 h]; Petroleo [426.1 gln] | 1 | 4972 | m3k | 1 | 1 | 4972 | Transportes |  |  |
| A2410 |  | Transporte de Material de Prestamo Cantera de Rio (Cuerpo de Terraplen) D>1km |  | 18d | 2024-09-12 | 2024-10-02 | A2400 SS | 307d | 15d | Operador equipo Liviano [228.64 h]; Volquete 22 m3 [228.64 h]; Petroleo [936.61 gln] | 1 | 27547.24 | m3k | 1 | 1 | 27547.24 | Transportes |  |  |
| A2391 |  | Transporte de Roca D<=1km |  | 15d | 2024-10-03 | 2024-10-21 | A2230 SS, A2360, A2370 | 292d | 0d | Peon [27.33 h]; Peon - Vigia [12.68 h]; Operador equipo Pesado [27.33 h]; Operador equipo Liviano [63.41 h]; Volquete 22 m3 [63.41 h]; Excavadora Cat 336 [27.33 h]; Petroleo [492.42 gln]; Peaje local [99.49] | 1 | 7816.11 | m3k | 1 | 1 | 7816.11 | Transportes |  |  |
| A2392 |  | Transporte de Roca D>1km |  | 15d | 2024-10-03 | 2024-10-21 | A2391 SS | 292d | 0d | Operador equipo Liviano [37.15 h]; Volquete 22 m3 [37.15 h]; Petroleo [152.18 gln] | 1 | 9822.44 | m3k | 1 | 1 | 9822.44 | Transportes |  |  |
| A2420 |  | Transporte de Material Seleccionado para Zanja D<=1km |  | 8d | 2024-10-11 | 2024-10-19 | A2200 SS | 293d | 0d | Peon - Vigia [0.21 h]; Operador equipo Liviano [1.04 h]; Volquete 15 m3 [1.04 h]; Petroleo [2.92 gln] | 1 | 37.5 | m3k | 1 | 1 | 37.5 | Transportes |  |  |
| A2430 |  | Transporte de Material Seleccionado para Zanja D>1km |  | 8d | 2024-10-11 | 2024-10-19 | A2420 SS | 293d | 1d | Operador equipo Liviano [2.29 h]; Volquete 15 m3 [2.29 h]; Petroleo [6.4 gln] | 1 | 207.77 | m3k | 1 | 1 | 207.77 | Transportes |  |  |
|  | 6 | **DI-PR-40B-D** |  |  | 2024-09-14 | 2024-10-15 |  |  |  |  |  |  |  |  |  |  |  |  |  |
| A10610 |  | Inicio - DE-PR-40B-D | milestone | 0d | 2024-09-14 | 2024-09-14 | A2080 | 0d |  |  |  |  |  |  | 0 |  |  |  |  |
| A10620 |  | Fin - DE-PR-40B-D | milestone | 0d | 2024-10-15 | 2024-10-15 | A10340 FF, A2800 FF, A2570 FF, A2680 FF, A2760 FF, A2780 FF | 297d |  |  |  |  |  |  | 0 |  |  |  |  |
|  | 1 | **EXCAVACIONES** |  |  | 2024-09-14 | 2024-09-16 |  |  |  |  |  |  |  |  |  |  |  |  |  |
| A2440 |  | Desbroce |  | 1d | 2024-09-14 | 2024-09-14 | A10610 SS | 0d |  | Capataz [0.01 h]; Peon [1 h]; Operador equipo Pesado [0.75 h]; Excavadora Cat 336 [0.25 h]; Tractor D6 [0.5 h]; Petroleo [5.62 gln] | 1 | 0.05 | ha | 1 | 1 | 0.05 | Excavacion | 0.8 | 0.0625 |
| A2500 |  | Conformacion de Material Excedente en DMO |  | 1d | 2024-09-14 | 2024-09-14 | A2440 SS | 305d | 1d | Capataz [0.12 h]; Peon [1.14 h]; Operador equipo Pesado [1.26 h]; Excavadora Cat 336 [0.12 h]; Tractor D6 [1.14 h]; Petroleo [8.97 gln] | 1 | 149.57 | m3 | 1 | 1 | 149.57 | Excavacion | 1050 | 0.142447619047619 |
| A2460 |  | Excavacion de Cimentacion |  | 1d | 2024-09-16 | 2024-09-16 | A2440 | 0d |  | Capataz [0.77 h]; Peon [7.67 h]; Operador equipo Pesado [5.11 h]; Operador equipo Liviano [4.26 h]; Excavadora Cat 336 [3.41 h]; Retroexcavadora sobre llantas 94 hp [4.26 h]; Tractor D8 [1.7 h]; Petroleo [55.74 gln] | 1 | 426.17 | m3 | 1 | 1 | 426.17 | Excavacion | 900 | 0.473522222222222 |
| A2490 |  | Conformacion de Material Excedente en DME |  | 1d | 2024-09-16 | 2024-09-16 | A2460 SS | 304d | 0d | Capataz [0.34 h]; Peon [3.24 h]; Operador equipo Pesado [3.58 h]; Excavadora Cat 336 [0.34 h]; Tractor D6 [3.24 h]; Petroleo [25.57 gln] | 1 | 426.17 | m3 | 1 | 1 | 426.17 | Excavacion | 1050 | 0.405876190476191 |
|  | 2 | **RELLENOS** |  |  | 2024-10-04 | 2024-10-11 |  |  |  |  |  |  |  |  |  |  |  |  |  |
| A2520 |  | Relleno con Material Granular (incluye extraccion de material, zarandeo y combinado) |  | 2d | 2024-10-04 | 2024-10-05 | A2650 | 297d | 0d | Capataz [23.38 h]; Operario [5.87 h]; Oficial [17.1 h]; Peon [61.29 h]; Peon - Vigia [3.63 h]; Operador equipo Pesado [90.21 h]; Operador equipo Liviano [35.27 h]; Cisterna 5000 gln [11.56 h]; Volquete 15 m3 [17.76 h]; Cargador Frontal 966 [26.93 h]; Chancadora Primaria [13.3 h]; Excavadora Cat 336 [20.82 h]; Retroexcavadora sobre llantas 58 hp [2.97 h]; Rodillo liso vibratorio 10 - 12 ton [11.23 h]; Rodillo liso vibratorio 0.80 - 1.10 ton [5.87 h]; Tractor D6 [14.95 h]; Petroleo [639.62 gln] | 1 | 826.06 | m3 | 1 | 1 | 826.06 | Relleno | 560 | 1.47510714285714 |
| A2570 |  | Grava para Drenaje |  | 1d | 2024-10-05 | 2024-10-05 | A2520 FF | 304d | 7d | Capataz [1.31 h]; Peon [4.26 h]; Peon - Vigia [0.13 h]; Operador equipo Pesado [1.75 h]; Operador equipo Liviano [3.93 h]; Volquete 15 m3 [0.67 h]; Cargador Frontal 966 [0.75 h]; Chancadora Primaria [0.5 h]; Excavadora Cat 336 [0.5 h]; Retroexcavadora sobre llantas 94 hp [3.26 h]; Tractor D6; Petroleo [22.28 gln] | 1 | 32.58 | m3 | 1 | 1 | 32.58 | Relleno | 80 | 0.40725 |
| A2540 |  | Relleno Afirmado |  | 1d | 2024-10-11 | 2024-10-11 | A2640 | 297d | 0d | Capataz [1.73 h]; Oficial [1.42 h]; Peon [4.46 h]; Peon - Vigia [0.48 h]; Operador equipo Pesado [8.17 h]; Operador equipo Liviano [3.01 h]; Cisterna 5000 gln [0.65 h]; Volquete 15 m3 [2.36 h]; Cargador Frontal 966 [1 h]; Chancadora LT200 [1 h]; Excavadora Cat 336 [1.88 h]; Motoniveladora 140K [1.42 h]; Rodillo liso vibratorio 10 - 12 ton [1.42 h]; Tractor D6 [0.44 h]; Zaranda Metso ST 4.8 168 HP [1 h]; Petroleo [57.52 gln]; CANON POR EXTRACCION CANTERA [60.22] | 1 | 57.35 | m3 | 1 | 1 | 57.35 | Relleno | 324 | 0.177006172839506 |

| ID | WBS | Activity | Type | Duration | Start | Finish | Predecessors | Total float | Free float | Resources | Cuadrilla | Rendimiento | Metrado | Unidad | Turno | RCuad | DurCal | Dur. Cal. | AGrupo |
| --- | --- | --- | --- | --- | --- | --- | --- | --- | --- | --- | --- | --- | --- | --- | --- | --- | --- | --- | --- |
|  | 3 | **GEOTEXTIL** |  |  | 2024-09-17 | 2024-10-07 |  |  |  |  |  |  |  |  |  |  |  |  |  |
| A2580 |  | Instalacion de Geotextil 400gr/m2 |  | 18d | 2024-09-17 | 2024-10-07 | A2650 SS, A2490, A2500 | 304d |  | Capataz [2.02 h]; Oficial [20.02 h]; Peon [30 h]; Operador equipo Liviano [2.47 h]; Camion grua 20 ton [2.47 h]; Petroleo [9.9 gln]; Geotextil de 400 gr/m2 [862.47 m2] | 1 | 600 | 749.97 | m2 | 1 | 1 | 749.97 | 1.24995 | Geotextil |
|  | 4 | **COLOCACION DE ROCA** |  |  | 2024-09-17 | 2024-10-12 |  |  |  |  |  |  |  |  |  |  |  |  |  |
| A2650 |  | Malla Gavion de 1m x 1m x 5m |  | 15d | 2024-09-17 | 2024-10-03 | A2460 | 297d | 0d | Capataz [53.24 h]; Operario [228 h]; Peon [1444.55 h]; Peon - Vigia [3.59 h]; Operador equipo Pesado [5.3 h]; Operador equipo Liviano [220.65 h]; Volquete 15 m3 [35.4 h]; Excavadora Cat 336 [5.3 h]; Retroexcavadora sobre llantas 94 hp [185.25 h]; Petroleo [607.39 gln]; ALAMBRE NEGRO #8 [570]; GAVION TIPO CAJA DE 1x1x5 m [114] | 2 | 4 | 114 | und | 1 | 2 | 57 | 14.25 | Roca |
| A2700 |  | Rehabilitacion de Enrocados de Proteccion Existentes |  | 18d | 2024-09-17 | 2024-10-07 | A2650 SS | 301d | 2d |  | 1 |  | 2559.33 | m3 | 1 | 1 | 2559.33 |  | Roca |
| A2640 |  | Proteccion de Talud con Colchon Reno 6m Largo x e=0.30cm |  | 3d | 2024-10-07 | 2024-10-10 | A2650, A2520 | 297d | 0d | Capataz [2.18 h]; Oficial [17.96 h]; Peon [111.58 h]; Peon - Vigia [0.17 h]; Operador equipo Pesado [0.25 h]; Operador equipo Liviano [14.24 h]; Volquete 15 m3 [1.67 h]; Excavadora Cat 336 [0.25 h]; Retroexcavadora sobre llantas 94 hp [12.57 h]; Zaranda estatica [3.59 h]; Petroleo [38.24 gln]; ALAMBRE NEGRO #8 [134.67]; GAVION COLCHON 8x10 cm [89.78] | 1 | 40 | 89.78 | m2 | 1 | 1 | 89.78 | 2.2445 | Roca |
| A2680 |  | Colocación de Roca en Corona |  | 2d | 2024-10-11 | 2024-10-12 | A2640, A2700 | 299d | 2d | Capataz [6.04 h]; Oficial [12.04 h]; Peon [12.04 h]; Operador equipo Pesado [13.23 h]; Excavadora Cat 336 [12.04 h]; Tractor D6 [1.19 h]; Petroleo [133.04 gln] | 1 | 280 | 361.53 | m3 | 1 | 1 | 361.53 | 1.29117857142857 | Roca |
|  | 5 | **TRANSPORTES** |  |  | 2024-09-14 | 2024-10-11 |  |  |  |  |  |  |  |  |  |  |  |  |  |
| A2710 |  | Transporte de Material Organico (a DMO) D<=1km |  | 1d | 2024-09-14 | 2024-09-14 | A2440 SS | 315d | 0d | Peon - Vigia [0.84 h]; Operador equipo Liviano [4.16 h]; Volquete 15 m3 [4.16 h]; Petroleo [11.64 gln] | 1 |  | 149.57 | m3k | 1 | 1 | 149.57 |  | Transportes |
| A2720 |  | Transporte de Material Organico (a DMO) D>1km |  | 1d | 2024-09-14 | 2024-09-14 | A2710 SS | 315d | 0d | Operador equipo Liviano [15.94 h]; Volquete 15 m3 [15.94 h]; Petroleo [44.64 gln] | 1 |  | 1449.31 | m3k | 1 | 1 | 1449.31 |  | Transportes |
| A2730 |  | Transporte de Material Excedente D<=1km |  | 1d | 2024-09-16 | 2024-09-16 | A2460 SS, A2720 | 315d | 0d | Peon - Vigia [2.17 h]; Operador equipo Liviano [10.82 h]; Volquete 22 m3 [4.65 h]; Volquete 15 m3 [6.18 h]; Petroleo [36.27 gln] | 1 |  | 426.17 | m3k | 1 | 1 | 426.17 |  | Transportes |
| A2740 |  | Transporte de Material Excedente D>1km |  | 1d | 2024-09-16 | 2024-09-16 | A2730 SS | 315d | 15d | Operador equipo Liviano [41.38 h]; Volquete 22 m3 [17.62 h]; Volquete 15 m3 [23.76 h]; Petroleo [138.46 gln] | 1 |  | 4096.54 | m3k | 1 | 1 | 4096.54 |  | Transportes |
| A2770 |  | Transporte de Roca D<=1km |  | 20d | 2024-09-17 | 2024-10-10 | A2650 SS | 301d | 0d | Peon [14.12 h]; Peon - Vigia [6.55 h]; Operador equipo Pesado [14.12 h]; Operador equipo Liviano [32.75 h]; Volquete 22 m3 [32.75 h]; Excavadora Cat 336 [14.12 h]; Petroleo [254.33 gln]; Peaje local [51.38] | 1 |  | 1129.33 | m3k | 1 | 1 | 1129.33 |  | Transportes |
| A2780 |  | Transporte de Roca D>1km |  | 20d | 2024-09-17 | 2024-10-10 | A2770 SS | 301d | 4d | Operador equipo Liviano [18.1 h]; Volquete 22 m3 [18.1 h]; Petroleo [74.12 gln] | 1 |  | 1739.94 | m3k | 1 | 1 | 1739.94 |  | Transportes |
| A2750 |  | Transporte de Material de Prestamo (Afirmado) D<=1km |  | 6d | 2024-10-04 | 2024-10-11 | A2520 SS, A2740 | 300d | 0d | Peon - Vigia [2.11 h]; Operador equipo Liviano [10.51 h]; Volquete 22 m3 [10.51 h]; Petroleo [43.1 gln] | 1 |  | 502.96 | m3k | 1 | 1 | 502.96 |  | Transportes |
| A2760 |  | Transporte de Material de Prestamo (Afirmado) D>1km |  | 6d | 2024-10-04 | 2024-10-11 | A2750 SS | 300d | 3d | Operador equipo Liviano [15.81 h]; Volquete 22 m3 [15.81 h]; Petroleo [64.74 gln] | 1 |  | 1904.24 | m3k | 1 | 1 | 1904.24 |  | Transportes |
| A2790 |  | Transporte de Material de Prestamo Cantera de Rio (Cuerpo de Terraplen) D<=1km |  | 3d | 2024-10-04 | 2024-10-07 | A2520 SS, A2750 SS | 303d | 0d | Peon - Vigia [3.47 h]; Operador equipo Liviano [17.26 h]; Volquete 22 m3 [17.26 h]; Petroleo [70.79 gln] | 1 |  | 826.06 | m3k | 1 | 1 | 826.06 |  | Transportes |
| A2800 |  | Transporte de Material de Prestamo Cantera de Rio (Cuerpo de Terraplen) D>1km |  | 3d | 2024-10-04 | 2024-10-07 | A2790 SS | 303d | 6d | Operador equipo Liviano [38.3 h]; Volquete 22 m3 [38.3 h]; Petroleo [156.89 gln] | 1 |  | 4614.34 | m3k | 1 | 1 | 4614.34 |  | Transportes |
|  | 6 | **VIA CARROZABLE** |  |  | 2024-10-12 | 2024-10-15 |  |  |  |  |  |  |  |  |  |  |  |  |  |
| A10330 |  | Material de Base para pavimento |  | 1d | 2024-10-12 | 2024-10-12 | A2540 | 297d | 0d |  |  |  | 50.02 | m3 |  | 0 |  |  | Via |
| A10340 |  | Pavimento Emboquillado e=0.25m |  | 2d | 2024-10-14 | 2024-10-15 | A10330 | 297d | 0d |  |  |  | 83.36 | m3 |  | 0 |  |  | Via |
|  | 5 | **DI-PR-47bis-D** |  |  | 2024-09-17 | 2024-11-05 |  |  |  |  |  |  |  |  |  |  |  |  |  |
| A10630 |  | Inicio - DE-PR-47bis-D | milestone | 0d | 2024-09-17 | 2024-09-17 | A2460 | 0d |  |  |  |  |  |  |  | 0 |  |  |  |
| A10640 |  | Fin - DE-PR-47bis-D | milestone | 0d | 2024-11-05 | 2024-11-05 | A3630 FF, A3710 FF, A3850 FF, A3870 FF, A3910 FF | 280d |  |  |  |  |  |  |  | 0 |  |  |  |

| ID | WBS | Activity | Duration | Start | Finish | Predecessors | Total float | Free float | Resources | Cuadrilla | Rendimiento | Metrado | Unidad | Turno | RCuad | DurCal | Dur. Cal. | AGrupo |
| --- | --- | --- | --- | --- | --- | --- | --- | --- | --- | --- | --- | --- | --- | --- | --- | --- | --- | --- |
|  | 1 | **EXCAVACIONES** |  | 2024-09-17 | 2024-10-10 |  |  |  |  |  |  |  |  |  |  |  |  |  |
| A3530 |  | Desbroce | 15d | 2024-09-17 | 2024-10-03 | A10630 SS | 0d |  | Capataz [0.06 h]; Peon [11.8 h]; Operador equipo Pesado [8.85 h]; Excavadora Cat 336 [2.95 h]; Tractor D6 [5.9 h]; Petroleo [66.38 gln] | 1 | 0.8 | 0.59 | ha | 1 | 1 | 0.59 | 0.7375 | Excavacion |
| A3590 |  | Conformacion de Material Excedente en DMO | 15d | 2024-09-17 | 2024-10-03 | A3530 SS | 303d | 10d | Capataz [1.44 h]; Peon [13.73 h]; Operador equipo Pesado [15.17 h]; Excavadora Cat 336 [1.44 h]; Tractor D6 [13.73 h]; Petroleo [108.36 gln] | 1 | 1050 | 1806.05 | m3 | 1 | 1 | 1806.05 | 1.72004761904762 | Excavacion |
| A3540 |  | Remocion de Dique Existente | 16d | 2024-09-19 | 2024-10-07 | A3530 SS+2d | 0d |  | Capataz [2.49 h]; Peon [12.47 h]; Operador equipo Pesado [18.7 h]; Excavadora Cat 336 [12.47 h]; Tractor D8 [6.23 h]; Petroleo [165.2 gln] | 1 | 800 | 1246.78 | m3 | 1 | 1 | 1246.78 | 1.558475 | Excavacion |
| A3550 |  | Excavacion de Cimentacion | 16d | 2024-09-19 | 2024-10-07 | A3540 SS | 0d |  | Capataz [22.86 h]; Peon [228.61 h]; Operador equipo Pesado [152.4 h]; Operador equipo Liviano [127 h]; Excavadora Cat 336 [101.6 h]; Retroexcavadora sobre llantas 94 hp [127 h]; Tractor D8 [50.8 h]; Petroleo [1661.2 gln] | 1 | 900 | 12700.31 | m3 | 1 | 1 | 12700.31 | 14.1114555555556 | Excavacion |
| A3570 |  | Excavacion de Uña | 16d | 2024-09-19 | 2024-10-07 | A3550 SS | 285d | 0d | Capataz [10.42 h]; Peon [52.11 h]; Operador equipo Pesado [52.11 h]; Excavadora Cat 336 [52.11 h]; Petroleo [588.85 gln] | 1 | 500 | 3256.9 | m3 | 1 | 1 | 3256.9 | 6.5138 | Excavacion |
| A3580 |  | Conformacion de Material Excedente en DME | 16d | 2024-09-19 | 2024-10-07 | A3540 SS | 300d | 7d | Capataz [13.35 h]; Peon [126.84 h]; Operador equipo Pesado [140.2 h]; Excavadora Cat 336 [13.35 h]; Tractor D6 [126.84 h]; Petroleo [1001.39 gln] | 1 | 1050 | 16689.9 | m3 | 1 | 1 | 16689.9 | 15.8951428571429 | Excavacion |
| A3600 |  | Excavacion Localizada - Sobreexcavacion | 16d | 2024-09-19 | 2024-10-07 | A3570 SS | 300d | 7d | Capataz [1.71 h]; Peon [35.77 h]; Peon - Vigia [12.42 h]; Operador equipo Pesado [35.55 h]; Operador equipo Liviano [62.11 h]; Volquete 15 m3 [62.11 h]; Excavadora Cat 336 [17.78 h]; Tractor D8 [17.78 h]; Petroleo [494.1 gln] | 1 | 240 | 2141.75 | m3 | 1 | 1 | 2141.75 | 8.92395833333333 | Excavacion |
| A3560 |  | Perfilado y Conformacion de Plataforma de Fundacion | 14d | 2024-09-24 | 2024-10-10 | A3550 SS+4d | 280d | 0d | Capataz [1.97 h]; Peon [24.24 h]; Operador equipo Pesado [43.24 h]; Operador equipo Liviano [9.17 h]; Cisterna 5000 gln [9.17 h]; Motoniveladora 140K [21.62 h]; Rodillo liso vibratorio 10 - 12 ton [21.62 h]; Petroleo [186.06 gln] | 1 | 2400 | 6551.39 | m2 | 1 | 1 | 6551.39 | 2.72974583333333 | Excavacion |
|  | 2 | **RELLENOS** |  | 2024-09-26 | 2024-10-19 |  |  |  |  |  |  |  |  |  |  |  |  |  |
| A3610 |  | Relleno con Material Granular (incluye extraccion de material, zarandeo y combinado) | 13d | 2024-09-26 | 2024-10-11 | A3560 SS+2d | 280d | 0d | Capataz [205.72 h]; Operario [51.61 h]; Oficial [150.47 h]; Peon [539.37 h]; Peon - Vigia [31.98 h]; Operador equipo Pesado [793.79 h]; Operador equipo Liviano [310.39 h]; Cisterna 5000 gln [101.77 h]; Volquete 15 m3 [156.29 h]; Cargador Frontal 966 [236.97 h]; Chancadora Primaria [117.03 h]; Excavadora Cat 336 [183.18 h]; Retroexcavadora sobre llantas 58 hp [26.17 h]; Rodillo liso vibratorio 10 - 12 ton [98.86 h]; Rodillo liso vibratorio 0.80 - 1.10 ton [51.61 h]; Tractor D6 [131.57 h]; Petroleo [5628.51 gln] | 1 | 560 | 7269.16 | m3 | 1 | 1 | 7269.16 | 12.9806428571429 | Relleno |
| A3650 |  | Relleno con Material Seleccionado (incluye extraccion de material, zarandeo y combinado) | 13d | 2024-09-26 | 2024-10-11 | A3610 SS | 297d | 4d | Capataz [15.03 h]; Oficial [74.71 h]; Peon [153.46 h]; Operador equipo Pesado [224.14 h]; Operador equipo Liviano [15.71 h]; Cisterna 5000 gln [15.71 h]; Excavadora Cat 336 [149.43 h]; Rodillo liso vibratorio 10 - 12 ton [74.71 h]; Petroleo [2284.9 gln] | 1 | 240 | 2243.62 | m3 | 1 | 1 | 2243.62 | 9.34841666666667 | Relleno |
| A3640 |  | Perfilado de Talud Dique | 12d | 2024-09-30 | 2024-10-14 | A3610 SS+3d | 295d | 2d | Capataz [6.2 h]; Peon [30.72 h]; Operador equipo Pesado [9.16 h]; Excavadora Cat 336 [9.16 h]; Petroleo [77.87 gln] | 1 | 700 | 2694.55 | m2 | 1 | 1 | 2694.55 | 3.84935714285714 | Relleno |
| A3660 |  | Grava para Drenaje | 4d | 2024-10-12 | 2024-10-16 | A3610 | 293d | 0d | Capataz [10.28 h]; Peon [33.33 h]; Peon - Vigia [1.05 h]; Operador equipo Pesado [13.67 h]; Operador equipo Liviano [30.73 h]; Volquete 15 m3 [5.23 h]; Cargador Frontal 966 [5.87 h]; Chancadora Primaria [3.9 h]; Excavadora Cat 336 [3.9 h]; Retroexcavadora sobre llantas 94 hp [25.5 h]; Tractor D6; Petroleo [174.41 gln] | 1 | 80 | 255.03 | m3 | 1 | 1 | 255.03 | 3.187875 | Relleno |
| A3620 |  | Relleno sin Compactar | 2d | 2024-10-17 | 2024-10-18 | A3710 SS, A3610, A3660, A3580, A3590, A3600, A3640, A3650 | 293d | 0d | Capataz [2.29 h]; Oficial [11.3 h]; Peon [11.3 h]; Operador equipo Pesado [11.3 h]; Tractor D6 [11.3 h]; Petroleo [79.11 gln] | 1 | 900 | 1269.78 | m3 | 1 | 1 | 1269.78 | 1.41086666666667 | Relleno |
| A3630 |  | Relleno Afirmado | 1d | 2024-10-19 | 2024-10-19 | A3620 | 293d | 13d | Capataz [8.5 h]; Oficial [6.98 h]; Peon [21.94 h]; Peon - Vigia [2.34 h]; Operador equipo Pesado [40.22 h]; Operador equipo Liviano [14.83 h]; Cisterna 5000 gln [3.19 h]; Volquete 15 m3 [11.64 h]; Cargador Frontal 966 [4.94 h]; Chancadora LT200 [4.94 h]; Excavadora Cat 336 [9.26 h]; Motoniveladora 140K [6.98 h]; Rodillo liso vibratorio 10 - 12 ton [6.98 h]; Tractor D6 [2.17 h]; Zaranda Metso ST 4.8 168 HP [4.94 h]; Petroleo [283.27 gln]; CANON POR EXTRACCION CANTERA [296.54] | 1 | 324 | 282.42 | m3 | 1 | 1 | 282.42 | 0.871666666666667 | Relleno |
|  | 3 | **GEOTEXTIL** |  | 2024-09-21 | 2024-10-24 |  |  |  |  |  |  |  |  |  |  |  |  |  |
| A3670 |  | Instalacion de Geotextil 400gr/m2 | 28d | 2024-09-21 | 2024-10-24 | A3700 SS | 289d | 0d | Capataz [18.09 h]; Oficial [178.9 h]; Peon [268.02 h]; Operador equipo Liviano [22.11 h]; Camion grua 20 ton [22.11 h]; Petroleo [88.45 gln]; Geotextil de 400 gr/m2 [7705.59 m2] | 1 | 600 | 6700.51 | m2 | 1 | 1 | 6700.51 | 11.1675166666667 | Geotextil |
| A3680 |  | Zanja de Anclaje | 8d | 2024-10-16 | 2024-10-24 | A3670 FF | 289d | 0d | Capataz [2.12 h]; Oficial [10.62 h]; Peon [31.95 h]; Operador equipo Pesado [10.62 h]; Operador equipo Liviano [0.3 h]; Cisterna 5000 gln [0.3 h]; Retroexcavadora sobre llantas 58 hp [10.62 h]; Petroleo [37.85 gln] | 1 | 32 | 42.5 | m3 | 1 | 1 | 42.5 | 1.328125 | Geotextil |
|  | 4 | **COLOCACION DE ROCA** |  | 2024-09-19 | 2024-11-05 |  |  |  |  |  |  |  |  |  |  |  |  |  |
| A3720 |  | Extraccion de Rocas Reutilizables | 16d | 2024-09-19 | 2024-10-07 | A3540 SS | 283d | 3d | Capataz [42.34 h]; Peon [84.6 h]; Operador equipo Pesado [84.6 h]; Excavadora Cat 336 [84.6 h]; Petroleo [719.14 gln] | 1 | 160 | 752 | m3 | 1 | 1 | 752 | 4.7 | Roca |
| A10650 |  | Suministro de Roca | 32d | 2024-09-21 | 2024-10-29 | A3700 SS | 285d | 0d |  |  |  |  |  |  | 0 |  |  | Roca |
| A3700 |  | Colocacion de Roca en Uña | 12d | 2024-09-21 | 2024-10-04 | A3570 SS+2d | 285d | 0d | Capataz [46.57 h]; Oficial [93.15 h]; Peon [93.15 h]; Operador equipo Pesado [102.59 h]; Excavadora Cat 336 [93.15 h]; Tractor D6 [9.45 h]; Petroleo [857.87 gln] | 1 | 280 | 3256.9 | m3 | 1 | 1 | 3256.9 | 11.6317857142857 | Roca |
| A3710 |  | Colocacion de Roca en Talud | 20d | 2024-10-12 | 2024-11-05 | A3700, A3610, A3720 | 280d | 0d | Capataz [76.46 h]; Oficial [153.29 h]; Peon [153.29 h]; Operador equipo Pesado [321.66 h]; Excavadora Cat 336 [306.22 h]; Tractor D6 [15.44 h]; Petroleo [2711.14 gln] | 1 | 192 | 3676.12 | m3 | 1 | 1 | 3676.12 | 19.1464583333333 | Roca |

| ID | WBS | Activity | Type | Duration | Start | Finish | Predecessors | Total float | Free float | Resources | Cuadrilla | Metrado | Unidad | Turno | RCuad | DurCal | AGrupo | Rendimiento | Dur. Cal. |
| --- | --- | --- | --- | --- | --- | --- | --- | --- | --- | --- | --- | --- | --- | --- | --- | --- | --- | --- | --- |
|  | 5 | **TRANSPORTES** |  |  | 2024-09-17 | 2024-10-29 |  |  |  |  |  |  |  |  |  |  |  |  |  |
| A3800 |  | Transporte de Material Organico (a DMO) D<=1km |  | 15d | 2024-09-17 | 2024-10-03 | A3530 SS | 298d | 0d | Peon - Vigia [10.11 h]; Operador equipo Liviano [50.21 h]; Volquete 15 m3 [50.21 h]; Petroleo [140.51 gln] | 1 | 1806.05 | m3k | 1 | 1 | 1806.05 | Transportes |  |  |
| A3810 |  | Transporte de Material Organico (a DMO) D>1km |  | 15d | 2024-09-17 | 2024-10-03 | A3800 SS | 298d | 9d | Operador equipo Liviano [222.21 h]; Volquete 15 m3 [222.21 h]; Petroleo [622.18 gln] | 1 | 20200.67 | m3k | 1 | 1 | 20200.67 | Transportes |  |  |
| A3820 |  | Transporte de Material Excedente D<=1km |  | 16d | 2024-09-19 | 2024-10-07 | A3540 SS | 295d | 0d | Peon - Vigia [85.12 h]; Operador equipo Liviano [423.92 h]; Volquete 22 m3 [181.92 h]; Volquete 15 m3 [242 h]; Petroleo [1420.3 gln] | 1 | 16689.8 | m3k | 1 | 1 | 16689.8 | Transportes |  |  |
| A3830 |  | Transporte de Material Excedente D>1km |  | 16d | 2024-09-19 | 2024-10-07 | A3820 SS | 295d | 6d | Operador equipo Liviano [1870.07 h]; Volquete 22 m3 [796.17 h]; Volquete 15 m3 [1073.9 h]; Petroleo [6258.24 gln] | 1 | 185155.09 | m3k | 1 | 1 | 185155.09 | Transportes |  |  |
| A3860 |  | Transporte de Roca D<=1km |  | 32d | 2024-09-21 | 2024-10-29 | A10650 SS | 285d | 0d | Peon [86.66 h]; Peon - Vigia [40.21 h]; Operador equipo Pesado [86.66 h]; Operador equipo Liviano [201.06 h]; Volquete 22 m3 [201.06 h]; Excavadora Cat 336 [86.66 h]; Petroleo [1561.32 gln]; Peaje local [315.45] | 1 | 6933.02 | m3k | 1 | 1 | 6933.02 | Transportes |  |  |
| A3870 |  | Transporte de Roca D>1km |  | 32d | 2024-09-21 | 2024-10-29 | A3860 SS | 285d | 5d | Operador equipo Liviano [198.31 h]; Volquete 22 m3 [198.31 h]; Petroleo [812.32 gln] | 1 | 19068.45 | m3k | 1 | 1 | 19068.45 | Transportes |  |  |
| A3840 |  | Transporte de Material de Prestamo (Afirmado) D<=1km |  | 20d | 2024-09-26 | 2024-10-19 | A3610 SS | 293d | 0d | Peon - Vigia [22.32 h]; Operador equipo Liviano [111.09 h]; Volquete 22 m3 [111.09 h]; Petroleo [455.5 gln] | 1 | 5315.09 | m3k | 1 | 1 | 5315.09 | Transportes |  |  |
| A3850 |  | Transporte de Material de Prestamo (Afirmado) D>1km |  | 20d | 2024-09-26 | 2024-10-19 | A3840 SS | 293d | 13d | Operador equipo Liviano [152.29 h]; Volquete 22 m3 [152.29 h]; Petroleo [623.86 gln] | 1 | 18348.79 | m3k | 1 | 1 | 18348.79 | Transportes |  |  |
| A3880 |  | Transporte de Material de Prestamo Cantera de Rio (Cuerpo de Terraplen) D<=1km |  | 15d | 2024-09-26 | 2024-10-14 | A3610 SS | 290d | 0d | Peon - Vigia [41.82 h]; Operador equipo Liviano [208.12 h]; Volquete 22 m3 [208.12 h]; Petroleo [853.41 gln] | 1 | 9958.08 | m3k | 1 | 1 | 9958.08 | Transportes |  |  |
| A3890 |  | Transporte de Material de Prestamo Cantera de Rio (Cuerpo de Terraplen) D>1km |  | 15d | 2024-09-26 | 2024-10-14 | A3880 SS | 290d | 1d | Operador equipo Liviano [597.25 h]; Volquete 22 m3 [597.25 h]; Petroleo [2446.58 gln] | 1 | 71958.35 | m3k | 1 | 1 | 71958.35 | Transportes |  |  |
| A3900 |  | Transporte de Material Seleccionado para Zanja D<=1km |  | 8d | 2024-10-16 | 2024-10-24 | A3680 SS, A3810, A3830, A3890 | 289d | 0d | Peon - Vigia [0.24 h]; Operador equipo Liviano [1.18 h]; Volquete 15 m3 [1.18 h]; Petroleo [3.31 gln] | 1 | 42.5 | m3k | 1 | 1 | 42.5 | Transportes |  |  |
| A3910 |  | Transporte de Material Seleccionado para Zanja D>1km |  | 8d | 2024-10-16 | 2024-10-24 | A3900 SS | 289d | 9d | Operador equipo Liviano [3.38 h]; Volquete 15 m3 [3.38 h]; Petroleo [9.47 gln] | 1 | 307.49 | m3k | 1 | 1 | 307.49 | Transportes |  |  |
|  | 7 | **DE-PR-49bis-D** |  |  | 2024-10-09 | 2024-12-20 |  |  |  |  |  |  |  |  |  |  |  |  |  |
| A10660 |  | Inicio - DE-PR-49bis-D | milestone | 0d | 2024-10-09 | 2024-10-09 | A3550 | 0d |  |  |  |  |  |  | 0 |  |  |  |  |
| A10670 |  | Fin - DE-PR-49bis-D | milestone | 0d | 2024-12-20 | 2024-12-20 | A4410 FF, A4690 FF, A10680 FF, A4630 FF, A4650 FF | 0d |  |  |  |  |  |  | 0 |  |  |  |  |
|  | 1 | **EXCAVACIONES** |  |  | 2024-10-09 | 2024-11-22 |  |  |  |  |  |  |  |  |  |  |  |  |  |
| A4310 |  | Desbroce |  | 15d | 2024-10-09 | 2024-10-25 | A10660 SS | 0d |  | Capataz [0.1 h]; Peon [21 h]; Operador equipo Pesado [15.75 h]; Excavadora Cat 336 [5.25 h]; Tractor D6 [10.5 h]; Petroleo [118.12 gln] | 1 | 1.05 | ha | 1 | 1 | 1.05 | Excavacion | 0.8 | 1.3125 |
| A4370 |  | Conformacion de Material Excedente en DMO |  | 15d | 2024-10-09 | 2024-10-25 | A4310 SS | 42d | 32d | Capataz [2.52 h]; Peon [23.93 h]; Operador equipo Pesado [26.45 h]; Excavadora Cat 336 [2.52 h]; Tractor D6 [23.93 h]; Petroleo [188.94 gln] | 1 | 3149.02 | m3 | 1 | 1 | 3149.02 | Excavacion | 1050 | 2.99906666666667 |
| A4330 |  | Excavacion de Cimentacion |  | 31d | 2024-10-15 | 2024-11-20 | A4310 SS+5d | 0d |  | Capataz [26.46 h]; Peon [264.59 h]; Operador equipo Pesado [176.39 h]; Operador equipo Liviano [146.99 h]; Excavadora Cat 336 [117.59 h]; Retroexcavadora sobre llantas 94 hp [146.99 h]; Tractor D8 [58.8 h]; Petroleo [1922.68 gln] | 1 | 14699.38 | m3 | 1 | 1 | 14699.38 | Excavacion | 900 | 16.3326444444444 |
| A4350 |  | Excavacion de Uña |  | 31d | 2024-10-15 | 2024-11-20 | A4330 SS | 0d |  | Capataz [14.5 h]; Peon [72.48 h]; Operador equipo Pesado [72.48 h]; Excavadora Cat 336 [72.48 h]; Petroleo [819.01 gln] | 1 | 4529.91 | m3 | 1 | 1 | 4529.91 | Excavacion | 500 | 9.05982 |
| A4360 |  | Conformacion de Material Excedente en DME |  | 31d | 2024-10-15 | 2024-11-20 | A4330 SS | 21d | 11d | Capataz [14.36 h]; Peon [136.38 h]; Operador equipo Pesado [150.74 h]; Excavadora Cat 336 [14.36 h]; Tractor D6 [136.38 h]; Petroleo [1076.7 gln] | 1 | 17944.99 | m3 | 1 | 1 | 17944.99 | Excavacion | 1050 | 17.0904666666667 |
| A4380 |  | Excavacion Localizada - Sobreexcavacion |  | 31d | 2024-10-15 | 2024-11-20 | A4350 SS | 21d | 11d | Capataz [8.91 h]; Peon [44.3 h]; Operador equipo Pesado [44.3 h]; Excavadora Cat 336 [44.3 h]; Petroleo [376.59 gln] | 1 | 1330.23 | m3 | 1 | 1 | 1330.23 | Excavacion | 240 | 5.542625 |
| A4340 |  | Perfilado y Conformacion de Plataforma de Fundacion |  | 28d | 2024-10-21 | 2024-11-22 | A4330 SS+5d | 10d | 0d | Capataz [3.59 h]; Peon [44.22 h]; Operador equipo Pesado [78.88 h]; Operador equipo Liviano [16.73 h]; Cisterna 5000 gln [16.73 h]; Motoniveladora 140K [39.44 h]; Rodillo liso vibratorio 10 - 12 ton [39.44 h]; Petroleo [339.4 gln] | 1 | 11950.82 | m2 | 1 | 1 | 11950.82 | Excavacion | 2400 | 4.97950833333333 |

| ID | WBS | Activity | Duration | Start | Finish | Predecessors | Total float | Free float | Resources | Cuadrilla | Rendimiento | Metrado | Unidad | Turno | RCuad | DurCal | Dur. Cal. | AGrupo |
| --- | --- | --- | --- | --- | --- | --- | --- | --- | --- | --- | --- | --- | --- | --- | --- | --- | --- | --- |
|  | 2 | **RELLENOS** |  | 2024-10-26 | 2024-12-07 |  |  |  |  |  |  |  |  |  |  |  |  |  |
| A4390 |  | Relleno con Material Granular (incluye extraccion de material, zarandeo y combinado) | 25d | 2024-10-26 | 2024-11-25 | A4340 SS+5d | 10d | 0d | Capataz [389.78 h]; Operario [97.79 h]; Oficial [285.1 h]; Peon [1021.97 h]; Peon - Vigia [60.6 h]; Operador equipo Pesado [1504.03 h]; Operador equipo Liviano [588.11 h]; Cisterna 5000 gln [192.82 h]; Volquete 15 m3 [296.12 h]; Cargador Frontal 966 [449 h]; Chancadora Primaria [221.75 h]; Excavadora Cat 336 [347.08 h]; Retroexcavadora sobre llantas 58 hp [49.58 h]; Rodillo liso vibratorio 10 - 12 ton [187.31 h]; Rodillo liso vibratorio 0.80 - 1.10 ton [97.79 h]; Tractor D6 [249.29 h]; Petroleo [10664.5 gln] | 1 | 560 | 13773.13 | m3 | 1 | 1 | 13773.13 | 24.594875 | Relleno |
| A4430 |  | Relleno con Material Seleccionado (incluye extraccion de material, zarandeo y combinado) | 25d | 2024-10-26 | 2024-11-25 | A4390 SS | 17d | 7d | Capataz [8.91 h]; Oficial [44.3 h]; Peon [90.99 h]; Operador equipo Pesado [132.89 h]; Operador equipo Liviano [9.31 h]; Cisterna 5000 gln [9.31 h]; Excavadora Cat 336 [88.59 h]; Rodillo liso vibratorio 10 - 12 ton [44.3 h]; Petroleo [1354.71 gln] | 1 | 240 | 1330.23 | m3 | 1 | 1 | 1330.23 | 5.542625 | Relleno |
| A4420 |  | Perfilado de Talud Dique | 24d | 2024-10-30 | 2024-11-27 | A4390 SS+3d | 15d | 5d | Capataz [15.93 h]; Peon [78.96 h]; Operador equipo Pesado [23.55 h]; Excavadora Cat 336 [23.55 h]; Petroleo [200.18 gln] | 1 | 700 | 6926.57 | m2 | 1 | 1 | 6926.57 | 9.8951 | Relleno |
| A4440 |  | Grava para Drenaje | 7d | 2024-11-26 | 2024-12-03 | A4390 | 10d | 0d | Capataz [20.8 h]; Peon [67.44 h]; Peon - Vigia [2.12 h]; Operador equipo Pesado [27.66 h]; Operador equipo Liviano [62.18 h]; Volquete 15 m3 [10.58 h]; Cargador Frontal 966 [11.87 h]; Chancadora Primaria [7.9 h]; Excavadora Cat 336 [7.9 h]; Retroexcavadora sobre llantas 94 hp [51.6 h]; Tractor D6; Petroleo [352.91 gln] | 1 | 80 | 516.02 | m3 | 1 | 1 | 516.02 | 6.45025 | Relleno |
| A4400 |  | Relleno sin Compactar | 3d | 2024-12-04 | 2024-12-06 | A4490 SS, A4390, A4440, A4360, A4370, A4380, A4420, A4430 | 10d | 0d | Capataz [4.84 h]; Oficial [23.91 h]; Peon [23.91 h]; Operador equipo Pesado [23.91 h]; Tractor D6 [23.91 h]; Petroleo [167.4 gln] | 1 | 900 | 2687.03 | m3 | 1 | 1 | 2687.03 | 2.98558888888889 | Relleno |
| A4410 |  | Relleno Afirmado | 1d | 2024-12-07 | 2024-12-07 | A4400 | 10d |  | Capataz [10.77 h]; Oficial [8.84 h]; Peon [27.81 h]; Peon - Vigia [2.97 h]; Operador equipo Pesado [50.96 h]; Operador equipo Liviano [18.79 h]; Cisterna 5000 gln [4.04 h]; Volquete 15 m3 [14.74 h]; Cargador Frontal 966 [6.26 h]; Chancadora LT200 [6.26 h]; Excavadora Cat 336 [11.74 h]; Motoniveladora 140K [8.84 h]; Rodillo liso vibratorio 10 - 12 ton [8.84 h]; Tractor D6 [2.76 h]; Zaranda Metso ST 4.8 168 HP [6.26 h]; Petroleo [358.93 gln]; CANON POR EXTRACCION CANTERA [375.75] | 1 | 324 | 357.86 | m3 | 1 | 1 | 357.86 | 1.10450617283951 | Relleno |
|  | 3 | **GEOTEXTIL** |  | 2024-10-17 | 2024-12-16 |  |  |  |  |  |  |  |  |  |  |  |  |  |
| A4450 |  | Instalacion de Geotextil 400gr/m2 | 50d | 2024-10-17 | 2024-12-16 | A4480 SS | 4d | 0d | Capataz [30.34 h]; Oficial [300.01 h]; Peon [449.45 h]; Operador equipo Liviano [37.08 h]; Camion grua 20 ton [37.08 h]; Petroleo [148.32 gln]; Geotextil de 400 gr/m2 [12921.8 m2] | 1 | 600 | 11236.32 | m2 | 1 | 1 | 11236.32 | 18.7272 | Geotextil |
| A4460 |  | Zanja de Anclaje | 8d | 2024-12-06 | 2024-12-16 | A4450 FF | 4d | 0d | Capataz [3.62 h]; Oficial [18.12 h]; Peon [54.51 h]; Operador equipo Pesado [18.12 h]; Operador equipo Liviano [0.51 h]; Cisterna 5000 gln [0.51 h]; Retroexcavadora sobre llantas 58 hp [18.12 h]; Petroleo [64.58 gln] | 1 | 32 | 72.5 | m3 | 1 | 1 | 72.5 | 2.265625 | Geotextil |
|  | 4 | **COLOCACION DE ROCA** |  | 2024-10-17 | 2024-12-20 |  |  |  |  |  |  |  |  |  |  |  |  |  |
| A10680 |  | Suministro de Roca | 54d | 2024-10-17 | 2024-12-20 | A4480 SS | 0d |  |  |  |  |  |  |  | 0 |  |  | Roca |
| A4480 |  | Colocacion de Roca en Uña | 28d | 2024-10-17 | 2024-11-19 | A4350 SS+2d | 0d |  | Capataz [64.78 h]; Oficial [129.56 h]; Peon [129.56 h]; Operador equipo Pesado [142.69 h]; Excavadora Cat 336 [129.56 h]; Tractor D6 [13.14 h]; Petroleo [1193.18 gln] | 1 | 280 | 4529.91 | m3 | 1 | 1 | 4529.91 | 16.17825 | Roca |
| A4490 |  | Colocacion de Roca en Talud | 26d | 2024-11-20 | 2024-12-20 | A4480 | 22d | 12d | Capataz [109.72 h]; Oficial [219.98 h]; Peon [219.98 h]; Operador equipo Pesado [461.58 h]; Excavadora Cat 336 [439.43 h]; Tractor D6 [22.16 h]; Petroleo [3890.49 gln] | 1 | 192 | 5275.24 | m3 | 1 | 2 | 2637.62 | 13.7376041666667 | Roca |
|  | 5 | **TRANSPORTES** |  | 2024-10-09 | 2024-12-20 |  |  |  |  |  |  |  |  |  |  |  |  |  |
| A4580 |  | Transporte de Material Organico (a DMO) D<=1km | 15d | 2024-10-09 | 2024-10-25 | A4310 SS | 38d | 0d | Peon - Vigia [17.63 h]; Operador equipo Liviano [87.54 h]; Volquete 15 m3 [87.54 h]; Petroleo [244.99 gln] | 1 |  | 3149.02 | m3k | 1 | 1 | 3149.02 |  | Transportes |
| A4590 |  | Transporte de Material Organico (a DMO) D>1km | 15d | 2024-10-09 | 2024-10-25 | A4580 SS | 38d | 34d | Operador equipo Liviano [398.18 h]; Volquete 15 m3 [398.18 h]; Petroleo [1114.9 gln] | 1 |  | 36198.01 | m3k | 1 | 1 | 36198.01 |  | Transportes |
| A4600 |  | Transporte de Material Excedente D<=1km | 31d | 2024-10-15 | 2024-11-20 | A4330 SS | 17d | 0d | Peon - Vigia [91.52 h]; Operador equipo Liviano [455.8 h]; Volquete 22 m3 [195.6 h]; Volquete 15 m3 [260.2 h]; Petroleo [1527.12 gln] | 1 |  | 17944.99 | m3k | 1 | 1 | 17944.99 |  | Transportes |
| A4610 |  | Transporte de Material Excedente D>1km | 31d | 2024-10-15 | 2024-11-20 | A4600 SS | 17d | 13d | Operador equipo Liviano [2083.25 h]; Volquete 22 m3 [886.93 h]; Volquete 15 m3 [1196.32 h]; Petroleo [6971.66 gln] | 1 |  | 206262.05 | m3k | 1 | 1 | 206262.05 |  | Transportes |
| A4640 |  | Transporte de Roca D<=1km | 54d | 2024-10-17 | 2024-12-20 | A10680 SS | 0d |  | Peon [122.56 h]; Peon - Vigia [56.87 h]; Operador equipo Pesado [122.56 h]; Operador equipo Liviano [284.35 h]; Volquete 22 m3 [284.35 h]; Excavadora Cat 336 [122.56 h]; Petroleo [2208.12 gln]; Peaje local [446.13] | 1 |  | 9805.15 | m3k | 1 | 1 | 9805.15 |  | Transportes |
| A4650 |  | Transporte de Roca D>1km | 54d | 2024-10-17 | 2024-12-20 | A4640 SS | 0d |  | Operador equipo Liviano [345.7 h]; Volquete 22 m3 [345.7 h]; Petroleo [1416.04 gln] | 1 |  | 33240.42 | m3k | 1 | 1 | 33240.42 |  | Transportes |
| A4620 |  | Transporte de Material de Prestamo (Afirmado) D<=1km | 36d | 2024-10-26 | 2024-12-07 | A4390 SS | 10d | 0d | Peon - Vigia [35.54 h]; Operador equipo Liviano [176.85 h]; Volquete 22 m3 [176.85 h]; Petroleo [725.18 gln] | 1 |  | 8461.81 | m3k | 1 | 1 | 8461.81 |  | Transportes |
| A4630 |  | Transporte de Material de Prestamo (Afirmado) D>1km | 36d | 2024-10-26 | 2024-12-07 | A4620 SS | 10d |  | Operador equipo Liviano [245.57 h]; Volquete 22 m3 [245.57 h]; Petroleo [1005.96 gln] | 1 |  | 29587.17 | m3k | 1 | 1 | 29587.17 |  | Transportes |
| A4660 |  | Transporte de Material de Prestamo Cantera de Rio (Cuerpo de Terraplen) D<=1km | 25d | 2024-10-26 | 2024-11-25 | A4390 SS | 13d | 0d | Peon - Vigia [63.43 h]; Operador equipo Liviano [315.66 h]; Volquete 22 m3 [315.66 h]; Petroleo [1294.36 gln] | 1 |  | 15103.36 | m3k | 1 | 1 | 15103.36 |  | Transportes |
| A4670 |  | Transporte de Material de Prestamo Cantera de Rio (Cuerpo de Terraplen) D>1km | 25d | 2024-10-26 | 2024-11-25 | A4660 SS | 13d | 9d | Operador equipo Liviano [945.17 h]; Volquete 22 m3 [945.17 h]; Petroleo [3871.77 gln] | 1 |  | 113875.47 | m3k | 1 | 1 | 113875.47 |  | Transportes |
| A4680 |  | Transporte de Material Seleccionado para Zanja D<=1km | 8d | 2024-12-06 | 2024-12-16 | A4460 SS, A4590, A4610, A4670 | 4d | 0d | Peon - Vigia [0.41 h]; Operador equipo Liviano [2.02 h]; Volquete 15 m3 [2.02 h]; Petroleo [5.64 gln] | 1 |  | 72.5 | m3k | 1 | 1 | 72.5 |  | Transportes |
| A4690 |  | Transporte de Material Seleccionado para Zanja D>1km | 8d | 2024-12-06 | 2024-12-16 | A4680 SS | 4d |  | Operador equipo Liviano [6.02 h]; Volquete 15 m3 [6.02 h]; Petroleo [16.85 gln] | 1 |  | 547.01 | m3k | 1 | 1 | 547.01 |  | Transportes |

| ID | WBS | Activity | Type | Duration | Start | Finish | Predecessors | Total float | Free float | Resources | RCuad | Cuadrilla | Rendimiento | Metrado | Unidad | Turno | DurCal | Dur. Cal. | AGrupo |
| --- | --- | --- | --- | --- | --- | --- | --- | --- | --- | --- | --- | --- | --- | --- | --- | --- | --- | --- | --- |
|  | 4 | **DI-PR-47-D** |  |  | 2025-04-15 | 2025-10-13 |  |  |  |  |  |  |  |  |  |  |  |  |  |
| A10690 |  | Inicio - DE-PR-47-D | milestone | 0d | 2025-04-15 | 2025-04-15 | A10670 FS+96d | 0d |  |  | 0 |  |  |  |  |  |  |  |  |
| A10700 |  | Fin - DE-PR-47-D | milestone | 0d | 2025-10-13 | 2025-10-13 | A5280 FF, A4020 FF, A4240 FF, A4260 FF, A4300 FF | 0d |  |  | 0 |  |  |  |  |  |  |  |  |
|  | 1 | **EXCAVACIONES** |  |  | 2025-04-15 | 2025-07-22 |  |  |  |  |  |  |  |  |  |  |  |  |  |
| A3920 |  | Desbroce |  | 40d | 2025-04-15 | 2025-06-03 | A10690 SS | 0d |  | Capataz [0.32 h]; Peon [64.4 h]; Operador equipo Pesado [48.3 h]; Excavadora Cat 336 [16.1 h]; Tractor D6 [32.2 h]; Petroleo [362.25 gln] | 1 | 1 | 0.8 | 3.22 | ha | 1 | 3.22 | 4.025 | Excavacion |
| A3980 |  | Conformacion de Material Excedente en DMO |  | 40d | 2025-04-15 | 2025-06-03 | A3920 SS | 13d | 2d | Capataz [7.74 h]; Peon [73.49 h]; Operador equipo Pesado [81.22 h]; Excavadora Cat 336 [7.74 h]; Tractor D6 [73.49 h]; Petroleo [580.15 gln] | 1 | 1 | 1050 | 9669.16 | m3 | 1 | 9669.16 | 9.20872380952381 | Excavacion |
| A3940 |  | Excavacion de Cimentacion |  | 69d | 2025-04-23 | 2025-07-14 | A3920 SS+5d | 0d |  | Capataz [80.46 h]; Peon [804.59 h]; Operador equipo Pesado [536.39 h]; Operador equipo Liviano [446.99 h]; Excavadora Cat 336 [357.59 h]; Retroexcavadora sobre llantas 94 hp [446.99 h]; Tractor D8 [178.8 h]; Petroleo [5846.66 gln] | 1 | 1 | 900 | 44699.25 | m3 | 1 | 44699.25 | 49.6658333333333 | Excavacion |
| A3960 |  | Excavacion de Uña |  | 69d | 2025-04-23 | 2025-07-14 | A3940 SS | 0d |  | Capataz [55 h]; Peon [275.01 h]; Operador equipo Pesado [275.01 h]; Excavadora Cat 336 [275.01 h]; Petroleo [3107.64 gln] | 1 | 1 | 500 | 17188.28 | m3 | 1 | 17188.28 | 34.37656 | Excavacion |
| A3970 |  | Conformacion de Material Excedente en DME |  | 69d | 2025-04-23 | 2025-07-14 | A3940 SS | 30d | 28d | Capataz [55 h]; Peon [522.52 h]; Operador equipo Pesado [577.52 h]; Excavadora Cat 336 [55 h]; Tractor D6 [522.52 h]; Petroleo [4125.14 gln] | 1 | 1 | 1050 | 68752.4 | m3 | 1 | 68752.4 | 65.4784761904762 | Excavacion |
| A3990 |  | Excavacion Localizada - Sobreexcavacion |  | 69d | 2025-04-23 | 2025-07-14 | A3960 SS | 30d | 28d | Capataz [90.06 h]; Peon [447.6 h]; Operador equipo Pesado [447.6 h]; Excavadora Cat 336 [447.6 h]; Petroleo [3805.3 gln] | 1 | 1 | 240 | 13441.55 | m3 | 1 | 13441.55 | 56.0064583333333 | Excavacion |
| A3950 |  | Perfilado y Conformacion de Plataforma de Fundacion |  | 64d | 2025-05-08 | 2025-07-22 | A3940 SS+12d | 2d | 0d | Capataz [11.79 h]; Peon [145.41 h]; Operador equipo Pesado [259.37 h]; Operador equipo Liviano [55.02 h]; Cisterna 5000 gln [55.02 h]; Motoniveladora 140K [129.69 h]; Rodillo liso vibratorio 10 - 12 ton [129.69 h]; Petroleo [1116.09 gln] | 1 | 1 | 2400 | 39298.98 | m2 | 1 | 39298.98 | 16.374575 | Excavacion |
|  | 2 | **RELLENOS** |  |  | 2025-05-20 | 2025-10-10 |  |  |  |  |  |  |  |  |  |  |  |  |  |
| A4000 |  | Relleno con Material Granular (incluye extraccion de material, zarandeo y combinado) |  | 84d | 2025-05-20 | 2025-09-01 | A3950 SS+10d | 2d | 0d | Capataz [1330.36 h]; Operario [333.77 h]; Oficial [973.09 h]; Peon [3488.09 h]; Peon - Vigia [206.84 h]; Operador equipo Pesado [5133.42 h]; Operador equipo Liviano [2007.3 h]; Cisterna 5000 gln [658.13 h]; Volquete 15 m3 [1010.7 h]; Cargador Frontal 966 [1532.5 h]; Chancadora Primaria [756.85 h]; Excavadora Cat 336 [1184.64 h]; Retroexcavadora sobre llantas 58 hp [169.23 h]; Rodillo liso vibratorio 10 - 12 ton [639.33 h]; Rodillo liso vibratorio 0.80 - 1.10 ton [333.77 h]; Tractor D6 [850.87 h]; Petroleo [36399.3 gln] | 1 | 1 | 560 | 47009.35 | m3 | 1 | 47009.35 | 83.9452678571428 | Relleno |
| A4040 |  | Relleno con Material Seleccionado (incluye extraccion de material, zarandeo y combinado) |  | 84d | 2025-05-20 | 2025-09-01 | A4000 SS | 22d | 20d | Capataz [91.12 h]; Oficial [452.9 h]; Peon [930.28 h]; Operador equipo Pesado [1358.7 h]; Operador equipo Liviano [95.2 h]; Cisterna 5000 gln [95.2 h]; Excavadora Cat 336 [905.8 h]; Rodillo liso vibratorio 10 - 12 ton [452.9 h]; Petroleo [13850.9 gln] | 1 | 1 | 240 | 13600.63 | m3 | 1 | 13600.63 | 56.6692916666667 | Relleno |
| A4030 |  | Perfilado de Talud Dique |  | 80d | 2025-06-06 | 2025-09-13 | A4000 SS+15d, A3980 | 11d | 9d | Capataz [49.47 h]; Peon [245.19 h]; Operador equipo Pesado [73.13 h]; Excavadora Cat 336 [73.13 h]; Petroleo [621.57 gln] | 1 | 1 | 700 | 21507.64 | m2 | 1 | 21507.64 | 30.7252 | Relleno |
| A4050 |  | Grava para Drenaje |  | 29d | 2025-08-21 | 2025-09-24 | A4000 SS+75d, A3970, A3990 | 2d | 0d | Capataz [93.13 h]; Peon [302.03 h]; Peon - Vigia [9.47 h]; Operador equipo Pesado [123.86 h]; Operador equipo Liviano [278.46 h]; Volquete 15 m3 [47.37 h]; Cargador Frontal 966 [53.15 h]; Chancadora Primaria [35.36 h]; Excavadora Cat 336 [35.36 h]; Retroexcavadora sobre llantas 94 hp [231.09 h]; Tractor D6; Petroleo [1580.4 gln] | 1 | 1 | 80 | 2310.86 | m3 | 1 | 2310.86 | 28.88575 | Relleno |
| A4010 |  | Relleno sin Compactar |  | 9d | 2025-09-25 | 2025-10-04 | A4100 SS, A4000, A4050, A4030, A4040 | 2d | 0d | Capataz [13.18 h]; Oficial [65.19 h]; Peon [65.19 h]; Operador equipo Pesado [65.19 h]; Tractor D6 [65.19 h]; Petroleo [456.31 gln] | 1 | 1 | 900 | 7324.39 | m3 | 1 | 7324.39 | 8.13821111111111 | Relleno |
| A4020 |  | Relleno Afirmado |  | 4d | 2025-10-06 | 2025-10-10 | A4010 | 2d |  | Capataz [35.32 h]; Oficial [28.98 h]; Peon [91.16 h]; Peon - Vigia [9.74 h]; Operador equipo Pesado [167.07 h]; Operador equipo Liviano [61.6 h]; Cisterna 5000 gln [13.26 h]; Volquete 15 m3 [48.34 h]; Cargador Frontal 966 [20.53 h]; Chancadora LT200 [20.53 h]; Excavadora Cat 336 [38.48 h]; Motoniveladora 140K [28.98 h]; Rodillo liso vibratorio 10 - 12 ton [28.98 h]; Tractor D6 [9.03 h]; Zaranda Metso ST 4.8 168 HP [20.53 h]; Petroleo [1176.79 gln]; CANON POR EXTRACCION CANTERA [1231.93] | 1 | 1 | 324 | 1173.27 | m3 | 1 | 1173.27 | 3.6212037037037 | Relleno |
|  | 3 | **GEOTEXTIL** |  |  | 2025-05-10 | 2025-10-10 |  |  |  |  |  |  |  |  |  |  |  |  |  |
| A4060 |  | Instalacion de Geotextil 400gr/m2 |  | 125d | 2025-05-10 | 2025-10-10 | A4090 SS | 2d | 0d | Capataz [111.53 h]; Oficial [1102.94 h]; Peon [1652.34 h]; Operador equipo Liviano [136.32 h]; Camion grua 20 ton [136.32 h]; Petroleo [545.27 gln]; Geotextil de 400 gr/m2 [47504.8 m2] | 1 | 1 | 600 | 41308.53 | m2 | 1 | 41308.53 | 68.84755 | Geotextil |
| A4070 |  | Zanja de Anclaje |  | 8d | 2025-10-01 | 2025-10-10 | A4060 FF | 2d | 0d | Capataz [11.88 h]; Oficial [59.38 h]; Peon [178.55 h]; Operador equipo Pesado [59.38 h]; Operador equipo Liviano [1.66 h]; Cisterna 5000 gln [1.66 h]; Retroexcavadora sobre llantas 58 hp [59.38 h]; Petroleo [211.54 gln] | 1 | 1 | 32 | 237.5 | m3 | 1 | 237.5 | 7.421875 | Geotextil |
|  | 4 | **COLOCACION DE ROCA** |  |  | 2025-05-10 | 2025-10-13 |  |  |  |  |  |  |  |  |  |  |  |  |  |
| A10710 |  | Suministro de Roca |  | 127d | 2025-05-10 | 2025-10-13 | A4090 SS | 0d |  |  | 0 |  |  |  |  |  |  |  | Roca |
| A4090 |  | Colocacion de Roca en Uña |  | 62d | 2025-05-10 | 2025-07-22 | A3960 SS+14d | 0d |  | Capataz [245.79 h]; Oficial [491.58 h]; Peon [491.58 h]; Operador equipo Pesado [541.43 h]; Excavadora Cat 336 [491.58 h]; Tractor D6 [49.85 h]; Petroleo [4527.39 gln] | 1 | 1 | 280 | 17188.28 | m3 | 1 | 17188.28 | 61.3867142857143 | Roca |
| A4100 |  | Colocacion de Roca en Talud |  | 65d | 2025-07-24 | 2025-10-13 | A4090 | 1d | 50d | Capataz [538.4 h]; Oficial [1079.39 h]; Peon [1079.39 h]; Operador equipo Pesado [2264.91 h]; Excavadora Cat 336 [2156.2 h]; Tractor D6 [108.72 h]; Petroleo [19090 gln] | 2 | 2 | 192 | 25884.71 | m3 | 1 | 12942.355 | 67.4080989583333 | Roca |

| ID | WBS | Activity | Duration | Start | Finish | Predecessors | Total float | Free float | Resources | Cuadrilla | Metrado | Unidad | Turno | RCuad | DurCal | AGrupo |
| --- | --- | --- | --- | --- | --- | --- | --- | --- | --- | --- | --- | --- | --- | --- | --- | --- |
|  | 5 | **TRANSPORTES** |  | 2025-04-15 | 2025-10-13 |  |  |  |  |  |  |  |  |  |  |  |
| A4190 |  | Transporte de Material Organico (a DMO) D<=1km | 40d | 2025-04-15 | 2025-06-03 | A3920 SS | 98d | 0d | Peon - Vigia [54.15 h]; Operador equipo Liviano [268.8 h]; Volquete 15 m3 [268.8 h]; Petroleo [752.26 gln] | 1 | 9669.16 | m3k | 1 | 1 | 9669.16 | Transportes |
| A4200 |  | Transporte de Material Organico (a DMO) D>1km | 40d | 2025-04-15 | 2025-06-03 | A4190 SS | 98d | 96d | Operador equipo Liviano [1342.8 h]; Volquete 15 m3 [1342.8 h]; Petroleo [3759.85 gln] | 1 | 122073.09 | m3k | 1 | 1 | 122073.09 | Transportes |
| A4210 |  | Transporte de Material Excedente D<=1km | 69d | 2025-04-23 | 2025-07-14 | A3940 SS | 64d | 0d | Peon - Vigia [350.64 h]; Operador equipo Liviano [1746.31 h]; Volquete 22 m3 [749.4 h]; Volquete 15 m3 [996.91 h]; Petroleo [5850.83 gln] | 1 | 68752.4 | m3k | 1 | 1 | 68752.4 | Transportes |
| A4220 |  | Transporte de Material Excedente D>1km | 69d | 2025-04-23 | 2025-07-14 | A4210 SS | 64d | 62d | Operador equipo Liviano [8742.54 h]; Volquete 22 m3 [3722.07 h]; Volquete 15 m3 [5020.47 h]; Petroleo [29257.2 gln] | 1 | 865598.31 | m3k | 1 | 1 | 865598.31 | Transportes |
| A4250 |  | Transporte de Roca D<=1km | 127d | 2025-05-10 | 2025-10-13 | A10710 SS | 0d |  | Peon [540.29 h]; Peon - Vigia [250.69 h]; Operador equipo Pesado [540.29 h]; Operador equipo Liviano [1253.47 h]; Volquete 22 m3 [1253.47 h]; Excavadora Cat 336 [540.29 h]; Petroleo [9733.82 gln]; Peaje local [1966.65] | 1 | 43222.99 | m3k | 1 | 1 | 43222.99 | Transportes |
| A4260 |  | Transporte de Roca D>1km | 127d | 2025-05-10 | 2025-10-13 | A4250 SS | 0d |  | Operador equipo Liviano [2024.52 h]; Volquete 22 m3 [2024.52 h]; Petroleo [8292.74 gln] | 1 | 194665.32 | m3k | 1 | 1 | 194665.32 | Transportes |
| A4230 |  | Transporte de Material de Prestamo (Afirmado) D<=1km | 117d | 2025-05-20 | 2025-10-10 | A4000 SS | 2d | 0d | Peon - Vigia [144.03 h]; Operador equipo Liviano [716.73 h]; Volquete 22 m3 [716.73 h]; Petroleo [2938.94 gln] | 1 | 34293.38 | m3k | 1 | 1 | 34293.38 | Transportes |
| A4240 |  | Transporte de Material de Prestamo (Afirmado) D>1km | 117d | 2025-05-20 | 2025-10-10 | A4230 SS | 2d |  | Operador equipo Liviano [2793.27 h]; Volquete 22 m3 [2793.27 h]; Petroleo [11442.3 gln] | 1 | 336539.07 | m3k | 1 | 1 | 336539.07 | Transportes |
| A4270 |  | Transporte de Material de Prestamo Cantera de Rio (Cuerpo de Terraplen) D<=1km | 84d | 2025-05-20 | 2025-09-01 | A4000 SS | 27d | 0d | Peon - Vigia [254.56 h]; Operador equipo Liviano [1266.75 h]; Volquete 22 m3 [1266.75 h]; Petroleo [5194.28 gln] | 1 | 60609.98 | m3k | 1 | 1 | 60609.98 | Transportes |
| A4280 |  | Transporte de Material de Prestamo Cantera de Rio (Cuerpo de Terraplen) D>1km | 84d | 2025-05-20 | 2025-09-01 | A4270 SS | 27d | 25d | Operador equipo Liviano [663.52 h]; Volquete 22 m3 [663.52 h]; Petroleo [2718.04 gln] | 1 | 79942.48 | m3k | 1 | 1 | 79942.48 | Transportes |
| A4290 |  | Transporte de Material Seleccionado para Zanja D<=1km | 8d | 2025-10-01 | 2025-10-10 | A4070 SS, A4200, A4220, A4280 | 2d | 0d | Peon - Vigia [1.33 h]; Operador equipo Liviano [6.6 h]; Volquete 15 m3 [6.6 h]; Petroleo [18.48 gln] | 1 | 237.5 | m3k | 1 | 1 | 237.5 | Transportes |
| A4300 |  | Transporte de Material Seleccionado para Zanja D>1km | 8d | 2025-10-01 | 2025-10-10 | A4290 SS | 2d |  | Operador equipo Liviano [3.33 h]; Volquete 15 m3 [3.33 h]; Petroleo [9.33 gln] | 1 | 302.81 | m3k | 1 | 1 | 302.81 | Transportes |
|  | 6 | **INTERFERENCIAS** |  | 2025-05-06 | 2025-06-17 |  |  |  |  |  |  |  |  |  |  |  |
|  | 1 | **CANAL DE-PR-47-D-CAN03** |  | 2025-05-06 | 2025-05-19 |  |  |  |  |  |  |  |  |  |  |  |
| A4700 |  | Trazo y replanteo de interferencia | 12d | 2025-05-06 | 2025-05-19 | A10690 SS+15d | 95d | 0d | Capataz [1.63 h]; Peon [32.61 h]; Topografo [16.3 h]; GPS [16.3 h]; MADERA TORNILLO [16.3]; PINTURA ESMALTE [1.63] |  | 815.15 | m2 |  | 0 |  | Interferencias |
| A4720 |  | Desvío provisional en tierras | 12d | 2025-05-06 | 2025-05-19 | A4700 SS | 95d | 0d | Capataz [7.71 h]; Peon [38.51 h]; Operador equipo Pesado [38.51 h]; Excavadora Cat 336 [38.51 h]; Petroleo [327.35 gln] |  | 288.9 | m |  | 0 |  | Interferencias |
| A4730 |  | Limpieza de terreno manual | 12d | 2025-05-06 | 2025-05-19 | A4720 SS | 95d | 0d | Capataz [0.33 h]; Oficial [6.52 h]; Peon [13.04 h]; Operador equipo Pesado [2.45 h]; Excavadora Cat 336 [0.82 h]; Tractor D6 [1.63 h]; Petroleo [18.34 gln] |  | 815.15 | m2 |  | 0 |  | Interferencias |
| A4750 |  | Excavacion no clasificada de zanja | 12d | 2025-05-06 | 2025-05-19 | A4730 SS | 95d | 0d | Capataz [0.79 h]; Peon [7.88 h]; Operador equipo Pesado [7.88 h]; Excavadora Cat 336 [7.88 h]; Petroleo [66.96 gln] |  | 157.56 | m3 |  | 0 |  | Interferencias |
| A4760 |  | Relleno estructural | 12d | 2025-05-06 | 2025-05-19 | A4750 SS | 95d | 0d | Capataz [1.32 h]; Operario [4.77 h]; Oficial [4.77 h]; Peon [11.4 h]; Peon - Vigia [0.15 h]; Operador equipo Pesado [5.04 h]; Operador equipo Liviano [6.19 h]; Cisterna 5000 gln [0.7 h]; Volquete 15 m3 [0.72 h]; Cargador Frontal 966 [1.1 h]; Chancadora Primaria [0.54 h]; Excavadora Cat 336 [0.86 h]; Retroexcavadora sobre llantas 58 hp [2.38 h]; Rodillo liso vibratorio 0.80 - 1.10 ton [4.77 h]; Tractor D6 [0.16 h]; Petroleo [35.52 gln] |  | 33.35 | m3 |  | 0 |  | Interferencias |
| A4860 |  | Emboquillado de piedra e=0.20m | 12d | 2025-05-06 | 2025-05-19 | A4760 SS | 95d | 0d | Capataz [11.76 h]; Operario [33.97 h]; Oficial [67.93 h]; Peon [111.09 h]; Peon - Vigia [0.11 h]; Operador equipo Pesado [0.16 h]; Operador equipo Liviano [23.97 h]; Cisterna 5000 gln [0.3 h]; Volquete 15 m3 [1.06 h]; Excavadora Cat 336 [0.16 h]; Retroexcavadora sobre llantas 94 hp [22.6 h]; Zaranda estatica [2.28 h]; Petroleo [62.01 gln]; ARENA GRUESA [9.81]; CEMENTO PORTLAND TIPO I (42.5 kg) [95.57] |  | 121.9 | m2 |  | 0 |  | Interferencias |
| A4930 |  | Sello en juntas | 12d | 2025-05-06 | 2025-05-19 | A4860 SS | 95d | 0d | Capataz [3.31 h]; Operario [13.25 h]; Peon [3.31 h]; TECNOPOR DE 1/2"X4X8' [2.27]; SELLADOR ELASTICO POLIURETANO SIKAFLEX 1A [11.37] |  | 39.75 | m |  | 0 |  | Interferencias |
|  | 2 | **DI-PR-47-TL-01** |  | 2025-05-20 | 2025-06-17 |  |  |  |  |  |  |  |  |  |  |  |
| A5000 |  | Trazo y replanteo de interferencia | 24d | 2025-05-20 | 2025-06-17 | A4930 | 95d | 0d | Capataz [0.64 h]; Peon [12.72 h]; Topografo [6.36 h]; GPS [6.36 h]; MADERA TORNILLO [6.36]; PINTURA ESMALTE [0.64] |  | 318.05 | m2 |  | 0 |  | Interferencias |
| A5010 |  | Desvío provisional con tubería | 24d | 2025-05-20 | 2025-06-17 | A5000 SS | 95d | 0d | Capataz [12.29 h]; Operario [21.17 h]; Oficial [21.17 h]; Peon [135.53 h]; Operador equipo Pesado [8.47 h]; Operador equipo Liviano [5.29 h]; Camion grua 20 ton [5.29 h]; Excavadora Cat 336 [8.47 h]; Petroleo [93.15 gln]; TUBERIA CORRUGADA HDPE D=630 mm [66.71] |  | 63.53 | m |  | 0 |  | Interferencias |
| A5030 |  | Limpieza de terreno manual | 24d | 2025-05-20 | 2025-06-17 | A5010 SS | 95d | 0d | Capataz [0.13 h]; Oficial [2.54 h]; Peon [5.09 h]; Operador equipo Pesado [0.95 h]; Excavadora Cat 336 [0.32 h]; Tractor D6 [0.64 h]; Petroleo [7.16 gln] |  | 318.05 | m2 |  | 0 |  | Interferencias |
| A5040 |  | Excavaciones no clasificada para estructuras | 24d | 2025-05-20 | 2025-06-17 | A5030 SS | 95d | 0d | Capataz [1.99 h]; Peon [9.96 h]; Operador equipo Pesado [9.96 h]; Excavadora Cat 336 [9.96 h]; Petroleo [84.63 gln] |  | 311.15 | m3 |  | 0 |  | Interferencias |
| A5050 |  | Excavacion no clasificada de zanja | 24d | 2025-05-20 | 2025-06-17 | A5040 SS | 95d | 0d | Capataz [0.21 h]; Peon [2.08 h]; Operador equipo Pesado [2.08 h]; Excavadora Cat 336 [2.08 h]; Petroleo [17.64 gln] |  | 41.5 | m3 |  | 0 |  | Interferencias |
| A5060 |  | Relleno estructural | 24d | 2025-05-20 | 2025-06-17 | A5050 SS | 95d | 0d | Capataz [8.86 h]; Operario [31.96 h]; Oficial [31.96 h]; Peon [76.44 h]; Peon - Vigia [0.98 h]; Operador equipo Pesado [33.79 h]; Operador equipo Liviano [41.51 h]; Cisterna 5000 gln [4.72 h]; Volquete 15 m3 [4.83 h]; Cargador Frontal 966 [7.4 h]; Chancadora Primaria [3.6 h]; Excavadora Cat 336 [5.75 h]; Retroexcavadora sobre llantas 58 hp [15.97 h]; Rodillo liso vibratorio 0.80 - 1.10 ton [31.96 h]; Tractor D6 [1.07 h]; Petroleo [238.19 gln] |  | 223.65 | m3 |  | 0 |  | Interferencias |
| A5070 |  | Suministro de roca (Alcantarillas) | 24d | 2025-05-20 | 2025-06-17 | A5060 SS | 95d | 0d | Capataz [4.7 h]; Peon [11.25 h]; Peon - Vigia [0.87 h]; Operador equipo Pesado [11.25 h]; Operador equipo Liviano [17.4 h]; Volquete 22 m3 [17.4 h]; Excavadora Cat 336 [11.25 h]; Petroleo [166.97 gln]; Peaje local [6.83] |  | 150 | m3 |  | 0 |  | Interferencias |
| A5080 |  | Colocación de roca en uña (Alcantarillas) | 24d | 2025-05-20 | 2025-06-17 | A5070 SS | 95d | 0d | Capataz [3.12 h]; Oficial [6.25 h]; Peon [6.25 h]; Operador equipo Pesado [7.5 h]; Excavadora Cat 336 [6.25 h]; Tractor D6 [1.25 h]; Petroleo [61.89 gln] |  | 150 | m3 |  | 0 |  | Interferencias |
| A5090 |  | Concreto de Nivelacion (f'c=100 kg/cm2) | 24d | 2025-05-20 | 2025-06-17 | A5080 SS | 95d | 0d | Capataz [0.56 h]; Operario [0.63 h]; Oficial [0.99 h]; Peon [5.23 h]; Operador equipo Liviano [0.67 h]; Cisterna 5000 gln [0.04 h]; Carmix 4.0 m3 [0.63 h]; Petroleo [3.29 gln]; PIEDRA CHANCADA [1.02]; ARENA GRUESA [0.86]; CEMENTO PORTLAND TIPO I (42.5 kg) [9.39] |  | 1.49 | m3 |  | 0 |  | Interferencias |
| A5110 |  | Concreto Clase C (f'c=280 kg/cm2) Premezclado - Cimientos reforzados | 24d | 2025-05-20 | 2025-06-17 | A5090 SS | 95d | 0d | Capataz [4.37 h]; Operario [12.58 h]; Oficial [17.46 h]; Peon [40.55 h]; Operador equipo Liviano [7.69 h]; Carmix 4.0 m3 [7.69 h]; Petroleo [40.91 gln]; PIEDRA CHANCADA [12.5]; ARENA GRUESA [10.58]; CEMENTO PORTLAND TIPO I (42.5 kg) [201.98]; PLASTIMENT TM-40 - PLASTIFICANTE [41.36]; ADITIVO CURADOR DE CONCRETO [2.75] |  | 18.32 | m3 |  | 0 |  | Interferencias |
| A5120 |  | Concreto Clase C (f'c=280 kg/cm2) Premezclado - Muros de contencion | 24d | 2025-05-20 | 2025-06-17 | A5110 SS | 95d | 0d | Capataz [5.71 h]; Operario [16.46 h]; Oficial [22.85 h]; Peon [59.45 h]; Operador equipo Liviano [10.07 h]; Carmix 4.0 m3 [10.07 h]; Petroleo [53.53 gln]; PIEDRA CHANCADA [16.36]; ARENA GRUESA [13.84]; CEMENTO PORTLAND TIPO I (42.5 kg) [264.27]; PLASTIMENT TM-40 - PLASTIFICANTE [54.11]; ADITIVO CURADOR DE CONCRETO [3.6] |  | 23.97 | m3 |  | 0 |  | Interferencias |
| A5130 |  | Encofrado y Desencofrado Caravista | 24d | 2025-05-20 | 2025-06-17 | A5120 SS | 95d | 0d | Capataz [3.96 h]; Operario [19.77 h]; Oficial [19.77 h]; Peon [39.55 h]; ALAMBRE NEGRO #8 [7.91]; CLAVOS PARA MADERA CON CABEZA DE 3" [7.91]; LACA DESMOLDEADORA [1.19]; MADERA TORNILLO INCLUYE CORTE PARA ENCOFRADO [118.65]; TRIPLAY DE 19 mm PARA ENCOFRADO [3.44] |  | 39.55 | m2 |  | 0 |  | Interferencias |
| A5140 |  | Encofrado y Desencofrado Cara Oculta | 24d | 2025-05-20 | 2025-06-17 | A5130 SS | 95d | 0d | Capataz [9.86 h]; Operario [98.58 h]; Oficial [98.58 h]; ALAMBRE NEGRO #8 [44.36]; CLAVOS PARA MADERA CON CABEZA DE 3" [31.05]; MADERA TORNILLO INCLUYE CORTE PARA ENCOFRADO [739.3] |  | 147.86 | m2 |  | 0 |  | Interferencias |
| A5150 |  | Acero de refuerzo f'y=4200kg/cm2 | 24d | 2025-05-20 | 2025-06-17 | A5140 SS | 95d | 0d | Capataz [6.39 h]; Operario [64.39 h]; Oficial [64.39 h]; Peon [32.2 h]; ALAMBRE NEGRO #16 [133.04]; ACERO CORRUGADO fy = 4200 kg/cm2 GRADO 60 [2793.87] |  | 2660.83 | kg |  | 0 |  | Interferencias |
| A5160 |  | Emboquillado de piedra e=0.20m | 24d | 2025-05-20 | 2025-06-17 | A5150 SS | 95d | 0d | Capataz [2.05 h]; Operario [5.92 h]; Oficial [11.84 h]; Peon [19.37 h]; Peon - Vigia [0.02 h]; Operador equipo Pesado [0.03 h]; Operador equipo Liviano [4.18 h]; Cisterna 5000 gln [0.05 h]; Volquete 15 m3 [0.18 h]; Excavadora Cat 336 [0.03 h]; Retroexcavadora sobre llantas 94 hp [3.94 h]; Zaranda estatica [0.4 h]; Petroleo [10.81 gln]; ARENA GRUESA [1.71]; CEMENTO PORTLAND TIPO I (42.5 kg) [16.66] |  | 21.25 | m2 |  | 0 |  | Interferencias |
| A5190 |  | Cama de arena e=0.20m | 24d | 2025-05-20 | 2025-06-17 | A5160 SS | 95d | 0d | Capataz [0.64 h]; Operario [3.19 h]; Oficial [6.39 h]; Peon [12.83 h]; Peon - Vigia [0.06 h]; Operador equipo Liviano [0.56 h]; Cisterna 5000 gln [0.22 h]; Volquete 22 m3 [0.34 h]; Petroleo [5.14 gln]; ARENA GRUESA [17.57] |  | 79.85 | m2 |  | 0 |  | Interferencias |
| A5200 |  | Tubería HDPE Corrugada Ø=900mm (Suministro e instalación) | 24d | 2025-05-20 | 2025-06-17 | A5190 SS | 95d | 0d | Capataz [13.18 h]; Operario [13.18 h]; Oficial [26.35 h]; Peon [26.35 h]; Operador equipo Pesado [6.59 h]; Operador equipo Liviano [3.29 h]; Camion grua 20 ton [3.29 h]; Excavadora Cat 336 [6.59 h]; Petroleo [69.18 gln]; Tubería HDPE Corrugado de 900 mm [43.48] |  | 39.53 | m |  | 0 |  | Interferencias |
| A5220 |  | Compuerta metálica tipo tarjeta 1.00x1.00m (Suministro e instalacion) | 24d | 2025-05-20 | 2025-06-17 | A5200 SS | 95d | 0d | Capataz [2 h]; Operario [8 h]; Oficial [8 h]; Peon [8 h]; Operador equipo Liviano [1 h]; Camion grua 20 ton [1 h]; Petroleo [4 gln]; Suministro de Compuerta plana tipo tarjeta 1.00 x 1.00m [1] |  | 1 | und |  | 0 |  | Interferencias |
| A5230 |  | Sello en juntas | 24d | 2025-05-20 | 2025-06-17 | A5220 SS | 95d | 0d | Capataz [0.71 h]; Operario [2.83 h]; Peon [0.71 h]; TECNOPOR DE 1/2"X4X8' [0.48]; SELLADOR ELASTICO POLIURETANO SIKAFLEX 1A [2.43] |  | 8.5 | m |  | 0 |  | Interferencias |
| A5240 |  | Waterstop (anillos de estanqueidad) | 24d | 2025-05-20 | 2025-06-17 | A5230 SS | 95d | 0d | Capataz [0.2 h]; Operario [2 h]; Peon [4 h]; WATER STOP (anillos de estanqueidad); DN=900mm [1.82] |  | 2 | und |  | 0 |  | Interferencias |
| A5250 |  | Pintura bituminosa | 24d | 2025-05-20 | 2025-06-17 | A5240 SS | 95d | 0d | Capataz [1.49 h]; Operario [14.89 h]; Peon [29.78 h]; PINTURA ASFALTICA [29.78]; IMPRIMANTE ASFALTICO [13.03] |  | 74.46 | m2 |  | 0 |  | Interferencias |
| A5260 |  | Suministro e Instalación de geotextil | 24d | 2025-05-20 | 2025-06-17 | A5250 SS | 95d | 0d | Capataz [0.18 h]; Oficial [1.81 h]; Peon [2.72 h]; Operador equipo Liviano [0.22 h]; Camion grua 20 ton [0.22 h]; Petroleo [0.9 gln]; Geotextil no tejido 200gr/m2 [81.48] |  | 67.9 | m2 |  | 0 |  | Interferencias |
| A5270 |  | Baranda metálica (suministro e instalación) | 24d | 2025-05-20 | 2025-06-17 | A5260 SS | 95d | 0d |  |  | 1 | m |  | 0 |  | Interferencias |
| A5280 |  | Rejilla metálica de 2.8mx1.50m (Suministro e instalación) | 24d | 2025-05-20 | 2025-06-17 | A5270 SS | 95d |  | Capataz [0.4 h]; Operario [4 h]; Peon [16 h]; Operador equipo Liviano [2 h]; Camion grua 20 ton [2 h]; Petroleo [8 gln] |  | 1 | und |  | 0 |  | Interferencias |

| ID | WBS | Activity | Type | Duration | Start | Finish | Predecessors | Total float | Free float | Resources | RCuad | Cuadrilla | Rendimiento | Metrado | Unidad | Turno | DurCal | Dur. Cal. | AGrupo |
| --- | --- | --- | --- | --- | --- | --- | --- | --- | --- | --- | --- | --- | --- | --- | --- | --- | --- | --- | --- |
|  | 8 | **DI-PR-51-I** |  |  | 2025-04-15 | 2025-08-02 |  |  |  |  |  |  |  |  |  |  |  |  |  |
| A10720 |  | Inicio - DE-PR-51-D | milestone | 0d | 2025-04-15 | 2025-04-15 | A10670 FS+96d | 0d |  |  | 0 |  |  |  |  |  |  |  |  |
| A10730 |  | Fin - DE-PR-51-D | milestone | 0d | 2025-08-02 | 2025-08-02 | A5540 FF, A5640 FF | 58d |  |  | 0 |  |  |  |  |  |  |  |  |
|  | 1 | **EXCAVACIONES** |  |  | 2025-04-15 | 2025-05-22 |  |  |  |  |  |  |  |  |  |  |  |  |  |
| A5300 |  | Desbroce |  | 15d | 2025-04-15 | 2025-05-05 | A10720 SS | 0d |  | Capataz [0.17 h]; Peon [33 h]; Operador equipo Pesado [24.75 h]; Excavadora Cat 336 [8.25 h]; Tractor D6 [16.5 h]; Petroleo [185.62 gln] | 1 | 1 | 0.8 | 1.65 | ha | 1 | 1.65 | 2.0625 | Excavacion |
| A5360 |  | Conformacion de Material Excedente en DMO |  | 15d | 2025-04-15 | 2025-05-05 | A5300 SS | 108d | 47d | Capataz [3.96 h]; Peon [37.58 h]; Operador equipo Pesado [41.54 h]; Excavadora Cat 336 [3.96 h]; Tractor D6 [37.58 h]; Petroleo [296.71 gln] | 1 | 1 | 1050 | 4945.13 | m3 | 1 | 4945.13 | 4.70964761904762 | Excavacion |
| A5320 |  | Excavacion de Cimentacion |  | 26d | 2025-04-19 | 2025-05-20 | A5300 SS+2d | 0d |  | Capataz [37.46 h]; Peon [374.6 h]; Operador equipo Pesado [249.74 h]; Operador equipo Liviano [208.11 h]; Excavadora Cat 336 [166.49 h]; Retroexcavadora sobre llantas 94 hp [208.11 h]; Tractor D8 [83.25 h]; Petroleo [2722.12 gln] | 1 | 1 | 900 | 20811.35 | m3 | 1 | 20811.35 | 23.1237222222222 | Excavacion |
| A5340 |  | Excavacion de Uña |  | 26d | 2025-04-19 | 2025-05-20 | A5320 SS | 58d | 0d | Capataz [45.73 h]; Peon [228.65 h]; Operador equipo Pesado [228.65 h]; Excavadora Cat 336 [228.65 h]; Petroleo [2583.77 gln] | 1 | 1 | 500 | 14290.79 | m3 | 1 | 14290.79 | 28.58158 | Excavacion |
| A5350 |  | Conformacion de Material Excedente en DME |  | 26d | 2025-04-19 | 2025-05-20 | A5320 SS | 95d | 34d | Capataz [28.63 h]; Peon [271.95 h]; Operador equipo Pesado [300.57 h]; Excavadora Cat 336 [28.63 h]; Tractor D6 [271.95 h]; Petroleo [2146.95 gln] | 1 | 1 | 1050 | 35782.45 | m3 | 1 | 35782.45 | 34.0785238095238 | Excavacion |
| A5330 |  | Perfilado y Conformacion de Plataforma de Fundacion |  | 21d | 2025-04-28 | 2025-05-22 | A5320 SS+7d | 68d | 0d | Capataz [5.45 h]; Peon [67.21 h]; Operador equipo Pesado [119.89 h]; Operador equipo Liviano [25.43 h]; Cisterna 5000 gln [25.43 h]; Motoniveladora 140K [59.95 h]; Rodillo liso vibratorio 10 - 12 ton [59.95 h]; Petroleo [515.9 gln] | 1 | 1 | 2400 | 18165.48 | m2 | 1 | 18165.48 | 7.56895 | Excavacion |
|  | 2 | **RELLENOS** |  |  | 2025-05-08 | 2025-06-21 |  |  |  |  |  |  |  |  |  |  |  |  |  |
| A5380 |  | Relleno con Material Granular (incluye extraccion de material, zarandeo y combinado) |  | 38d | 2025-05-08 | 2025-06-21 | A5330 SS+8d | 68d | 0d | Capataz [7.11 h]; Operario [1.78 h]; Oficial [5.2 h]; Peon [18.64 h]; Peon - Vigia [1.11 h]; Operador equipo Pesado [27.44 h]; Operador equipo Liviano [10.73 h]; Cisterna 5000 gln [3.52 h]; Volquete 15 m3 [5.4 h]; Cargador Frontal 966 [8.19 h]; Chancadora Primaria [4.05 h]; Excavadora Cat 336 [6.33 h]; Retroexcavadora sobre llantas 58 hp [0.9 h]; Rodillo liso vibratorio 10 - 12 ton [3.42 h]; Rodillo liso vibratorio 0.80 - 1.10 ton [1.78 h]; Tractor D6 [4.55 h]; Petroleo [194.56 gln] | 1 | 1 | 560 | 251.27 | m3 | 1 | 251.27 | 0.448696428571429 | Relleno |
| A5420 |  | Relleno con Material Seleccionado (incluye extraccion de material, zarandeo y combinado) |  | 38d | 2025-05-08 | 2025-06-21 | A5380 SS | 68d | 7d | Capataz [60.25 h]; Oficial [299.43 h]; Peon [615.04 h]; Operador equipo Pesado [898.29 h]; Operador equipo Liviano [62.94 h]; Cisterna 5000 gln [62.94 h]; Excavadora Cat 336 [598.86 h]; Rodillo liso vibratorio 10 - 12 ton [299.43 h]; Petroleo [9157.32 gln] | 1 | 1 | 240 | 8991.87 | m3 | 1 | 8991.87 | 37.466125 | Relleno |
|  | 3 | **GEOTEXTIL** |  |  | 2025-04-22 | 2025-07-18 |  |  |  |  |  |  |  |  |  |  |  |  |  |
| A5440 |  | Instalacion de Geotextil 400gr/m2 |  | 74d | 2025-04-22 | 2025-07-18 | A5470 SS | 61d | 0d | Capataz [54.64 h]; Oficial [540.34 h]; Peon [809.49 h]; Operador equipo Liviano [66.78 h]; Camion grua 20 ton [66.78 h]; Petroleo [267.13 gln]; Geotextil de 400 gr/m2 [23272.9 m2] | 1 | 1 | 600 | 20237.34 | m2 | 1 | 20237.34 | 33.7289 | Geotextil |
| A5450 |  | Zanja de Anclaje |  | 16d | 2025-07-01 | 2025-07-18 | A5440 FF, A5350, A5360, A5420 | 61d | 0d | Capataz [6.69 h]; Oficial [33.44 h]; Peon [100.55 h]; Operador equipo Pesado [33.44 h]; Operador equipo Liviano [0.94 h]; Cisterna 5000 gln [0.94 h]; Retroexcavadora sobre llantas 58 hp [33.44 h]; Petroleo [119.13 gln] | 1 | 1 | 32 | 133.75 | m3 | 1 | 133.75 | 4.1796875 | Geotextil |
|  | 4 | **COLOCACION DE ROCA** |  |  | 2025-04-22 | 2025-08-02 |  |  |  |  |  |  |  |  |  |  |  |  |  |
| A10740 |  | Suministro de Roca |  | 84d | 2025-04-22 | 2025-08-02 | A5470 SS | 58d | 0d |  | 0 |  |  |  |  |  |  |  | Roca |
| A5470 |  | Colocacion de Roca en Uña |  | 51d | 2025-04-22 | 2025-06-21 | A5340 SS+2d | 58d | 0d | Capataz [204.36 h]; Oficial [408.72 h]; Peon [408.72 h]; Operador equipo Pesado [450.16 h]; Excavadora Cat 336 [408.72 h]; Tractor D6 [41.44 h]; Petroleo [3764.19 gln] | 1 | 1 | 280 | 14290.79 | m3 | 1 | 14290.79 | 51.0385357142857 | Roca |
| A5480 |  | Colocacion de Roca en Talud |  | 26d | 2025-06-23 | 2025-07-22 | A5470, A5580, A5600 | 58d | 0d | Capataz [102.76 h]; Oficial [206.02 h]; Peon [206.02 h]; Operador equipo Pesado [432.29 h]; Excavadora Cat 336 [411.54 h]; Tractor D6 [20.75 h]; Petroleo [3643.55 gln] | 1 | 1 | 192 | 4940.41 | m3 | 1 | 4940.41 | 25.7313020833333 | Roca |
| A5540 |  | Colocación de Roca en Corona |  | 7d | 2025-07-24 | 2025-08-02 | A5480, A5680 | 58d | 0d | Capataz [30.07 h]; Oficial [59.95 h]; Peon [59.95 h]; Operador equipo Pesado [65.89 h]; Excavadora Cat 336 [59.95 h]; Tractor D6 [5.94 h]; Petroleo [662.54 gln] | 1 | 1 | 280 | 1800.39 | m3 | 1 | 1800.39 | 6.42996428571429 | Roca |
|  | 5 | **TRANSPORTES** |  |  | 2025-04-15 | 2025-08-02 |  |  |  |  |  |  |  |  |  |  |  |  |  |
| A5570 |  | Transporte de Material Organico (a DMO) D<=1km |  | 15d | 2025-04-15 | 2025-05-05 | A5300 SS | 98d | 0d | Peon - Vigia [27.69 h]; Operador equipo Liviano [137.47 h]; Volquete 15 m3 [137.47 h]; Petroleo [384.73 gln] | 1 | 1 |  | 4945.13 | m3k | 1 | 4945.13 |  | Transportes |
| A5580 |  | Transporte de Material Organico (a DMO) D>1km |  | 15d | 2025-04-15 | 2025-05-05 | A5570 SS | 98d | 40d | Operador equipo Liviano [784.26 h]; Volquete 15 m3 [784.26 h]; Petroleo [2195.93 gln] | 1 | 1 |  | 71296.38 | m3k | 1 | 71296.38 |  | Transportes |
| A5590 |  | Transporte de Material Excedente D<=1km |  | 26d | 2025-04-19 | 2025-05-20 | A5320 SS | 85d | 0d | Peon - Vigia [182.49 h]; Operador equipo Liviano [908.87 h]; Volquete 22 m3 [390.03 h]; Volquete 15 m3 [518.85 h]; Petroleo [3045.09 gln] | 1 | 1 |  | 35782.45 | m3k | 1 | 35782.45 |  | Transportes |
| A5600 |  | Transporte de Material Excedente D>1km |  | 26d | 2025-04-19 | 2025-05-20 | A5590 SS | 85d | 27d | Operador equipo Liviano [5205.3 h]; Volquete 22 m3 [2216.12 h]; Volquete 15 m3 [2989.18 h]; Petroleo [17419.7 gln] | 1 | 1 |  | 515376.54 | m3k | 1 | 515376.54 |  | Transportes |
| A5630 |  | Transporte de Roca D<=1km |  | 84d | 2025-04-22 | 2025-08-02 | A10740 SS | 58d | 0d | Peon [262.89 h]; Peon - Vigia [121.98 h]; Operador equipo Pesado [262.89 h]; Operador equipo Liviano [609.92 h]; Volquete 22 m3 [609.92 h]; Excavadora Cat 336 [262.89 h]; Petroleo [4736.31 gln]; Peaje local [956.94] | 1 | 1 |  | 21031.59 | m3k | 1 | 21031.59 |  | Transportes |
| A5640 |  | Transporte de Roca D>1km |  | 84d | 2025-04-22 | 2025-08-02 | A5630 SS | 58d | 0d | Operador equipo Liviano [1377.91 h]; Volquete 22 m3 [1377.91 h]; Petroleo [5644.11 gln] | 1 | 1 |  | 132490.91 | m3k | 1 | 132490.91 |  | Transportes |
| A5610 |  | Transporte de Material de Prestamo (Afirmado) D<=1km |  | 38d | 2025-05-08 | 2025-06-21 | A5380 SS | 68d | 0d | Peon - Vigia [20.15 h]; Operador equipo Liviano [100.26 h]; Volquete 22 m3 [100.26 h]; Petroleo [411.1 gln] | 1 | 1 |  | 4797 | m3k | 1 | 4797 |  | Transportes |
| A5620 |  | Transporte de Material de Prestamo (Afirmado) D>1km |  | 38d | 2025-05-08 | 2025-06-21 | A5610 SS | 68d | 7d | Operador equipo Liviano [402.22 h]; Volquete 22 m3 [402.22 h]; Petroleo [1647.63 gln] | 1 | 1 |  | 48459.75 | m3k | 1 | 48459.75 |  | Transportes |
| A5650 |  | Transporte de Material de Prestamo Cantera de Rio (Cuerpo de Terraplen) D<=1km |  | 38d | 2025-05-08 | 2025-06-21 | A5380 SS | 68d | 0d | Peon - Vigia [39.73 h]; Operador equipo Liviano [197.72 h]; Volquete 22 m3 [197.72 h]; Petroleo [810.74 gln] | 1 | 1 |  | 9460.25 | m3k | 1 | 9460.25 |  | Transportes |
| A5660 |  | Transporte de Material de Prestamo Cantera de Rio (Cuerpo de Terraplen) D>1km |  | 38d | 2025-05-08 | 2025-06-21 | A5650 SS | 68d | 7d | Operador equipo Liviano [475.19 h]; Volquete 22 m3 [475.19 h]; Petroleo [1946.58 gln] | 1 | 1 |  | 57252.29 | m3k | 1 | 57252.29 |  | Transportes |
| A5670 |  | Transporte de Material Seleccionado para Zanja D<=1km |  | 16d | 2025-07-01 | 2025-07-18 | A5450 SS, A7740, A5660, A5620 | 61d | 0d | Peon - Vigia [0.75 h]; Operador equipo Liviano [3.72 h]; Volquete 15 m3 [3.72 h]; Petroleo [10.41 gln] | 1 | 1 |  | 133.75 | m3k | 1 | 133.75 |  | Transportes |
| A5680 |  | Transporte de Material Seleccionado para Zanja D>1km |  | 16d | 2025-07-01 | 2025-07-18 | A5670 SS | 61d | 3d | Operador equipo Liviano [8.93 h]; Volquete 15 m3 [8.93 h]; Petroleo [25 gln] | 1 | 1 |  | 811.53 | m3k | 1 | 811.53 |  | Transportes |

| ID | WBS | Activity | Duration | Start | Finish | Predecessors | Total float | Free float | Resources | Metrado | Unidad | RCuad | AGrupo |
| --- | --- | --- | --- | --- | --- | --- | --- | --- | --- | --- | --- | --- | --- |
|  | 6 | **INTERFERENCIAS** |  | 2025-04-23 | 2025-06-03 |  |  |  |  |  |  |  |  |
|  | 1 | **DI-PR-51-I-CAN01** |  | 2025-04-23 | 2025-04-28 |  |  |  |  |  |  |  |  |
| A5690 |  | Trazo y replanteo de interferencia | 5d | 2025-04-23 | 2025-04-28 | A10720 SS+5d | 83d | 0d | Capataz [1.45 h]; Peon [28.95 h]; Topografo [14.47 h]; GPS [14.47 h]; MADERA TORNILLO [14.47]; PINTURA ESMALTE [1.45] | 723.66 | m2 | 0 | Interferencias |
| A5710 |  | Desvío provisional en tierras | 5d | 2025-04-23 | 2025-04-28 | A5690 SS | 83d | 0d | Capataz [4.86 h]; Peon [24.26 h]; Operador equipo Pesado [24.26 h]; Excavadora Cat 336 [24.26 h]; Petroleo [206.22 gln] | 182 | m | 0 | Interferencias |
| A5720 |  | Limpieza de terreno manual | 5d | 2025-04-23 | 2025-04-28 | A5710 SS | 83d | 0d | Capataz [0.29 h]; Oficial [5.79 h]; Peon [11.58 h]; Operador equipo Pesado [2.17 h]; Excavadora Cat 336 [0.72 h]; Tractor D6 [1.45 h]; Petroleo [16.28 gln] | 723.66 | m2 | 0 | Interferencias |
| A5740 |  | Excavacion no clasificada de zanja | 5d | 2025-04-23 | 2025-04-28 | A5720 SS | 83d | 0d | Capataz [1.35 h]; Peon [13.52 h]; Operador equipo Pesado [13.52 h]; Excavadora Cat 336 [13.52 h]; Petroleo [114.92 gln] | 270.39 | m3 | 0 | Interferencias |
| A5750 |  | Relleno estructural | 5d | 2025-04-23 | 2025-04-28 | A5740 SS | 83d | 0d | Capataz [3.54 h]; Operario [12.76 h]; Oficial [12.76 h]; Peon [30.53 h]; Peon - Vigia [0.39 h]; Operador equipo Pesado [13.49 h]; Operador equipo Liviano [16.58 h]; Cisterna 5000 gln [1.88 h]; Volquete 15 m3 [1.93 h]; Cargador Frontal 966 [2.96 h]; Chancadora Primaria [1.44 h]; Excavadora Cat 336 [2.3 h]; Retroexcavadora sobre llantas 58 hp [6.38 h]; Rodillo liso vibratorio 0.80 - 1.10 ton [12.76 h]; Tractor D6 [0.43 h]; Petroleo [95.12 gln] | 89.31 | m3 | 0 | Interferencias |
| A5850 |  | Emboquillado de piedra e=0.20m | 5d | 2025-04-23 | 2025-04-28 | A5750 SS | 83d | 0d | Capataz [23.71 h]; Operario [68.48 h]; Oficial [136.93 h]; Peon [223.91 h]; Peon - Vigia [0.22 h]; Operador equipo Pesado [0.32 h]; Operador equipo Liviano [48.3 h]; Cisterna 5000 gln [0.61 h]; Volquete 15 m3 [2.14 h]; Excavadora Cat 336 [0.32 h]; Retroexcavadora sobre llantas 94 hp [45.55 h]; Zaranda estatica [4.59 h]; Petroleo [124.99 gln]; ARENA GRUESA [19.78]; CEMENTO PORTLAND TIPO I (42.5 kg) [192.63] | 245.7 | m2 | 0 | Interferencias |
| A5920 |  | Sello en juntas | 5d | 2025-04-23 | 2025-04-28 | A5850 SS | 83d | 0d | Capataz [6.82 h]; Operario [27.3 h]; Peon [6.82 h]; TECNOPOR DE 1/2"X4X8' [4.67]; SELLADOR ELASTICO POLIURETANO SIKAFLEX 1A [23.42] | 81.9 | m | 0 | Interferencias |
|  | 2 | **DI-PR-51-I-CAN02** |  | 2025-04-29 | 2025-05-05 |  |  |  |  |  |  |  |  |
| A5990 |  | Trazo y replanteo de interferencia | 5d | 2025-04-29 | 2025-05-05 | A5920 | 83d | 0d | Capataz [0.32 h]; Peon [6.36 h]; Topografo [3.18 h]; GPS [3.18 h]; MADERA TORNILLO [3.18]; PINTURA ESMALTE [0.32] | 159.09 | m2 | 0 | Interferencias |
| A6010 |  | Desvío provisional en tierras | 5d | 2025-04-29 | 2025-05-05 | A5990 SS | 83d | 0d | Capataz [1.83 h]; Peon [9.13 h]; Operador equipo Pesado [9.13 h]; Excavadora Cat 336 [9.13 h]; Petroleo [77.62 gln] | 68.5 | m | 0 | Interferencias |
| A6020 |  | Limpieza de terreno manual | 5d | 2025-04-29 | 2025-05-05 | A6010 SS | 83d | 0d | Capataz [0.06 h]; Oficial [1.27 h]; Peon [2.55 h]; Operador equipo Pesado [0.48 h]; Excavadora Cat 336 [0.16 h]; Tractor D6 [0.32 h]; Petroleo [3.58 gln] | 159.09 | m2 | 0 | Interferencias |
| A6040 |  | Excavacion no clasificada de zanja | 5d | 2025-04-29 | 2025-05-05 | A6020 SS | 83d | 0d | Capataz [0.24 h]; Peon [2.35 h]; Operador equipo Pesado [2.35 h]; Excavadora Cat 336 [2.35 h]; Petroleo [19.98 gln] | 47.02 | m3 | 0 | Interferencias |
| A6050 |  | Relleno estructural | 5d | 2025-04-29 | 2025-05-05 | A6040 SS | 83d | 0d | Capataz [0.37 h]; Operario [1.34 h]; Oficial [1.34 h]; Peon [3.21 h]; Peon - Vigia [0.04 h]; Operador equipo Pesado [1.42 h]; Operador equipo Liviano [1.74 h]; Cisterna 5000 gln [0.2 h]; Volquete 15 m3 [0.2 h]; Cargador Frontal 966 [0.31 h]; Chancadora Primaria [0.15 h]; Excavadora Cat 336 [0.24 h]; Retroexcavadora sobre llantas 58 hp [0.67 h]; Rodillo liso vibratorio 0.80 - 1.10 ton [1.34 h]; Tractor D6 [0.05 h]; Petroleo [10.01 gln] | 9.4 | m3 | 0 | Interferencias |
| A6150 |  | Emboquillado de piedra e=0.20m | 5d | 2025-04-29 | 2025-05-05 | A6050 SS | 83d | 0d | Capataz [6.27 h]; Operario [18.1 h]; Oficial [36.19 h]; Peon [59.17 h]; Peon - Vigia [0.06 h]; Operador equipo Pesado [0.08 h]; Operador equipo Liviano [12.77 h]; Cisterna 5000 gln [0.16 h]; Volquete 15 m3 [0.56 h]; Excavadora Cat 336 [0.08 h]; Retroexcavadora sobre llantas 94 hp [12.04 h]; Zaranda estatica [1.21 h]; Petroleo [33.03 gln]; ARENA GRUESA [5.23]; CEMENTO PORTLAND TIPO I (42.5 kg) [50.91] | 64.93 | m2 | 0 | Interferencias |
| A6220 |  | Sello en juntas | 5d | 2025-04-29 | 2025-05-05 | A6150 SS | 83d | 0d | Capataz [1.77 h]; Operario [7.07 h]; Peon [1.77 h]; TECNOPOR DE 1/2"X4X8' [1.21]; SELLADOR ELASTICO POLIURETANO SIKAFLEX 1A [6.06] | 21.2 | m | 0 | Interferencias |
|  | 3 | **DI-PR-51-I-CAN03** |  | 2025-05-06 | 2025-05-10 |  |  |  |  |  |  |  |  |
| A6290 |  | Trazo y replanteo de interferencia | 5d | 2025-05-06 | 2025-05-10 | A6220 | 83d | 0d | Capataz [0.46 h]; Peon [9.28 h]; Topografo [4.64 h]; GPS [4.64 h]; MADERA TORNILLO [4.64]; PINTURA ESMALTE [0.46] | 232.03 | m2 | 0 | Interferencias |
| A6310 |  | Desvío provisional en tierras | 5d | 2025-05-06 | 2025-05-10 | A6290 SS | 83d | 0d | Capataz [1.74 h]; Peon [8.66 h]; Operador equipo Pesado [8.66 h]; Excavadora Cat 336 [8.66 h]; Petroleo [73.65 gln] | 65 | m | 0 | Interferencias |
| A6320 |  | Limpieza de terreno manual | 5d | 2025-05-06 | 2025-05-10 | A6310 SS | 83d | 0d | Capataz [0.09 h]; Oficial [1.86 h]; Peon [3.71 h]; Operador equipo Pesado [0.7 h]; Excavadora Cat 336 [0.23 h]; Tractor D6 [0.46 h]; Petroleo [5.22 gln] | 232.03 | m2 | 0 | Interferencias |
| A6340 |  | Excavacion no clasificada de zanja | 5d | 2025-05-06 | 2025-05-10 | A6320 SS | 83d | 0d | Capataz [0.19 h]; Peon [1.86 h]; Operador equipo Pesado [1.86 h]; Excavadora Cat 336 [1.86 h]; Petroleo [15.83 gln] | 37.25 | m3 | 0 | Interferencias |
| A6350 |  | Relleno estructural | 5d | 2025-05-06 | 2025-05-10 | A6340 SS | 83d | 0d | Capataz [1.67 h]; Operario [6.04 h]; Oficial [6.04 h]; Peon [14.44 h]; Peon - Vigia [0.19 h]; Operador equipo Pesado [6.38 h]; Operador equipo Liviano [7.84 h]; Cisterna 5000 gln [0.89 h]; Volquete 15 m3 [0.91 h]; Cargador Frontal 966 [1.4 h]; Chancadora Primaria [0.68 h]; Excavadora Cat 336 [1.09 h]; Retroexcavadora sobre llantas 58 hp [3.02 h]; Rodillo liso vibratorio 0.80 - 1.10 ton [6.04 h]; Tractor D6 [0.2 h]; Petroleo [45 gln] | 42.25 | m3 | 0 | Interferencias |
| A6450 |  | Emboquillado de piedra e=0.20m | 5d | 2025-05-06 | 2025-05-10 | A6350 SS | 83d | 0d | Capataz [10.23 h]; Operario [29.54 h]; Oficial [59.07 h]; Peon [96.6 h]; Peon - Vigia [0.1 h]; Operador equipo Pesado [0.14 h]; Operador equipo Liviano [20.84 h]; Cisterna 5000 gln [0.27 h]; Volquete 15 m3 [0.92 h]; Excavadora Cat 336 [0.14 h]; Retroexcavadora sobre llantas 94 hp [19.65 h]; Zaranda estatica [1.98 h]; Petroleo [53.92 gln]; ARENA GRUESA [8.53]; CEMENTO PORTLAND TIPO I (42.5 kg) [83.1] | 106 | m2 | 0 | Interferencias |
| A6520 |  | Sello en juntas | 5d | 2025-05-06 | 2025-05-10 | A6450 SS | 83d | 0d | Capataz [2.87 h]; Operario [11.48 h]; Peon [2.87 h]; TECNOPOR DE 1/2"X4X8' [1.96]; SELLADOR ELASTICO POLIURETANO SIKAFLEX 1A [9.85] | 34.45 | m | 0 | Interferencias |

| ID | WBS | Activity | Duration | Start | Finish | Predecessors | Total float | Free float | Resources | Metrado | Unidad | RCuad | AGrupo |
| --- | --- | --- | --- | --- | --- | --- | --- | --- | --- | --- | --- | --- | --- |
|  | 4 | **DI-PR-51-I-CAN04** |  | 2025-05-12 | 2025-05-16 |  |  |  |  |  |  |  |  |
| A6590 |  | Trazo y replanteo de interferencia | 5d | 2025-05-12 | 2025-05-16 | A6520 | 83d | 0d | Capataz [0.36 h]; Peon [7.24 h]; Topografo [3.62 h]; GPS [3.62 h]; MADERA TORNILLO [3.62]; PINTURA ESMALTE [0.36] | 180.91 | m2 | 0 | Interferencias |
| A6610 |  | Desvío provisional en tierras | 5d | 2025-05-12 | 2025-05-16 | A6590 SS | 83d | 0d | Capataz [2.18 h]; Peon [10.86 h]; Operador equipo Pesado [10.86 h]; Excavadora Cat 336 [10.86 h]; Petroleo [92.35 gln] | 81.5 | m | 0 | Interferencias |
| A6620 |  | Limpieza de terreno manual | 5d | 2025-05-12 | 2025-05-16 | A6610 SS | 83d | 0d | Capataz [0.07 h]; Oficial [1.45 h]; Peon [2.89 h]; Operador equipo Pesado [0.54 h]; Excavadora Cat 336 [0.18 h]; Tractor D6 [0.36 h]; Petroleo [4.07 gln] | 180.91 | m2 | 0 | Interferencias |
| A6640 |  | Excavacion no clasificada de zanja | 5d | 2025-05-12 | 2025-05-16 | A6620 SS | 83d | 0d | Capataz [0.26 h]; Peon [2.64 h]; Operador equipo Pesado [2.64 h]; Excavadora Cat 336 [2.64 h]; Petroleo [22.43 gln] | 52.78 | m3 | 0 | Interferencias |
| A6650 |  | Relleno estructural | 5d | 2025-05-12 | 2025-05-16 | A6640 SS | 83d | 0d | Capataz [0.43 h]; Operario [1.56 h]; Oficial [1.56 h]; Peon [3.73 h]; Peon - Vigia [0.05 h]; Operador equipo Pesado [1.65 h]; Operador equipo Liviano [2.02 h]; Cisterna 5000 gln [0.23 h]; Volquete 15 m3 [0.24 h]; Cargador Frontal 966 [0.36 h]; Chancadora Primaria [0.18 h]; Excavadora Cat 336 [0.28 h]; Retroexcavadora sobre llantas 58 hp [0.78 h]; Rodillo liso vibratorio 0.80 - 1.10 ton [1.56 h]; Tractor D6 [0.05 h]; Petroleo [11.62 gln] | 10.91 | m3 | 0 | Interferencias |
| A6750 |  | Emboquillado de piedra e=0.20m | 5d | 2025-05-12 | 2025-05-16 | A6650 SS | 83d | 0d | Capataz [0.51 h]; Operario [1.48 h]; Oficial [2.95 h]; Peon [4.83 h]; Peon - Vigia [0 h]; Operador equipo Pesado [0.01 h]; Operador equipo Liviano [1.04 h]; Cisterna 5000 gln [0.01 h]; Volquete 15 m3 [0.05 h]; Excavadora Cat 336 [0.01 h]; Retroexcavadora sobre llantas 94 hp [0.98 h]; Zaranda estatica [0.1 h]; Petroleo [2.7 gln]; ARENA GRUESA [0.43]; CEMENTO PORTLAND TIPO I (42.5 kg) [4.16] | 5.3 | m2 | 0 | Interferencias |
| A6820 |  | Sello en juntas | 5d | 2025-05-12 | 2025-05-16 | A6750 SS | 83d | 0d | Capataz [0.22 h]; Operario [0.88 h]; Peon [0.22 h]; TECNOPOR DE 1/2"X4X8' [0.15]; SELLADOR ELASTICO POLIURETANO SIKAFLEX 1A [0.76] | 2.65 | m | 0 | Interferencias |
|  | 5 | **DI-PR-51-I-INT01** |  | 2025-05-17 | 2025-05-22 |  |  |  |  |  |  |  |  |
| A6890 |  | Trazo y replanteo de interferencia | 5d | 2025-05-17 | 2025-05-22 | A6820 | 83d | 0d | Capataz [0.09 h]; Peon [1.75 h]; Topografo [0.88 h]; GPS [0.88 h]; MADERA TORNILLO [0.88]; PINTURA ESMALTE [0.09] | 43.8 | m2 | 0 | Interferencias |
| A6900 |  | Desvío provisional con tubería | 5d | 2025-05-17 | 2025-05-22 | A6890 SS | 83d | 0d | Capataz [3.8 h]; Operario [6.54 h]; Oficial [6.54 h]; Peon [41.88 h]; Operador equipo Pesado [2.62 h]; Operador equipo Liviano [1.64 h]; Camion grua 20 ton [1.64 h]; Excavadora Cat 336 [2.62 h]; Petroleo [28.78 gln]; TUBERIA CORRUGADA HDPE D=630 mm [20.61] | 19.63 | m | 0 | Interferencias |
| A6920 |  | Limpieza de terreno manual | 5d | 2025-05-17 | 2025-05-22 | A6900 SS | 83d | 0d | Capataz [0.02 h]; Oficial [0.35 h]; Peon [0.7 h]; Operador equipo Pesado [0.13 h]; Excavadora Cat 336 [0.04 h]; Tractor D6 [0.09 h]; Petroleo [0.99 gln] | 43.8 | m2 | 0 | Interferencias |
| A6930 |  | Excavaciones no clasificada para estructuras | 5d | 2025-05-17 | 2025-05-22 | A6920 SS | 83d | 0d | Capataz [0.34 h]; Peon [1.7 h]; Operador equipo Pesado [1.7 h]; Excavadora Cat 336 [1.7 h]; Petroleo [14.41 gln] | 52.98 | m3 | 0 | Interferencias |
| A6940 |  | Excavacion no clasificada de zanja | 5d | 2025-05-17 | 2025-05-22 | A6930 SS | 83d | 0d | Capataz [0.05 h]; Peon [0.51 h]; Operador equipo Pesado [0.51 h]; Excavadora Cat 336 [0.51 h]; Petroleo [4.3 gln] | 10.11 | m3 | 0 | Interferencias |
| A6950 |  | Relleno estructural | 5d | 2025-05-17 | 2025-05-22 | A6940 SS | 83d | 0d | Capataz [0.93 h]; Operario [3.37 h]; Oficial [3.37 h]; Peon [8.07 h]; Peon - Vigia [0.1 h]; Operador equipo Pesado [3.57 h]; Operador equipo Liviano [4.38 h]; Cisterna 5000 gln [0.5 h]; Volquete 15 m3 [0.51 h]; Cargador Frontal 966 [0.78 h]; Chancadora Primaria [0.38 h]; Excavadora Cat 336 [0.61 h]; Retroexcavadora sobre llantas 58 hp [1.69 h]; Rodillo liso vibratorio 0.80 - 1.10 ton [3.37 h]; Tractor D6 [0.11 h]; Petroleo [25.13 gln] | 23.6 | m3 | 0 | Interferencias |
| A6980 |  | Concreto de Nivelacion (f'c=100 kg/cm2) | 5d | 2025-05-17 | 2025-05-22 | A6950 SS | 83d | 0d | Capataz [0.95 h]; Operario [1.06 h]; Oficial [1.68 h]; Peon [8.85 h]; Operador equipo Liviano [1.13 h]; Cisterna 5000 gln [0.07 h]; Carmix 4.0 m3 [1.06 h]; Petroleo [5.56 gln]; PIEDRA CHANCADA [1.72]; ARENA GRUESA [1.46]; CEMENTO PORTLAND TIPO I (42.5 kg) [15.88] | 2.52 | m3 | 0 | Interferencias |
| A7000 |  | Concreto Clase C (f'c=280 kg/cm2) Premezclado - Cimientos reforzados | 5d | 2025-05-17 | 2025-05-22 | A6980 SS | 83d | 0d | Capataz [2.01 h]; Operario [5.8 h]; Oficial [8.05 h]; Peon [18.68 h]; Operador equipo Liviano [3.54 h]; Carmix 4.0 m3 [3.54 h]; Petroleo [18.85 gln]; PIEDRA CHANCADA [5.76]; ARENA GRUESA [4.87]; CEMENTO PORTLAND TIPO I (42.5 kg) [93.05]; PLASTIMENT TM-40 - PLASTIFICANTE [19.05]; ADITIVO CURADOR DE CONCRETO [1.27] | 8.44 | m3 | 0 | Interferencias |
| A7010 |  | Concreto Clase C (f'c=280 kg/cm2) Premezclado - Muros de contencion | 5d | 2025-05-17 | 2025-05-22 | A7000 SS | 83d | 0d | Capataz [1.79 h]; Operario [5.16 h]; Oficial [7.16 h]; Peon [18.62 h]; Operador equipo Liviano [3.15 h]; Carmix 4.0 m3 [3.15 h]; Petroleo [16.77 gln]; PIEDRA CHANCADA [5.13]; ARENA GRUESA [4.34]; CEMENTO PORTLAND TIPO I (42.5 kg) [82.8]; PLASTIMENT TM-40 - PLASTIFICANTE [16.95]; ADITIVO CURADOR DE CONCRETO [1.13] | 7.51 | m3 | 0 | Interferencias |
| A7020 |  | Encofrado y Desencofrado Caravista | 5d | 2025-05-17 | 2025-05-22 | A7010 SS | 83d | 0d | Capataz [5.44 h]; Operario [27.19 h]; Oficial [27.19 h]; Peon [54.38 h]; ALAMBRE NEGRO #8 [10.88]; CLAVOS PARA MADERA CON CABEZA DE 3" [10.88]; LACA DESMOLDEADORA [1.63]; MADERA TORNILLO INCLUYE CORTE PARA ENCOFRADO [163.14]; TRIPLAY DE 19 mm PARA ENCOFRADO [4.73] | 54.38 | m2 | 0 | Interferencias |
| A7030 |  | Encofrado y Desencofrado Cara Oculta | 5d | 2025-05-17 | 2025-05-22 | A7020 SS | 83d | 0d | Capataz [2.66 h]; Operario [26.57 h]; Oficial [26.57 h]; ALAMBRE NEGRO #8 [11.96]; CLAVOS PARA MADERA CON CABEZA DE 3" [8.37]; MADERA TORNILLO INCLUYE CORTE PARA ENCOFRADO [199.3] | 39.86 | m2 | 0 | Interferencias |
| A7040 |  | Acero de refuerzo f'y=4200kg/cm2 | 5d | 2025-05-17 | 2025-05-22 | A7030 SS | 83d | 0d | Capataz [2.4 h]; Operario [24.19 h]; Oficial [24.19 h]; Peon [12.1 h]; ALAMBRE NEGRO #16 [49.98]; ACERO CORRUGADO fy = 4200 kg/cm2 GRADO 60 [1049.65] | 999.67 | kg | 0 | Interferencias |
| A7070 |  | Emboquillado de piedra e=0.50m | 5d | 2025-05-17 | 2025-05-22 | A7040 SS | 83d | 0d |  | 12.84 | m2 | 0 | Interferencias |
| A7120 |  | Sello en juntas | 5d | 2025-05-17 | 2025-05-22 | A7070 SS | 83d | 0d | Capataz [0.36 h]; Operario [1.43 h]; Peon [0.36 h]; TECNOPOR DE 1/2"X4X8' [0.24]; SELLADOR ELASTICO POLIURETANO SIKAFLEX 1A [1.22] | 4.28 | m | 0 | Interferencias |
| A7140 |  | Pintura bituminosa | 5d | 2025-05-17 | 2025-05-22 | A7120 SS | 83d | 0d | Capataz [0.8 h]; Operario [7.97 h]; Peon [15.94 h]; PINTURA ASFALTICA [15.94]; IMPRIMANTE ASFALTICO [6.98] | 39.86 | m2 | 0 | Interferencias |

| ID | WBS | Activity | Duration | Start | Finish | Predecessors | Total float | Free float | Resources | Metrado | Unidad | RCuad | AGrupo |
| --- | --- | --- | --- | --- | --- | --- | --- | --- | --- | --- | --- | --- | --- |
|  | 6 | **DI-PR-51-I-INT02** |  | 2025-05-23 | 2025-05-28 |  |  |  |  |  |  |  |  |
| A7190 |  | Trazo y replanteo de interferencia | 5d | 2025-05-23 | 2025-05-28 | A7140 | 83d | 0d | Capataz [0.08 h]; Peon [1.54 h]; Topografo [0.77 h]; GPS [0.77 h]; MADERA TORNILLO [0.77]; PINTURA ESMALTE [0.08] | 38.56 | m2 | 0 | Interferencias |
| A7200 |  | Desvío provisional con tubería | 5d | 2025-05-23 | 2025-05-28 | A7190 SS | 83d | 0d | Capataz [6.22 h]; Operario [10.73 h]; Oficial [10.73 h]; Peon [68.65 h]; Operador equipo Pesado [4.29 h]; Operador equipo Liviano [2.68 h]; Camion grua 20 ton [2.68 h]; Excavadora Cat 336 [4.29 h]; Petroleo [47.19 gln]; TUBERIA CORRUGADA HDPE D=630 mm [33.79] | 32.18 | m | 0 | Interferencias |
| A7220 |  | Limpieza de terreno manual | 5d | 2025-05-23 | 2025-05-28 | A7200 SS | 83d | 0d | Capataz [0.02 h]; Oficial [0.31 h]; Peon [0.62 h]; Operador equipo Pesado [0.12 h]; Excavadora Cat 336 [0.04 h]; Tractor D6 [0.08 h]; Petroleo [0.87 gln] | 38.56 | m2 | 0 | Interferencias |
| A7230 |  | Excavaciones no clasificada para estructuras | 5d | 2025-05-23 | 2025-05-28 | A7220 SS | 83d | 0d | Capataz [0.32 h]; Peon [1.6 h]; Operador equipo Pesado [1.6 h]; Excavadora Cat 336 [1.6 h]; Petroleo [13.6 gln] | 49.99 | m3 | 0 | Interferencias |
| A7240 |  | Excavacion no clasificada de zanja | 5d | 2025-05-23 | 2025-05-28 | A7230 SS | 83d | 0d | Capataz [0.04 h]; Peon [0.43 h]; Operador equipo Pesado [0.43 h]; Excavadora Cat 336 [0.43 h]; Petroleo [3.7 gln] | 8.7 | m3 | 0 | Interferencias |
| A7250 |  | Relleno estructural | 5d | 2025-05-23 | 2025-05-28 | A7240 SS | 83d | 0d | Capataz [1.01 h]; Operario [3.63 h]; Oficial [3.63 h]; Peon [8.68 h]; Peon - Vigia [0.11 h]; Operador equipo Pesado [3.84 h]; Operador equipo Liviano [4.71 h]; Cisterna 5000 gln [0.54 h]; Volquete 15 m3 [0.55 h]; Cargador Frontal 966 [0.84 h]; Chancadora Primaria [0.41 h]; Excavadora Cat 336 [0.65 h]; Retroexcavadora sobre llantas 58 hp [1.81 h]; Rodillo liso vibratorio 0.80 - 1.10 ton [3.63 h]; Tractor D6 [0.12 h]; Petroleo [27.04 gln] | 25.39 | m3 | 0 | Interferencias |
| A7280 |  | Concreto de Nivelacion (f'c=100 kg/cm2) | 5d | 2025-05-23 | 2025-05-28 | A7250 SS | 83d | 0d | Capataz [0.74 h]; Operario [0.82 h]; Oficial [1.31 h]; Peon [6.89 h]; Operador equipo Liviano [0.88 h]; Cisterna 5000 gln [0.05 h]; Carmix 4.0 m3 [0.82 h]; Petroleo [4.32 gln]; PIEDRA CHANCADA [1.34]; ARENA GRUESA [1.13]; CEMENTO PORTLAND TIPO I (42.5 kg) [12.35] | 1.96 | m3 | 0 | Interferencias |
| A7300 |  | Concreto Clase C (f'c=280 kg/cm2) Premezclado - Cimientos reforzados | 5d | 2025-05-23 | 2025-05-28 | A7280 SS | 83d | 0d | Capataz [1.52 h]; Operario [4.39 h]; Oficial [6.09 h]; Peon [14.14 h]; Operador equipo Liviano [2.68 h]; Carmix 4.0 m3 [2.68 h]; Petroleo [14.27 gln]; PIEDRA CHANCADA [4.36]; ARENA GRUESA [3.69]; CEMENTO PORTLAND TIPO I (42.5 kg) [70.45]; PLASTIMENT TM-40 - PLASTIFICANTE [14.43]; ADITIVO CURADOR DE CONCRETO [0.96] | 6.39 | m3 | 0 | Interferencias |
| A7310 |  | Concreto Clase C (f'c=280 kg/cm2) Premezclado - Muros de contencion | 5d | 2025-05-23 | 2025-05-28 | A7300 SS | 83d | 0d | Capataz [1.39 h]; Operario [4 h]; Oficial [5.56 h]; Peon [14.46 h]; Operador equipo Liviano [2.45 h]; Carmix 4.0 m3 [2.45 h]; Petroleo [13.02 gln]; PIEDRA CHANCADA [3.98]; ARENA GRUESA [3.37]; CEMENTO PORTLAND TIPO I (42.5 kg) [64.28]; PLASTIMENT TM-40 - PLASTIFICANTE [13.16]; ADITIVO CURADOR DE CONCRETO [0.87] | 5.83 | m3 | 0 | Interferencias |
| A7320 |  | Encofrado y Desencofrado Caravista | 5d | 2025-05-23 | 2025-05-28 | A7310 SS | 83d | 0d | Capataz [3.52 h]; Operario [17.59 h]; Oficial [17.59 h]; Peon [35.17 h]; ALAMBRE NEGRO #8 [7.03]; CLAVOS PARA MADERA CON CABEZA DE 3" [7.03]; LACA DESMOLDEADORA [1.06]; MADERA TORNILLO INCLUYE CORTE PARA ENCOFRADO [105.51]; TRIPLAY DE 19 mm PARA ENCOFRADO [3.06] | 35.17 | m2 | 0 | Interferencias |
| A7330 |  | Encofrado y Desencofrado Cara Oculta | 5d | 2025-05-23 | 2025-05-28 | A7320 SS | 83d | 0d | Capataz [2.07 h]; Operario [20.71 h]; Oficial [20.71 h]; ALAMBRE NEGRO #8 [9.32]; CLAVOS PARA MADERA CON CABEZA DE 3" [6.52]; MADERA TORNILLO INCLUYE CORTE PARA ENCOFRADO [155.3] | 31.06 | m2 | 0 | Interferencias |
| A7340 |  | Acero de refuerzo f'y=4200kg/cm2 | 5d | 2025-05-23 | 2025-05-28 | A7330 SS | 83d | 0d | Capataz [1.72 h]; Operario [17.31 h]; Oficial [17.31 h]; Peon [8.65 h]; ALAMBRE NEGRO #16 [35.76]; ACERO CORRUGADO fy = 4200 kg/cm2 GRADO 60 [750.86] | 715.1 | kg | 0 | Interferencias |
| A7360 |  | Emboquillado de piedra e=0.30m | 5d | 2025-05-23 | 2025-05-28 | A7340 SS | 83d | 0d | Capataz [1.75 h]; Operario [5.04 h]; Oficial [10.08 h]; Peon [16.48 h]; Peon - Vigia [0.02 h]; Operador equipo Pesado [0.02 h]; Operador equipo Liviano [3.55 h]; Cisterna 5000 gln [0.04 h]; Volquete 15 m3 [0.16 h]; Excavadora Cat 336 [0.02 h]; Retroexcavadora sobre llantas 94 hp [3.35 h]; Zaranda estatica [0.34 h]; Petroleo [9.2 gln]; ARENA GRUESA [1.46]; CEMENTO PORTLAND TIPO I (42.5 kg) [14.18] | 12.06 | m2 | 0 | Interferencias |
| A7420 |  | Sello en juntas | 5d | 2025-05-23 | 2025-05-28 | A7360 SS | 83d | 0d | Capataz [0.63 h]; Operario [2.53 h]; Peon [0.63 h]; TECNOPOR DE 1/2"X4X8' [0.43]; SELLADOR ELASTICO POLIURETANO SIKAFLEX 1A [2.17] | 7.6 | m | 0 | Interferencias |
| A7440 |  | Pintura bituminosa | 5d | 2025-05-23 | 2025-05-28 | A7420 SS | 83d | 0d | Capataz [0.62 h]; Operario [6.21 h]; Peon [12.42 h]; PINTURA ASFALTICA [12.42]; IMPRIMANTE ASFALTICO [5.44] | 31.06 | m2 | 0 | Interferencias |
|  | 7 | **DI-PR-51-I-INT03** |  | 2025-05-29 | 2025-06-03 |  |  |  |  |  |  |  |  |
| A7490 |  | Trazo y replanteo de interferencia | 5d | 2025-05-29 | 2025-06-03 | A7440 | 83d | 0d | Capataz [0.02 h]; Peon [0.49 h]; Topografo [0.25 h]; GPS [0.25 h]; MADERA TORNILLO [0.25]; PINTURA ESMALTE [0.02] | 12.32 | m2 | 0 | Interferencias |
| A7500 |  | Desvío provisional con tubería | 5d | 2025-05-29 | 2025-06-03 | A7490 SS | 83d | 0d | Capataz [3.64 h]; Operario [6.27 h]; Oficial [6.27 h]; Peon [40.11 h]; Operador equipo Pesado [2.51 h]; Operador equipo Liviano [1.57 h]; Camion grua 20 ton [1.57 h]; Excavadora Cat 336 [2.51 h]; Petroleo [27.57 gln]; TUBERIA CORRUGADA HDPE D=630 mm [19.74] | 18.8 | m | 0 | Interferencias |
| A7520 |  | Limpieza de terreno manual | 5d | 2025-05-29 | 2025-06-03 | A7500 SS | 83d | 0d | Capataz [0 h]; Oficial [0.1 h]; Peon [0.2 h]; Operador equipo Pesado [0.04 h]; Excavadora Cat 336 [0.01 h]; Tractor D6 [0.02 h]; Petroleo [0.28 gln] | 12.32 | m2 | 0 | Interferencias |
| A7530 |  | Excavaciones no clasificada para estructuras | 5d | 2025-05-29 | 2025-06-03 | A7520 SS | 83d | 0d | Capataz [0.09 h]; Peon [0.45 h]; Operador equipo Pesado [0.45 h]; Excavadora Cat 336 [0.45 h]; Petroleo [3.79 gln] | 13.94 | m3 | 0 | Interferencias |
| A7540 |  | Excavacion no clasificada de zanja | 5d | 2025-05-29 | 2025-06-03 | A7530 SS | 83d | 0d | Capataz [0.02 h]; Peon [0.17 h]; Operador equipo Pesado [0.17 h]; Excavadora Cat 336 [0.17 h]; Petroleo [1.45 gln] | 3.4 | m3 | 0 | Interferencias |
| A7550 |  | Relleno estructural | 5d | 2025-05-29 | 2025-06-03 | A7540 SS | 83d | 0d | Capataz [0.64 h]; Operario [2.32 h]; Oficial [2.32 h]; Peon [5.55 h]; Peon - Vigia [0.07 h]; Operador equipo Pesado [2.46 h]; Operador equipo Liviano [3.02 h]; Cisterna 5000 gln [0.34 h]; Volquete 15 m3 [0.35 h]; Cargador Frontal 966 [0.54 h]; Chancadora Primaria [0.26 h]; Excavadora Cat 336 [0.42 h]; Retroexcavadora sobre llantas 58 hp [1.16 h]; Rodillo liso vibratorio 0.80 - 1.10 ton [2.32 h]; Tractor D6 [0.08 h]; Petroleo [17.31 gln] | 16.25 | m3 | 0 | Interferencias |
| A7570 |  | Colocación de roca en uña (Alcantarillas) | 5d | 2025-05-29 | 2025-06-03 | A7550 SS | 83d | 0d | Capataz [0.02 h]; Oficial [0.04 h]; Peon [0.04 h]; Operador equipo Pesado [0.05 h]; Excavadora Cat 336 [0.04 h]; Tractor D6 [0.01 h]; Petroleo [0.41 gln] | 1 | m3 | 0 | Interferencias |
| A7580 |  | Concreto de Nivelacion (f'c=100 kg/cm2) | 5d | 2025-05-29 | 2025-06-03 | A7570 SS | 83d | 0d | Capataz [0.35 h]; Operario [0.39 h]; Oficial [0.62 h]; Peon [3.27 h]; Operador equipo Liviano [0.42 h]; Cisterna 5000 gln [0.02 h]; Carmix 4.0 m3 [0.39 h]; Petroleo [2.05 gln]; PIEDRA CHANCADA [0.63]; ARENA GRUESA [0.54]; CEMENTO PORTLAND TIPO I (42.5 kg) [5.86] | 0.93 | m3 | 0 | Interferencias |
| A7600 |  | Concreto Clase C (f'c=280 kg/cm2) Premezclado - Cimientos reforzados | 5d | 2025-05-29 | 2025-06-03 | A7580 SS | 83d | 0d | Capataz [0.77 h]; Operario [2.22 h]; Oficial [3.09 h]; Peon [7.17 h]; Operador equipo Liviano [1.36 h]; Carmix 4.0 m3 [1.36 h]; Petroleo [7.24 gln]; PIEDRA CHANCADA [2.21]; ARENA GRUESA [1.87]; CEMENTO PORTLAND TIPO I (42.5 kg) [35.72]; PLASTIMENT TM-40 - PLASTIFICANTE [7.31]; ADITIVO CURADOR DE CONCRETO [0.49] | 3.24 | m3 | 0 | Interferencias |
| A7610 |  | Concreto Clase C (f'c=280 kg/cm2) Premezclado - Muros de contencion | 5d | 2025-05-29 | 2025-06-03 | A7600 SS | 83d | 0d | Capataz [0.86 h]; Operario [2.48 h]; Oficial [3.44 h]; Peon [8.95 h]; Operador equipo Liviano [1.52 h]; Carmix 4.0 m3 [1.52 h]; Petroleo [8.06 gln]; PIEDRA CHANCADA [2.46]; ARENA GRUESA [2.08]; CEMENTO PORTLAND TIPO I (42.5 kg) [39.8]; PLASTIMENT TM-40 - PLASTIFICANTE [8.15]; ADITIVO CURADOR DE CONCRETO [0.54] | 3.61 | m3 | 0 | Interferencias |
| A7620 |  | Encofrado y Desencofrado Caravista | 5d | 2025-05-29 | 2025-06-03 | A7610 SS | 83d | 0d | Capataz [2.52 h]; Operario [12.59 h]; Oficial [12.59 h]; Peon [25.17 h]; ALAMBRE NEGRO #8 [5.03]; CLAVOS PARA MADERA CON CABEZA DE 3" [5.03]; LACA DESMOLDEADORA [0.76]; MADERA TORNILLO INCLUYE CORTE PARA ENCOFRADO [75.51]; TRIPLAY DE 19 mm PARA ENCOFRADO [2.19] | 25.17 | m2 | 0 | Interferencias |
| A7630 |  | Encofrado y Desencofrado Cara Oculta | 5d | 2025-05-29 | 2025-06-03 | A7620 SS | 83d | 0d | Capataz [1.7 h]; Operario [16.97 h]; Oficial [16.97 h]; ALAMBRE NEGRO #8 [7.64]; CLAVOS PARA MADERA CON CABEZA DE 3" [5.35]; MADERA TORNILLO INCLUYE CORTE PARA ENCOFRADO [127.3] | 25.46 | m2 | 0 | Interferencias |
| A7640 |  | Acero de refuerzo f'y=4200kg/cm2 | 5d | 2025-05-29 | 2025-06-03 | A7630 SS | 83d | 0d | Capataz [1.22 h]; Operario [12.33 h]; Oficial [12.33 h]; Peon [6.17 h]; ALAMBRE NEGRO #16 [25.48]; ACERO CORRUGADO fy = 4200 kg/cm2 GRADO 60 [535.09] | 509.61 | kg | 0 | Interferencias |
| A7650 |  | Emboquillado de piedra e=0.20m | 5d | 2025-05-29 | 2025-06-03 | A7640 SS | 83d | 0d | Capataz [0.35 h]; Operario [1 h]; Oficial [2.01 h]; Peon [3.28 h]; Peon - Vigia [0 h]; Operador equipo Pesado [0 h]; Operador equipo Liviano [0.71 h]; Cisterna 5000 gln [0.01 h]; Volquete 15 m3 [0.03 h]; Excavadora Cat 336 [0 h]; Retroexcavadora sobre llantas 94 hp [0.67 h]; Zaranda estatica [0.07 h]; Petroleo [1.83 gln]; ARENA GRUESA [0.29]; CEMENTO PORTLAND TIPO I (42.5 kg) [2.82] | 3.6 | m2 | 0 | Interferencias |
| A7720 |  | Sello en juntas | 5d | 2025-05-29 | 2025-06-03 | A7650 SS | 83d | 0d | Capataz [0.25 h]; Operario [1 h]; Peon [0.25 h]; TECNOPOR DE 1/2"X4X8' [0.17]; SELLADOR ELASTICO POLIURETANO SIKAFLEX 1A [0.86] | 3 | m | 0 | Interferencias |
| A7740 |  | Pintura bituminosa | 5d | 2025-05-29 | 2025-06-03 | A7720 SS | 83d | 22d | Capataz [0.51 h]; Operario [5.09 h]; Peon [10.18 h]; PINTURA ASFALTICA [10.18]; IMPRIMANTE ASFALTICO [4.46] | 25.46 | m2 | 0 | Interferencias |

| ID | WBS | Activity | Type | Duration | Start | Finish | Predecessors | Total float | Free float | Resources | RCuad | Cuadrilla | Rendimiento | Metrado | Unidad | Turno | DurCal | Dur. Cal. | AGrupo |
| --- | --- | --- | --- | --- | --- | --- | --- | --- | --- | --- | --- | --- | --- | --- | --- | --- | --- | --- | --- |
|  | 9 | **DI-PR-53-I** |  |  | 2025-05-02 | 2025-08-23 |  |  |  |  |  |  |  |  |  |  |  |  |  |
| A10750 |  | Inicio - DE-PR-53-I | milestone | 0d | 2025-05-02 | 2025-05-02 | A10720 SS+12d | 14d | 0d |  | 0 |  |  |  |  |  |  |  |  |
| A10760 |  | Fin - DE-PR-53-I | milestone | 0d | 2025-08-23 | 2025-08-23 | A7890 FF, A7970 FF, A7840 FF, A7850 FF, A7900 FF, A8130 FF, A8170 FF | 41d |  |  | 0 |  |  |  |  |  |  |  |  |
|  | 1 | **EXCAVACIONES** |  |  | 2025-05-06 | 2025-07-12 |  |  |  |  |  |  |  |  |  |  |  |  |  |
| A7790 |  | Desbroce |  | 15d | 2025-05-06 | 2025-05-22 | A10750 SS, A5300 | 11d | 0d | Capataz [0.1 h]; Peon [19 h]; Operador equipo Pesado [14.25 h]; Excavadora Cat 336 [4.75 h]; Tractor D6 [9.5 h]; Petroleo [106.88 gln] | 1 | 1 | 0.8 | 0.95 | ha | 1 | 0.95 | 1.1875 | Excavacion |
| A7850 |  | Conformacion de Material Excedente en DMO |  | 15d | 2025-05-06 | 2025-05-22 | A7790 SS | 116d | 75d | Capataz [2.29 h]; Peon [21.75 h]; Operador equipo Pesado [24.04 h]; Excavadora Cat 336 [2.29 h]; Tractor D6 [21.75 h]; Petroleo [171.73 gln] | 1 | 1 | 1050 | 2862.24 | m3 | 1 | 2862.24 | 2.72594285714286 | Excavacion |
| A7800 |  | Remocion de Dique Existente |  | 44d | 2025-05-21 | 2025-07-11 | A7790 SS+2d, A5320 | 0d |  | Capataz [1.03 h]; Peon [5.15 h]; Operador equipo Pesado [7.73 h]; Excavadora Cat 336 [5.15 h]; Tractor D8 [2.58 h]; Petroleo [68.26 gln] | 1 | 1 | 800 | 515.16 | m3 | 1 | 515.16 | 0.64395 | Excavacion |
| A7810 |  | Excavacion de Cimentacion |  | 44d | 2025-05-21 | 2025-07-11 | A7800 SS | 0d |  | Capataz [19.07 h]; Peon [190.72 h]; Operador equipo Pesado [127.15 h]; Operador equipo Liviano [105.96 h]; Excavadora Cat 336 [84.77 h]; Retroexcavadora sobre llantas 94 hp [105.96 h]; Tractor D8 [42.38 h]; Petroleo [1385.91 gln] | 1 | 1 | 900 | 10595.63 | m3 | 1 | 10595.63 | 11.7729222222222 | Excavacion |
| A7830 |  | Excavacion de Uña |  | 44d | 2025-05-21 | 2025-07-11 | A7810 SS | 41d | 0d | Capataz [32.62 h]; Peon [163.09 h]; Operador equipo Pesado [163.09 h]; Excavadora Cat 336 [163.09 h]; Petroleo [1842.91 gln] | 1 | 1 | 500 | 10193.09 | m3 | 1 | 10193.09 | 20.38618 | Excavacion |
| A7840 |  | Conformacion de Material Excedente en DME |  | 44d | 2025-05-21 | 2025-07-11 | A7800 SS | 74d | 33d | Capataz [21.58 h]; Peon [204.98 h]; Operador equipo Pesado [226.56 h]; Excavadora Cat 336 [21.58 h]; Tractor D6 [204.98 h]; Petroleo [1618.28 gln] | 1 | 1 | 1050 | 26971.3 | m3 | 1 | 26971.3 | 25.6869523809524 | Excavacion |
| A7860 |  | Excavacion Localizada - Sobreexcavacion |  | 44d | 2025-05-21 | 2025-07-11 | A7830 SS | 70d | 8d | Capataz [36.95 h]; Peon [183.67 h]; Operador equipo Pesado [183.67 h]; Excavadora Cat 336 [183.67 h]; Petroleo [1561.44 gln] | 1 | 1 | 240 | 5515.52 | m3 | 1 | 5515.52 | 22.9813333333333 | Excavacion |
| A7820 |  | Perfilado y Conformacion de Plataforma de Fundacion |  | 33d | 2025-06-04 | 2025-07-12 | A7810 SS+12d | 52d | 0d | Capataz [2.61 h]; Peon [32.2 h]; Operador equipo Pesado [57.43 h]; Operador equipo Liviano [12.18 h]; Cisterna 5000 gln [12.18 h]; Motoniveladora 140K [28.72 h]; Rodillo liso vibratorio 10 - 12 ton [28.72 h]; Petroleo [247.13 gln] | 1 | 1 | 2400 | 8701.71 | m2 | 1 | 8701.71 | 3.6257125 | Excavacion |
|  | 2 | **RELLENOS** |  |  | 2025-06-23 | 2025-08-11 |  |  |  |  |  |  |  |  |  |  |  |  |  |
| A7870 |  | Relleno con Material Granular (incluye extraccion de material, zarandeo y combinado) |  | 25d | 2025-06-23 | 2025-07-21 | A7820 SS+15d | 52d | 0d | Capataz [135.9 h]; Operario [34.1 h]; Oficial [99.4 h]; Peon [356.32 h]; Peon - Vigia [21.13 h]; Operador equipo Pesado [524.4 h]; Operador equipo Liviano [205.05 h]; Cisterna 5000 gln [67.23 h]; Volquete 15 m3 [103.25 h]; Cargador Frontal 966 [156.55 h]; Chancadora Primaria [77.31 h]; Excavadora Cat 336 [121.01 h]; Retroexcavadora sobre llantas 58 hp [17.29 h]; Rodillo liso vibratorio 10 - 12 ton [65.31 h]; Rodillo liso vibratorio 0.80 - 1.10 ton [34.1 h]; Tractor D6 [86.92 h]; Petroleo [3718.32 gln] | 1 | 1 | 560 | 4802.17 | m3 | 1 | 4802.17 | 8.57530357142857 | Relleno |
| A7910 |  | Relleno con Material Seleccionado (incluye extraccion de material, zarandeo y combinado) |  | 25d | 2025-06-23 | 2025-07-21 | A7870 SS | 62d | 0d | Capataz [38.22 h]; Oficial [189.94 h]; Peon [390.15 h]; Operador equipo Pesado [569.83 h]; Operador equipo Liviano [39.93 h]; Cisterna 5000 gln [39.93 h]; Excavadora Cat 336 [379.88 h]; Rodillo liso vibratorio 10 - 12 ton [189.94 h]; Petroleo [5808.92 gln] | 1 | 1 | 240 | 5703.97 | m3 | 1 | 5703.97 | 23.7665416666667 | Relleno |
| A7900 |  | Perfilado de Talud Dique |  | 25d | 2025-07-09 | 2025-08-11 | A7870 SS+14d | 52d | 11d | Capataz [6.96 h]; Peon [34.51 h]; Operador equipo Pesado [10.29 h]; Excavadora Cat 336 [10.29 h]; Petroleo [87.49 gln] | 1 | 1 | 700 | 3027.4 | m2 | 1 | 3027.4 | 4.32485714285714 | Relleno |
| A7920 |  | Grava para Drenaje |  | 3d | 2025-07-22 | 2025-07-25 | A7870, A7860, A7910 | 62d | 0d | Capataz [7.98 h]; Peon [25.88 h]; Peon - Vigia [0.81 h]; Operador equipo Pesado [10.61 h]; Operador equipo Liviano [23.86 h]; Volquete 15 m3 [4.06 h]; Cargador Frontal 966 [4.55 h]; Chancadora Primaria [3.03 h]; Excavadora Cat 336 [3.03 h]; Retroexcavadora sobre llantas 94 hp [19.8 h]; Tractor D6; Petroleo [135.42 gln] | 1 | 1 | 80 | 198.01 | m3 | 1 | 198.01 | 2.475125 | Relleno |
| A7890 |  | Relleno Afirmado |  | 1d | 2025-07-26 | 2025-07-26 | A7920 | 62d | 21d | Capataz [11.36 h]; Oficial [9.32 h]; Peon [29.32 h]; Peon - Vigia [3.13 h]; Operador equipo Pesado [53.74 h]; Operador equipo Liviano [19.81 h]; Cisterna 5000 gln [4.26 h]; Volquete 15 m3 [15.55 h]; Cargador Frontal 966 [6.6 h]; Chancadora LT200 [6.6 h]; Excavadora Cat 336 [12.38 h]; Motoniveladora 140K [9.32 h]; Rodillo liso vibratorio 10 - 12 ton [9.32 h]; Tractor D6 [2.91 h]; Zaranda Metso ST 4.8 168 HP [6.6 h]; Petroleo [378.51 gln]; CANON POR EXTRACCION CANTERA [396.25] | 1 | 1 | 324 | 377.38 | m3 | 1 | 377.38 | 1.16475308641975 | Relleno |
|  | 3 | **GEOTEXTIL** |  |  | 2025-06-06 | 2025-08-20 |  |  |  |  |  |  |  |  |  |  |  |  |  |
| A7930 |  | Instalacion de Geotextil 400gr/m2 |  | 60d | 2025-06-06 | 2025-08-20 | A7960 SS | 44d | 0d | Capataz [34.37 h]; Oficial [339.93 h]; Peon [509.26 h]; Operador equipo Liviano [42.01 h]; Camion grua 20 ton [42.01 h]; Petroleo [168.06 gln]; Geotextil de 400 gr/m2 [14641.2 m2] | 1 | 1 | 600 | 12731.45 | m2 | 1 | 12731.45 | 21.2190833333333 | Geotextil |
| A7940 |  | Zanja de Anclaje |  | 8d | 2025-08-12 | 2025-08-20 | A7930 FF | 44d | 0d | Capataz [3.8 h]; Oficial [19 h]; Peon [57.14 h]; Operador equipo Pesado [19 h]; Operador equipo Liviano [0.53 h]; Cisterna 5000 gln [0.53 h]; Retroexcavadora sobre llantas 58 hp [19 h]; Petroleo [67.69 gln] | 1 | 1 | 32 | 76 | m3 | 1 | 76 | 2.375 | Geotextil |
|  | 4 | **COLOCACION DE ROCA** |  |  | 2025-05-21 | 2025-08-23 |  |  |  |  |  |  |  |  |  |  |  |  |  |
| A7980 |  | Extraccion de Rocas Reutilizables |  | 44d | 2025-05-21 | 2025-07-11 | A7800 SS | 48d | 7d | Capataz [21.34 h]; Peon [42.64 h]; Operador equipo Pesado [42.64 h]; Excavadora Cat 336 [42.64 h]; Petroleo [362.44 gln] | 1 | 1 | 160 | 379 | m3 | 1 | 379 | 2.36875 | Roca |
| A10770 |  | Suministro de Roca |  | 63d | 2025-06-06 | 2025-08-23 | A7960 SS | 41d | 0d |  | 0 |  |  |  |  |  |  |  | Roca |
| A7960 |  | Colocacion de Roca en Uña |  | 37d | 2025-06-06 | 2025-07-19 | A7830 SS+14d | 41d | 0d | Capataz [145.76 h]; Oficial [291.52 h]; Peon [291.52 h]; Operador equipo Pesado [321.08 h]; Excavadora Cat 336 [291.52 h]; Tractor D6 [29.56 h]; Petroleo [2684.86 gln] | 1 | 1 | 280 | 10193.09 | m3 | 1 | 10193.09 | 36.4038928571429 | Roca |
| A7970 |  | Colocacion de Roca en Talud |  | 26d | 2025-07-21 | 2025-08-23 | A7960, A7980 | 41d | 0d | Capataz [103.61 h]; Oficial [207.71 h]; Peon [207.71 h]; Operador equipo Pesado [435.84 h]; Excavadora Cat 336 [414.92 h]; Tractor D6 [20.92 h]; Petroleo [3673.5 gln] | 1 | 1 | 192 | 4981.02 | m3 | 1 | 4981.02 | 25.9428125 | Roca |

| ID | WBS | Activity | Duration | Start | Finish | Predecessors | Total float | Free float | Resources | Cuadrilla | Metrado | Unidad | Turno | RCuad | DurCal | AGrupo |
| --- | --- | --- | --- | --- | --- | --- | --- | --- | --- | --- | --- | --- | --- | --- | --- | --- |
|  | 5 | **TRANSPORTES** |  | 2025-05-06 | 2025-08-23 |  |  |  |  |  |  |  |  |  |  |  |
| A8060 |  | Transporte de Material Organico (a DMO) D<=1km | 15d | 2025-05-06 | 2025-05-22 | A7790 SS | 108d | 0d | Peon - Vigia [16.03 h]; Operador equipo Liviano [79.57 h]; Volquete 15 m3 [79.57 h]; Petroleo [222.68 gln] | 1 | 2862.24 | m3k | 1 | 1 | 2862.24 | Transportes |
| A8070 |  | Transporte de Material Organico (a DMO) D>1km | 15d | 2025-05-06 | 2025-05-22 | A8060 SS | 108d | 64d | Operador equipo Liviano [451.86 h]; Volquete 15 m3 [451.86 h]; Petroleo [1265.21 gln] | 1 | 41078.4 | m3k | 1 | 1 | 41078.4 | Transportes |
| A8080 |  | Transporte de Material Excedente D<=1km | 44d | 2025-05-21 | 2025-07-11 | A7800 SS | 66d | 0d | Peon - Vigia [137.55 h]; Operador equipo Liviano [685.07 h]; Volquete 22 m3 [293.99 h]; Volquete 15 m3 [391.08 h]; Petroleo [2295.26 gln] | 1 | 26971.3 | m3k | 1 | 1 | 26971.3 | Transportes |
| A8090 |  | Transporte de Material Excedente D>1km | 44d | 2025-05-21 | 2025-07-11 | A8080 SS | 66d | 22d | Operador equipo Liviano [3908.9 h]; Volquete 22 m3 [1664.18 h]; Volquete 15 m3 [2244.71 h]; Petroleo [13081.2 gln] | 1 | 387019.36 | m3k | 1 | 1 | 387019.36 | Transportes |
| A8120 |  | Transporte de Roca D<=1km | 63d | 2025-06-06 | 2025-08-23 | A10770 SS | 41d | 0d | Peon [190.79 h]; Peon - Vigia [88.53 h]; Operador equipo Pesado [190.79 h]; Operador equipo Liviano [442.63 h]; Volquete 22 m3 [442.63 h]; Excavadora Cat 336 [190.79 h]; Petroleo [3437.23 gln]; Peaje local [694.47] | 1 | 15262.99 | m3k | 1 | 1 | 15262.99 | Transportes |
| A8130 |  | Transporte de Roca D>1km | 63d | 2025-06-06 | 2025-08-23 | A8120 SS | 41d | 0d | Operador equipo Liviano [1013.14 h]; Volquete 22 m3 [1013.14 h]; Petroleo [4149.98 gln] | 1 | 97417.31 | m3k | 1 | 1 | 97417.31 | Transportes |
| A8100 |  | Transporte de Material de Prestamo (Afirmado) D<=1km | 29d | 2025-06-23 | 2025-07-26 | A7870 SS | 54d | 0d | Peon - Vigia [25.48 h]; Operador equipo Liviano [126.82 h]; Volquete 22 m3 [126.82 h]; Petroleo [520 gln] | 1 | 6067.72 | m3k | 1 | 1 | 6067.72 | Transportes |
| A8110 |  | Transporte de Material de Prestamo (Afirmado) D>1km | 29d | 2025-06-23 | 2025-07-26 | A8100 SS | 54d | 10d | Operador equipo Liviano [510.4 h]; Volquete 22 m3 [510.4 h]; Petroleo [2090.79 gln] | 1 | 61493.89 | m3k | 1 | 1 | 61493.89 | Transportes |
| A8140 |  | Transporte de Material de Prestamo Cantera de Rio (Cuerpo de Terraplen) D<=1km | 25d | 2025-06-23 | 2025-07-21 | A7870 SS | 58d | 0d | Peon - Vigia [44.64 h]; Operador equipo Liviano [222.14 h]; Volquete 22 m3 [222.14 h]; Petroleo [910.88 gln] | 1 | 10628.68 | m3k | 1 | 1 | 10628.68 | Transportes |
| A8150 |  | Transporte de Material de Prestamo Cantera de Rio (Cuerpo de Terraplen) D>1km | 25d | 2025-06-23 | 2025-07-21 | A8140 SS | 58d | 14d | Operador equipo Liviano [530.24 h]; Volquete 22 m3 [530.24 h]; Petroleo [2172.06 gln] | 1 | 63884.18 | m3k | 1 | 1 | 63884.18 | Transportes |
| A8160 |  | Transporte de Material Seleccionado para Zanja D<=1km | 8d | 2025-08-12 | 2025-08-20 | A7940 SS, A9040, A8070, A8090, A8110, A8150 | 44d | 0d | Peon - Vigia [0.43 h]; Operador equipo Liviano [2.11 h]; Volquete 15 m3 [2.11 h]; Petroleo [5.91 gln] | 1 | 76 | m3k | 1 | 1 | 76 | Transportes |
| A8170 |  | Transporte de Material Seleccionado para Zanja D>1km | 8d | 2025-08-12 | 2025-08-20 | A8160 SS | 44d | 3d | Operador equipo Liviano [5.02 h]; Volquete 15 m3 [5.02 h]; Petroleo [14.05 gln] | 1 | 456.15 | m3k | 1 | 1 | 456.15 | Transportes |
|  | 6 | **INTERFERENCIAS** |  | 2025-05-02 | 2025-05-19 |  |  |  |  |  |  |  |  |  |  |  |
|  | 1 | **CANAL DI-PR-53-I-CAN01** |  | 2025-05-02 | 2025-05-07 |  |  |  |  |  |  |  |  |  |  |  |
| A8180 |  | Trazo y replanteo de interferencia | 5d | 2025-05-02 | 2025-05-07 | A10750 SS | 111d | 0d | Capataz [1.62 h]; Peon [32.38 h]; Topografo [16.19 h]; GPS [16.19 h]; MADERA TORNILLO [16.19]; PINTURA ESMALTE [1.62] |  | 809.4 | m2 |  | 0 |  | Interferencias |
| A8200 |  | Desvío provisional en tierras | 5d | 2025-05-02 | 2025-05-07 | A8180 SS | 111d | 0d | Capataz [7.47 h]; Peon [37.28 h]; Operador equipo Pesado [37.28 h]; Excavadora Cat 336 [37.28 h]; Petroleo [316.93 gln] |  | 279.7 | m |  | 0 |  | Interferencias |
| A8210 |  | Limpieza de terreno manual | 5d | 2025-05-02 | 2025-05-07 | A8200 SS | 111d | 0d | Capataz [0.32 h]; Oficial [6.48 h]; Peon [12.95 h]; Operador equipo Pesado [2.43 h]; Excavadora Cat 336 [0.81 h]; Tractor D6 [1.62 h]; Petroleo [18.21 gln] |  | 809.4 | m2 |  | 0 |  | Interferencias |
| A8230 |  | Excavacion no clasificada de zanja | 5d | 2025-05-02 | 2025-05-07 | A8210 SS | 111d | 0d | Capataz [1.77 h]; Peon [17.71 h]; Operador equipo Pesado [17.71 h]; Excavadora Cat 336 [17.71 h]; Petroleo [150.54 gln] |  | 354.22 | m3 |  | 0 |  | Interferencias |
| A8240 |  | Relleno estructural | 5d | 2025-05-02 | 2025-05-07 | A8230 SS | 111d | 0d | Capataz [1.73 h]; Operario [6.24 h]; Oficial [6.24 h]; Peon [14.94 h]; Peon - Vigia [0.19 h]; Operador equipo Pesado [6.6 h]; Operador equipo Liviano [8.11 h]; Cisterna 5000 gln [0.92 h]; Volquete 15 m3 [0.94 h]; Cargador Frontal 966 [1.45 h]; Chancadora Primaria [0.7 h]; Excavadora Cat 336 [1.12 h]; Retroexcavadora sobre llantas 58 hp [3.12 h]; Rodillo liso vibratorio 0.80 - 1.10 ton [6.24 h]; Tractor D6 [0.21 h]; Petroleo [46.54 gln] |  | 43.7 | m3 |  | 0 |  | Interferencias |
| A8340 |  | Emboquillado de piedra e=0.20m | 5d | 2025-05-02 | 2025-05-07 | A8240 SS | 111d | 0d | Capataz [7.98 h]; Operario [23.04 h]; Oficial [46.08 h]; Peon [75.35 h]; Peon - Vigia [0.07 h]; Operador equipo Pesado [0.11 h]; Operador equipo Liviano [16.25 h]; Cisterna 5000 gln [0.21 h]; Volquete 15 m3 [0.72 h]; Excavadora Cat 336 [0.11 h]; Retroexcavadora sobre llantas 94 hp [15.33 h]; Zaranda estatica [1.55 h]; Petroleo [42.06 gln]; ARENA GRUESA [6.66]; CEMENTO PORTLAND TIPO I (42.5 kg) [64.82] |  | 82.68 | m2 |  | 0 |  | Interferencias |
| A8410 |  | Sello en juntas | 5d | 2025-05-02 | 2025-05-07 | A8340 SS | 111d | 0d | Capataz [2.43 h]; Operario [9.72 h]; Peon [2.43 h]; TECNOPOR DE 1/2"X4X8' [1.66]; SELLADOR ELASTICO POLIURETANO SIKAFLEX 1A [8.34] |  | 29.15 | m |  | 0 |  | Interferencias |
|  | 2 | **CANAL DI-PR-53-I-CAN02** |  | 2025-05-08 | 2025-05-13 |  |  |  |  |  |  |  |  |  |  |  |
| A8480 |  | Trazo y replanteo de interferencia | 5d | 2025-05-08 | 2025-05-13 | A8410 | 111d | 0d | Capataz [0.14 h]; Peon [2.76 h]; Topografo [1.38 h]; GPS [1.38 h]; MADERA TORNILLO [1.38]; PINTURA ESMALTE [0.14] |  | 68.9 | m2 |  | 0 |  | Interferencias |
| A8500 |  | Desvío provisional en tierras | 5d | 2025-05-08 | 2025-05-13 | A8480 SS | 111d | 0d | Capataz [0.8 h]; Peon [4 h]; Operador equipo Pesado [4 h]; Excavadora Cat 336 [4 h]; Petroleo [33.99 gln] |  | 30 | m |  | 0 |  | Interferencias |
| A8510 |  | Limpieza de terreno manual | 5d | 2025-05-08 | 2025-05-13 | A8500 SS | 111d | 0d | Capataz [0.03 h]; Oficial [0.55 h]; Peon [1.1 h]; Operador equipo Pesado [0.21 h]; Excavadora Cat 336 [0.07 h]; Tractor D6 [0.14 h]; Petroleo [1.55 gln] |  | 68.9 | m2 |  | 0 |  | Interferencias |
| A8530 |  | Excavacion no clasificada de zanja | 5d | 2025-05-08 | 2025-05-13 | A8510 SS | 111d | 0d | Capataz [0.19 h]; Peon [1.87 h]; Operador equipo Pesado [1.87 h]; Excavadora Cat 336 [1.87 h]; Petroleo [15.88 gln] |  | 37.37 | m3 |  | 0 |  | Interferencias |
| A8640 |  | Emboquillado de piedra e=0.20m | 5d | 2025-05-08 | 2025-05-13 | A8530 SS | 111d | 0d | Capataz [7.67 h]; Operario [22.16 h]; Oficial [44.31 h]; Peon [72.45 h]; Peon - Vigia [0.07 h]; Operador equipo Pesado [0.1 h]; Operador equipo Liviano [15.63 h]; Cisterna 5000 gln [0.2 h]; Volquete 15 m3 [0.69 h]; Excavadora Cat 336 [0.1 h]; Retroexcavadora sobre llantas 94 hp [14.74 h]; Zaranda estatica [1.49 h]; Petroleo [40.44 gln]; ARENA GRUESA [6.4]; CEMENTO PORTLAND TIPO I (42.5 kg) [62.33] |  | 79.5 | m2 |  | 0 |  | Interferencias |
| A8710 |  | Sello en juntas | 5d | 2025-05-08 | 2025-05-13 | A8640 SS | 111d | 0d | Capataz [2.21 h]; Operario [8.83 h]; Peon [2.21 h]; TECNOPOR DE 1/2"X4X8' [1.51]; SELLADOR ELASTICO POLIURETANO SIKAFLEX 1A [7.58] |  | 26.5 | m |  | 0 |  | Interferencias |

| ID | WBS | Activity | Type | Duration | Start | Finish | Predecessors | Total float | Free float | Resources | Metrado | Unidad | RCuad | AGrupo | Cuadrilla | Rendimiento | Turno | DurCal | Dur. Cal. |
| --- | --- | --- | --- | --- | --- | --- | --- | --- | --- | --- | --- | --- | --- | --- | --- | --- | --- | --- | --- |
|  | 3 | **DE-PR-53-I-INT01** |  |  | 2025-05-14 | 2025-05-19 |  |  |  |  |  |  |  |  |  |  |  |  |  |
| A8780 |  | Trazo y replanteo de interferencia |  | 5d | 2025-05-14 | 2025-05-19 | A8710 | 111d | 0d | Capataz [0.08 h]; Peon [1.59 h]; Topografo [0.8 h]; GPS [0.8 h]; MADERA TORNILLO [0.8]; PINTURA ESMALTE [0.08] | 39.8 | m2 | 0 | Interferencias |  |  |  |  |  |
| A8790 |  | Desvío provisional con tubería |  | 5d | 2025-05-14 | 2025-05-19 | A8780 SS | 111d | 0d | Capataz [6.79 h]; Operario [11.71 h]; Oficial [11.71 h]; Peon [74.94 h]; Operador equipo Pesado [4.68 h]; Operador equipo Liviano [2.93 h]; Camion grua 20 ton [2.93 h]; Excavadora Cat 336 [4.68 h]; Petroleo [51.51 gln]; TUBERIA CORRUGADA HDPE D=630 mm [36.89] | 35.13 | m | 0 | Interferencias |  |  |  |  |  |
| A8810 |  | Limpieza de terreno manual |  | 5d | 2025-05-14 | 2025-05-19 | A8790 SS | 111d | 0d | Capataz [0.02 h]; Oficial [0.32 h]; Peon [0.64 h]; Operador equipo Pesado [0.12 h]; Excavadora Cat 336 [0.04 h]; Tractor D6 [0.08 h]; Petroleo [0.9 gln] | 39.8 | m2 | 0 | Interferencias |  |  |  |  |  |
| A8820 |  | Excavaciones no clasificada para estructuras |  | 5d | 2025-05-14 | 2025-05-19 | A8810 SS | 111d | 0d | Capataz [0.96 h]; Peon [4.81 h]; Operador equipo Pesado [4.81 h]; Excavadora Cat 336 [4.81 h]; Petroleo [40.92 gln] | 150.45 | m3 | 0 | Interferencias |  |  |  |  |  |
| A8840 |  | Relleno estructural |  | 5d | 2025-05-14 | 2025-05-19 | A8820 SS | 111d | 0d | Capataz [3.58 h]; Operario [12.93 h]; Oficial [12.93 h]; Peon [30.92 h]; Peon - Vigia [0.4 h]; Operador equipo Pesado [13.67 h]; Operador equipo Liviano [16.79 h]; Cisterna 5000 gln [1.91 h]; Volquete 15 m3 [1.95 h]; Cargador Frontal 966 [2.99 h]; Chancadora Primaria [1.46 h]; Excavadora Cat 336 [2.33 h]; Retroexcavadora sobre llantas 58 hp [6.46 h]; Rodillo liso vibratorio 0.80 - 1.10 ton [12.93 h]; Tractor D6 [0.43 h]; Petroleo [96.35 gln] | 90.47 | m3 | 0 | Interferencias |  |  |  |  |  |
| A8850 |  | Suministro de roca (Alcantarillas) |  | 5d | 2025-05-14 | 2025-05-19 | A8840 SS | 111d | 0d | Capataz [2.78 h]; Peon [6.67 h]; Peon - Vigia [0.52 h]; Operador equipo Pesado [6.67 h]; Operador equipo Liviano [10.31 h]; Volquete 22 m3 [10.31 h]; Excavadora Cat 336 [6.67 h]; Petroleo [98.93 gln]; Peaje local [4.04] | 88.88 | m3 | 0 | Interferencias |  |  |  |  |  |
| A8860 |  | Colocación de roca en uña (Alcantarillas) |  | 5d | 2025-05-14 | 2025-05-19 | A8850 SS | 111d | 0d | Capataz [1.85 h]; Oficial [3.71 h]; Peon [3.71 h]; Operador equipo Pesado [4.44 h]; Excavadora Cat 336 [3.71 h]; Tractor D6 [0.74 h]; Petroleo [36.67 gln] | 88.88 | m3 | 0 | Interferencias |  |  |  |  |  |
| A8870 |  | Concreto de Nivelacion (f'c=100 kg/cm2) |  | 5d | 2025-05-14 | 2025-05-19 | A8860 SS | 111d | 0d | Capataz [10.48 h]; Operario [11.68 h]; Oficial [18.54 h]; Peon [97.7 h]; Operador equipo Liviano [12.42 h]; Cisterna 5000 gln [0.74 h]; Carmix 4.0 m3 [11.68 h]; Petroleo [61.36 gln]; PIEDRA CHANCADA [18.98]; ARENA GRUESA [16.06]; CEMENTO PORTLAND TIPO I (42.5 kg) [175.2] | 27.81 | m3 | 0 | Interferencias |  |  |  |  |  |
| A8890 |  | Concreto Clase C (f'c=280 kg/cm2) Premezclado - Cimientos reforzados |  | 5d | 2025-05-14 | 2025-05-19 | A8870 SS | 111d | 0d | Capataz [5.2 h]; Operario [14.99 h]; Oficial [20.81 h]; Peon [48.32 h]; Operador equipo Liviano [9.17 h]; Carmix 4.0 m3 [9.17 h]; Petroleo [48.75 gln]; PIEDRA CHANCADA [14.9]; ARENA GRUESA [12.61]; CEMENTO PORTLAND TIPO I (42.5 kg) [240.68]; PLASTIMENT TM-40 - PLASTIFICANTE [49.28]; ADITIVO CURADOR DE CONCRETO [3.27] | 21.83 | m3 | 0 | Interferencias |  |  |  |  |  |
| A8900 |  | Concreto Clase C (f'c=280 kg/cm2) Premezclado - Muros de contencion |  | 5d | 2025-05-14 | 2025-05-19 | A8890 SS | 111d | 0d | Capataz [5.35 h]; Operario [15.42 h]; Oficial [21.41 h]; Peon [55.7 h]; Operador equipo Liviano [9.43 h]; Carmix 4.0 m3 [9.43 h]; Petroleo [50.16 gln]; PIEDRA CHANCADA [15.33]; ARENA GRUESA [12.97]; CEMENTO PORTLAND TIPO I (42.5 kg) [247.62]; PLASTIMENT TM-40 - PLASTIFICANTE [50.7]; ADITIVO CURADOR DE CONCRETO [3.37] | 22.46 | m3 | 0 | Interferencias |  |  |  |  |  |
| A8910 |  | Encofrado y Desencofrado Caravista |  | 5d | 2025-05-14 | 2025-05-19 | A8900 SS | 111d | 0d | Capataz [4.4 h]; Operario [22.02 h]; Oficial [22.02 h]; Peon [44.04 h]; ALAMBRE NEGRO #8 [8.81]; CLAVOS PARA MADERA CON CABEZA DE 3" [8.81]; LACA DESMOLDEADORA [1.32]; MADERA TORNILLO INCLUYE CORTE PARA ENCOFRADO [132.12]; TRIPLAY DE 19 mm PARA ENCOFRADO [3.83] | 44.04 | m2 | 0 | Interferencias |  |  |  |  |  |
| A8920 |  | Encofrado y Desencofrado Cara Oculta |  | 5d | 2025-05-14 | 2025-05-19 | A8910 SS | 111d | 0d | Capataz [5.52 h]; Operario [55.2 h]; Oficial [55.2 h]; ALAMBRE NEGRO #8 [24.84]; CLAVOS PARA MADERA CON CABEZA DE 3" [17.39]; MADERA TORNILLO INCLUYE CORTE PARA ENCOFRADO [413.95] | 82.79 | m2 | 0 | Interferencias |  |  |  |  |  |
| A8930 |  | Acero de refuerzo f'y=4200kg/cm2 |  | 5d | 2025-05-14 | 2025-05-19 | A8920 SS | 111d | 0d | Capataz [6.45 h]; Operario [65.04 h]; Oficial [65.04 h]; Peon [32.52 h]; ALAMBRE NEGRO #16 [134.39]; ACERO CORRUGADO fy = 4200 kg/cm2 GRADO 60 [2822.11] | 2687.72 | kg | 0 | Interferencias |  |  |  |  |  |
| A8970 |  | Cama de arena e=0.20m |  | 5d | 2025-05-14 | 2025-05-19 | A8930 SS | 111d | 0d | Capataz [0.14 h]; Operario [0.7 h]; Oficial [1.4 h]; Peon [2.8 h]; Peon - Vigia [0.01 h]; Operador equipo Liviano [0.12 h]; Cisterna 5000 gln [0.05 h]; Volquete 22 m3 [0.07 h]; Petroleo [1.12 gln]; ARENA GRUESA [3.84] | 17.45 | m2 | 0 | Interferencias |  |  |  |  |  |
| A8980 |  | Tubería HDPE Corrugada Ø=900mm (Suministro e instalación) |  | 5d | 2025-05-14 | 2025-05-19 | A8970 SS | 111d | 0d | Capataz [3.71 h]; Operario [3.71 h]; Oficial [7.42 h]; Peon [7.42 h]; Operador equipo Pesado [1.86 h]; Operador equipo Liviano [0.93 h]; Camion grua 20 ton [0.93 h]; Excavadora Cat 336 [1.86 h]; Petroleo [19.48 gln]; Tubería HDPE Corrugado de 900 mm [12.24] | 11.13 | m | 0 | Interferencias |  |  |  |  |  |
| A8990 |  | Compuertas Charnela Ø900 (Suministro e instalacion) |  | 5d | 2025-05-14 | 2025-05-19 | A8980 SS | 111d | 0d | Capataz [4 h]; Operario [8 h]; Oficial [16 h]; Peon [32 h]; Operador equipo Liviano [6 h]; Camion grua 20 ton [6 h]; Petroleo [24 gln]; Suministro de Compuerta tipo CHARNELA, D=900mm [1] | 1 | und | 0 | Interferencias |  |  |  |  |  |
| A9020 |  | Waterstop (anillos de estanqueidad) |  | 5d | 2025-05-14 | 2025-05-19 | A8990 SS | 111d | 0d | Capataz [0.2 h]; Operario [2 h]; Peon [4 h]; WATER STOP (anillos de estanqueidad); DN=900mm [1.82] | 2 | und | 0 | Interferencias |  |  |  |  |  |
| A9030 |  | Pintura bituminosa |  | 5d | 2025-05-14 | 2025-05-19 | A9020 SS | 111d | 0d | Capataz [1.66 h]; Operario [16.56 h]; Peon [33.12 h]; PINTURA ASFALTICA [33.12]; IMPRIMANTE ASFALTICO [14.49] | 82.79 | m2 | 0 | Interferencias |  |  |  |  |  |
| A9040 |  | Suministro e Instalación de geotextil |  | 5d | 2025-05-14 | 2025-05-19 | A9030 SS | 111d | 67d | Capataz [0.1 h]; Oficial [1.03 h]; Peon [1.54 h]; Operador equipo Liviano [0.13 h]; Camion grua 20 ton [0.13 h]; Petroleo [0.51 gln]; Geotextil no tejido 200gr/m2 [46.15] | 38.46 | m2 | 0 | Interferencias |  |  |  |  |  |
|  | 10 | **DI-PR-55-D** |  |  | 2025-07-02 | 2025-10-13 |  |  |  |  |  |  |  |  |  |  |  |  |  |
| A10780 |  | Inicio - DE-PR-55-D | milestone | 0d | 2025-07-02 | 2025-07-02 | A7810 SS+35d | 0d |  |  |  |  | 0 |  |  |  |  |  |  |
| A10790 |  | Fin - DE-PR-55-D | milestone | 0d | 2025-10-13 | 2025-10-13 | A9260 FF, A9180 FF, A9210 FF, A9420 FF, A9460 FF | 0d |  |  |  |  | 0 |  |  |  |  |  |  |
|  | 1 | **EXCAVACIONES** |  |  | 2025-07-02 | 2025-08-29 |  |  |  |  |  |  |  |  |  |  |  |  |  |
| A9080 |  | Desbroce |  | 15d | 2025-07-02 | 2025-07-18 | A10780 SS | 0d |  | Capataz [0.26 h]; Peon [51.4 h]; Operador equipo Pesado [38.55 h]; Excavadora Cat 336 [12.85 h]; Tractor D6 [25.7 h]; Petroleo [289.12 gln] | 2.57 | ha | 1 | Excavacion | 1 | 0.8 | 1 | 2.57 | 3.2125 |
| A9140 |  | Conformacion de Material Excedente en DMO |  | 15d | 2025-07-02 | 2025-07-18 | A9080 SS | 51d | 24d | Capataz [6.57 h]; Peon [62.39 h]; Operador equipo Pesado [68.95 h]; Excavadora Cat 336 [6.57 h]; Tractor D6 [62.39 h]; Petroleo [492.52 gln] | 8208.67 | m3 | 1 | Excavacion | 1 | 1050 | 1 | 8208.67 | 7.81778095238095 |
| A9090 |  | Remocion de Dique Existente |  | 43d | 2025-07-04 | 2025-08-27 | A9080 SS+2d | 0d |  | Capataz [13.11 h]; Peon [65.54 h]; Operador equipo Pesado [98.3 h]; Excavadora Cat 336 [65.54 h]; Tractor D8 [32.77 h]; Petroleo [868.36 gln] | 6553.65 | m3 | 1 | Excavacion | 1 | 800 | 1 | 6553.65 | 8.1920625 |
| A9100 |  | Excavacion de Cimentacion |  | 43d | 2025-07-04 | 2025-08-27 | A9090 SS | 0d |  | Capataz [69.17 h]; Peon [691.68 h]; Operador equipo Pesado [461.12 h]; Operador equipo Liviano [384.27 h]; Excavadora Cat 336 [307.41 h]; Retroexcavadora sobre llantas 94 hp [384.27 h]; Tractor D8 [153.71 h]; Petroleo [5026.22 gln] | 38426.77 | m3 | 1 | Excavacion | 1 | 900 | 1 | 38426.77 | 42.6964111111111 |
| A9120 |  | Excavacion de Uña |  | 43d | 2025-07-04 | 2025-08-27 | A9100 SS | 0d |  | Capataz [53.48 h]; Peon [267.39 h]; Operador equipo Pesado [267.39 h]; Excavadora Cat 336 [267.39 h]; Petroleo [3021.49 gln] | 16711.77 | m3 | 1 | Excavacion | 1 | 500 | 1 | 16711.77 | 33.42354 |
| A9130 |  | Conformacion de Material Excedente en DME |  | 43d | 2025-07-04 | 2025-08-27 | A9090 SS | 28d | 10d | Capataz [45.67 h]; Peon [433.82 h]; Operador equipo Pesado [479.49 h]; Excavadora Cat 336 [45.67 h]; Tractor D6 [433.82 h]; Petroleo [3424.89 gln] | 57081.57 | m3 | 1 | Excavacion | 1 | 1050 | 1 | 57081.57 | 54.3634 |
| A9110 |  | Perfilado y Conformacion de Plataforma de Fundacion |  | 35d | 2025-07-16 | 2025-08-29 | A9100 SS+10d | 7d | 0d | Capataz [7.07 h]; Peon [87.25 h]; Operador equipo Pesado [155.64 h]; Operador equipo Liviano [33.02 h]; Cisterna 5000 gln [33.02 h]; Motoniveladora 140K [77.82 h]; Rodillo liso vibratorio 10 - 12 ton [77.82 h]; Petroleo [669.74 gln] | 23582.38 | m2 | 1 | Excavacion | 1 | 2400 | 1 | 23582.38 | 9.82599166666667 |

| ID | WBS | Activity | Duration | Start | Finish | Predecessors | Total float | Free float | Resources | Cuadrilla | Rendimiento | Metrado | Unidad | Turno | RCuad | DurCal | Dur. Cal. | AGrupo |
| --- | --- | --- | --- | --- | --- | --- | --- | --- | --- | --- | --- | --- | --- | --- | --- | --- | --- | --- |
|  | 2 | **RELLENOS** |  | 2025-08-18 | 2025-09-22 |  |  |  |  |  |  |  |  |  |  |  |  |  |
| A9160 |  | Relleno con Material Granular (incluye extraccion de material, zarandeo y combinado) | 29d | 2025-08-18 | 2025-09-20 | A9110 SS+24d | 7d | 0d | Capataz [451.16 h]; Operario [113.19 h]; Oficial [330 h]; Peon [1182.89 h]; Peon - Vigia [70.14 h]; Operador equipo Pesado [1740.86 h]; Operador equipo Liviano [680.72 h]; Cisterna 5000 gln [223.19 h]; Volquete 15 m3 [342.75 h]; Cargador Frontal 966 [519.71 h]; Chancadora Primaria [256.67 h]; Excavadora Cat 336 [401.74 h]; Retroexcavadora sobre llantas 58 hp [57.39 h]; Rodillo liso vibratorio 10 - 12 ton [216.81 h]; Rodillo liso vibratorio 0.80 - 1.10 ton [113.19 h]; Tractor D6 [288.55 h]; Petroleo [12343.9 gln] | 1 | 560 | 15941.97 | m3 | 1 | 1 | 15941.97 | 28.4678035714286 | Relleno |
| A9190 |  | Perfilado de Talud Dique | 7d | 2025-08-21 | 2025-08-28 | A9160 SS+3d, A9140 | 27d | 9d | Capataz [49.72 h]; Peon [246.45 h]; Operador equipo Pesado [73.5 h]; Excavadora Cat 336 [73.5 h]; Petroleo [624.78 gln] | 1 | 700 | 21618.8 | m2 | 1 | 1 | 21618.8 | 30.884 | Relleno |
| A9210 |  | Grava para Drenaje | 10d | 2025-09-10 | 2025-09-20 | A9160 FF, A9130, A9190 | 18d |  | Capataz [22.23 h]; Peon [72.1 h]; Peon - Vigia [2.26 h]; Operador equipo Pesado [29.57 h]; Operador equipo Liviano [66.47 h]; Volquete 15 m3 [11.31 h]; Cargador Frontal 966 [12.69 h]; Chancadora Primaria [8.44 h]; Excavadora Cat 336 [8.44 h]; Retroexcavadora sobre llantas 94 hp [55.16 h]; Tractor D6; Petroleo [377.25 gln] | 1 | 80 | 551.61 | m3 | 1 | 1 | 551.61 | 6.895125 | Relleno |
| A9180 |  | Relleno Afirmado | 1d | 2025-09-22 | 2025-09-22 | A9160 | 17d |  | Capataz [3.94 h]; Oficial [3.23 h]; Peon [10.17 h]; Peon - Vigia [1.09 h]; Operador equipo Pesado [18.65 h]; Operador equipo Liviano [6.87 h]; Cisterna 5000 gln [1.48 h]; Volquete 15 m3 [5.4 h]; Cargador Frontal 966 [2.29 h]; Chancadora LT200 [2.29 h]; Excavadora Cat 336 [4.3 h]; Motoniveladora 140K [3.23 h]; Rodillo liso vibratorio 10 - 12 ton [3.23 h]; Tractor D6 [1.01 h]; Zaranda Metso ST 4.8 168 HP [2.29 h]; Petroleo [131.34 gln]; CANON POR EXTRACCION CANTERA [137.5] | 1 | 324 | 130.95 | m3 | 1 | 1 | 130.95 | 0.404166666666667 | Relleno |
|  | 3 | **GEOTEXTIL** |  | 2025-07-05 | 2025-10-13 |  |  |  |  |  |  |  |  |  |  |  |  |  |
| A9220 |  | Instalacion de Geotextil 400gr/m2 | 80d | 2025-07-05 | 2025-10-13 | A9250 SS | 0d |  | Capataz [192.04 h]; Oficial [1899.05 h]; Peon [2845.02 h]; Operador equipo Liviano [234.71 h]; Camion grua 20 ton [234.71 h]; Petroleo [938.86 gln]; Geotextil de 400 gr/m2 [81794.4 m2] | 1 | 600 | 71125.53 | m2 | 1 | 1 | 71125.53 | 118.54255 | Geotextil |
| A9230 |  | Zanja de Anclaje | 10d | 2025-10-01 | 2025-10-13 | A9220 FF | 0d |  | Capataz [6.26 h]; Oficial [31.29 h]; Peon [94.1 h]; Operador equipo Pesado [31.29 h]; Operador equipo Liviano [0.88 h]; Cisterna 5000 gln [0.88 h]; Retroexcavadora sobre llantas 58 hp [31.29 h]; Petroleo [111.48 gln] | 1 | 32 | 125.16 | m3 | 1 | 1 | 125.16 | 3.91125 | Geotextil |
|  | 4 | **COLOCACION DE ROCA** |  | 2025-07-04 | 2025-10-11 |  |  |  |  |  |  |  |  |  |  |  |  |  |
| A9270 |  | Extraccion de Rocas Reutilizables | 43d | 2025-07-04 | 2025-08-27 | A9090 SS | 7d | 6d | Capataz [84.68 h]; Peon [169.2 h]; Operador equipo Pesado [169.2 h]; Excavadora Cat 336 [169.2 h]; Petroleo [1438.28 gln] | 1 | 160 | 1504 | m3 | 1 | 1 | 1504 | 9.4 | Roca |
| A10800 |  | Suministro de Roca | 79d | 2025-07-05 | 2025-10-11 | A9250 SS | 1d | 0d |  |  |  |  |  |  | 0 |  |  | Roca |
| A9250 |  | Colocacion de Roca en Uña | 60d | 2025-07-05 | 2025-09-18 | A9120 SS+1d | 0d |  | Capataz [238.98 h]; Oficial [477.96 h]; Peon [477.96 h]; Operador equipo Pesado [526.42 h]; Excavadora Cat 336 [477.96 h]; Tractor D6 [48.46 h]; Petroleo [4401.88 gln] | 1 | 280 | 16711.77 | m3 | 1 | 1 | 16711.77 | 59.6848928571429 | Roca |
| A9260 |  | Colocacion de Roca en Talud | 31d | 2025-09-05 | 2025-10-11 | A9250 SS+48d, A9270 | 1d |  | Capataz [246.59 h]; Oficial [494.37 h]; Peon [494.37 h]; Operador equipo Pesado [1037.34 h]; Excavadora Cat 336 [987.54 h]; Tractor D6 [49.79 h]; Petroleo [8743.27 gln] | 2 | 192 | 11855.28 | m3 | 1 | 2 | 5927.64 | 30.873125 | Roca |
|  | 5 | **TRANSPORTES** |  | 2025-07-02 | 2025-10-13 |  |  |  |  |  |  |  |  |  |  |  |  |  |
| A9350 |  | Transporte de Material Organico (a DMO) D<=1km | 15d | 2025-07-02 | 2025-07-18 | A9080 SS | 28d | 0d | Peon - Vigia [45.97 h]; Operador equipo Liviano [228.2 h]; Volquete 15 m3 [228.2 h]; Petroleo [638.63 gln] | 1 |  | 8208.67 | m3k | 1 | 1 | 8208.67 |  | Transportes |
| A9360 |  | Transporte de Material Organico (a DMO) D>1km | 15d | 2025-07-02 | 2025-07-18 | A9350 SS | 28d | 21d | Operador equipo Liviano [1159.45 h]; Volquete 15 m3 [1159.45 h]; Petroleo [3246.47 gln] | 1 |  | 105404.84 | m3k | 1 | 1 | 105404.84 |  | Transportes |
| A9370 |  | Transporte de Material Excedente D<=1km | 43d | 2025-07-04 | 2025-08-27 | A9090 SS | 28d | 0d | Peon - Vigia [291.12 h]; Operador equipo Liviano [1449.87 h]; Volquete 22 m3 [622.19 h]; Volquete 15 m3 [827.68 h]; Petroleo [4857.64 gln] | 1 |  | 57081.57 | m3k | 1 | 1 | 57081.57 |  | Transportes |
| A9380 |  | Transporte de Material Excedente D>1km | 43d | 2025-07-04 | 2025-08-27 | A9370 SS | 28d |  | Operador equipo Liviano [7337.92 h]; Volquete 22 m3 [3124.06 h]; Volquete 15 m3 [4213.85 h]; Petroleo [24556.6 gln] | 1 |  | 726526.25 | m3k | 1 | 1 | 726526.25 |  | Transportes |
| A9410 |  | Transporte de Roca D<=1km | 79d | 2025-07-05 | 2025-10-11 | A10800 SS | 1d | 0d | Peon [357.09 h]; Peon - Vigia [165.69 h]; Operador equipo Pesado [357.09 h]; Operador equipo Liviano [828.44 h]; Volquete 22 m3 [828.44 h]; Excavadora Cat 336 [357.09 h]; Petroleo [6433.3 gln]; Peaje local [1299.8] | 1 |  | 28567.05 | m3k | 1 | 1 | 28567.05 |  | Transportes |
| A9420 |  | Transporte de Roca D>1km | 79d | 2025-07-05 | 2025-10-11 | A9410 SS | 1d |  | Operador equipo Liviano [1331.68 h]; Volquete 22 m3 [1331.68 h]; Petroleo [5454.76 gln] | 1 |  | 128046.04 | m3k | 1 | 1 | 128046.04 |  | Transportes |
| A9390 |  | Transporte de Material de Prestamo (Afirmado) D<=1km | 30d | 2025-08-18 | 2025-09-22 | A9160 SS, A9360 | 7d | 0d | Peon - Vigia [36.61 h]; Operador equipo Liviano [182.17 h]; Volquete 22 m3 [182.17 h]; Petroleo [746.97 gln] | 1 |  | 8716.12 | m3k | 1 | 1 | 8716.12 |  | Transportes |
| A9400 |  | Transporte de Material de Prestamo (Afirmado) D>1km | 30d | 2025-08-18 | 2025-09-22 | A9390 SS | 7d |  | Operador equipo Liviano [702.29 h]; Volquete 22 m3 [702.29 h]; Petroleo [2876.86 gln] | 1 |  | 84613.62 | m3k | 1 | 1 | 84613.62 |  | Transportes |
| A9430 |  | Transporte de Material de Prestamo Cantera de Rio (Cuerpo de Terraplen) D<=1km | 30d | 2025-08-18 | 2025-09-22 | A9160 SS | 7d | 0d | Peon - Vigia [86.04 h]; Operador equipo Liviano [428.17 h]; Volquete 22 m3 [428.17 h]; Petroleo [1755.71 gln] | 1 |  | 20486.66 | m3k | 1 | 1 | 20486.66 |  | Transportes |
| A9440 |  | Transporte de Material de Prestamo Cantera de Rio (Cuerpo de Terraplen) D>1km | 30d | 2025-08-18 | 2025-09-22 | A9430 SS | 7d |  | Operador equipo Liviano [336.39 h]; Volquete 22 m3 [336.39 h]; Petroleo [1377.98 gln] | 1 |  | 40528.84 | m3k | 1 | 1 | 40528.84 |  | Transportes |
| A9450 |  | Transporte de Material Seleccionado para Zanja D<=1km | 10d | 2025-10-01 | 2025-10-13 | A9230 SS, A10250, A9380, A9400, A9440 | 0d |  | Peon - Vigia [0.7 h]; Operador equipo Liviano [3.48 h]; Volquete 15 m3 [3.48 h]; Petroleo [9.74 gln] | 1 |  | 125.16 | m3k | 1 | 1 | 125.16 |  | Transportes |
| A9460 |  | Transporte de Material Seleccionado para Zanja D>1km | 10d | 2025-10-01 | 2025-10-13 | A9450 SS, A10320 | 0d |  | Operador equipo Liviano [2.59 h]; Volquete 15 m3 [2.59 h]; Petroleo [7.25 gln] | 1 |  | 235.48 | m3k | 1 | 1 | 235.48 |  | Transportes |

| ID | WBS | Activity | Type | Duration | Start | Finish | Predecessors | Total float | Free float | Resources | Metrado | Unidad | RCuad | AGrupo | Cuadrilla | Rendimiento | Turno | DurCal | Dur. Cal. |
| --- | --- | --- | --- | --- | --- | --- | --- | --- | --- | --- | --- | --- | --- | --- | --- | --- | --- | --- | --- |
|  | 7 | **OBRAS CIVILES** |  |  | 2025-07-14 | 2025-08-11 |  |  |  |  |  |  |  |  |  |  |  |  |  |
| A10250 |  | Concreto de Nivelacion (f'c=100 kg/cm2) |  | 21d | 2025-07-14 | 2025-08-11 | A10780 SS+10d | 42d | 0d | Capataz [1.36 h]; Operario [1.51 h]; Oficial [2.4 h]; Peon [12.65 h]; Operador equipo Liviano [1.61 h]; Cisterna 5000 gln [0.1 h]; Carmix 4.0 m3 [1.51 h]; Petroleo [7.94 gln]; PIEDRA CHANCADA [2.46]; ARENA GRUESA [2.08]; CEMENTO PORTLAND TIPO I (42.5 kg) [22.68] | 3.6 | m3 | 0 | Obras civiles |  |  |  |  |  |
| A10260 |  | Concreto Clase C (f'c=280 kg/cm2) Premezclado - Cimientos reforzados |  | 21d | 2025-07-14 | 2025-08-11 | A10250 SS | 42d | 0d | Capataz [4.72 h]; Operario [13.6 h]; Oficial [18.88 h]; Peon [43.82 h]; Operador equipo Liviano [8.32 h]; Carmix 4.0 m3 [8.32 h]; Petroleo [44.22 gln]; PIEDRA CHANCADA [13.51]; ARENA GRUESA [11.43]; CEMENTO PORTLAND TIPO I (42.5 kg) [218.29]; PLASTIMENT TM-40 - PLASTIFICANTE [44.7]; ADITIVO CURADOR DE CONCRETO [2.97] | 19.8 | m3 | 0 | Obras civiles |  |  |  |  |  |
| A10270 |  | Concreto Clase C (f'c=280 kg/cm2) Premezclado - Muros de contencion |  | 21d | 2025-07-14 | 2025-08-11 | A10260 SS | 42d | 0d | Capataz [4.25 h]; Operario [12.26 h]; Oficial [17.02 h]; Peon [44.27 h]; Operador equipo Liviano [7.5 h]; Carmix 4.0 m3 [7.5 h]; Petroleo [39.86 gln]; PIEDRA CHANCADA [12.18]; ARENA GRUESA [10.31]; CEMENTO PORTLAND TIPO I (42.5 kg) [196.8]; PLASTIMENT TM-40 - PLASTIFICANTE [40.3]; ADITIVO CURADOR DE CONCRETO [2.68] | 17.85 | m3 | 0 | Obras civiles |  |  |  |  |  |
| A10280 |  | Encofrado y Desencofrado Caravista |  | 21d | 2025-07-14 | 2025-08-11 | A10270 SS | 42d | 0d | Capataz [10.2 h]; Operario [51 h]; Oficial [51 h]; Peon [102 h]; ALAMBRE NEGRO #8 [20.4]; CLAVOS PARA MADERA CON CABEZA DE 3" [20.4]; LACA DESMOLDEADORA [3.06]; MADERA TORNILLO INCLUYE CORTE PARA ENCOFRADO [306]; TRIPLAY DE 19 mm PARA ENCOFRADO [8.87] | 102 | m2 | 0 | Obras civiles |  |  |  |  |  |
| A10290 |  | Encofrado y Desencofrado Cara Oculta |  | 21d | 2025-07-14 | 2025-08-11 | A10280 SS | 42d | 0d | Capataz [1.7 h]; Operario [17.02 h]; Oficial [17.02 h]; ALAMBRE NEGRO #8 [7.66]; CLAVOS PARA MADERA CON CABEZA DE 3" [5.36]; MADERA TORNILLO INCLUYE CORTE PARA ENCOFRADO [127.65] | 25.53 | m2 | 0 | Obras civiles |  |  |  |  |  |
| A10300 |  | Acero de refuerzo f'y=4200kg/cm2 |  | 21d | 2025-07-14 | 2025-08-11 | A10290 SS | 42d | 0d | Capataz [3.44 h]; Operario [34.67 h]; Oficial [34.67 h]; Peon [17.34 h]; ALAMBRE NEGRO #16 [71.64]; ACERO CORRUGADO fy = 4200 kg/cm2 GRADO 60 [1504.35] | 1432.71 | kg | 0 | Obras civiles |  |  |  |  |  |
| A10310 |  | Junta de dilatación |  | 21d | 2025-07-14 | 2025-08-11 | A10300 SS | 42d | 0d | Capataz [0.28 h]; Operario [1.13 h]; Peon [1.13 h]; MATERIAL DE RESPALDO 1/2" PARA JUNTAS 10 mm [3.4]; TECNOPOR DE 1/2"X4X8' [0.19]; SELLADOR ELASTICO POLIURETANO SIKAFLEX 1A [0.97] | 3.4 | m | 0 | Obras civiles |  |  |  |  |  |
| A10320 |  | Pintura bituminosa |  | 21d | 2025-07-14 | 2025-08-11 | A10310 SS | 42d |  | Capataz [2.17 h]; Operario [21.7 h]; Peon [43.41 h]; PINTURA ASFALTICA [43.41]; IMPRIMANTE ASFALTICO [18.99] | 108.52 | m2 | 0 | Obras civiles |  |  |  |  |  |
|  | 11 | **DC-PR-01A-D** |  |  | 2025-08-07 | 2025-08-27 |  |  |  |  |  |  |  |  |  |  |  |  |  |
| A10830 |  | Inicio - DC-PR-01A-D | milestone | 0d | 2025-08-07 | 2025-08-07 | A7790 FS+60d | 38d | 0d |  |  |  | 0 |  |  |  |  |  |  |
| A10840 |  | Fin - DC-PR-01A-D | milestone | 0d | 2025-08-27 | 2025-08-27 | A10160 FF, A9910 FF | 38d |  |  |  |  | 0 |  |  |  |  |  |  |
|  | 1 | **EXCAVACIONES** |  |  | 2025-08-07 | 2025-08-27 |  |  |  |  |  |  |  |  |  |  |  |  |  |
| A9910 |  | Conformacion de Material Excedente en DME |  | 18d | 2025-08-07 | 2025-08-27 | A9931 SS | 38d | 0d | Capataz [13.31 h]; Peon [126.4 h]; Operador equipo Pesado [139.7 h]; Excavadora Cat 336 [13.31 h]; Tractor D6 [126.4 h]; Petroleo [997.88 gln] | 16631.33 | m3 | 1 | Excavacion | 1 | 1050 | 1 | 16631.33 | 15.8393619047619 |
| A9931 |  | Descolmatación |  | 18d | 2025-08-07 | 2025-08-27 | A10830 SS | 38d | 0d | Capataz [13.31 h]; Peon [277.74 h]; Peon - Vigia [96.46 h]; Operador equipo Pesado [276.08 h]; Operador equipo Liviano [482.31 h]; Volquete 15 m3 [482.31 h]; Excavadora Cat 336 [138.04 h]; Tractor D8 [138.04 h]; Petroleo [3836.85 gln] | 16631.33 | m3 | 1 | Excavacion | 1 | 960 | 1 | 16631.33 | 17.3243020833333 |
|  | 5 | **TRANSPORTES** |  |  | 2025-08-07 | 2025-08-27 |  |  |  |  |  |  |  |  |  |  |  |  |  |
| A10150 |  | Transporte de Material Excedente D<=1km |  | 18d | 2025-08-07 | 2025-08-27 | A9931 SS | 38d | 0d | Peon - Vigia [84.82 h]; Operador equipo Liviano [422.44 h]; Volquete 22 m3 [181.28 h]; Volquete 15 m3 [241.15 h]; Petroleo [1415.33 gln] | 16631.33 | m3k | 1 | Transportes | 1 |  | 1 | 16631.33 |  |
| A10160 |  | Transporte de Material Excedente D>1km |  | 18d | 2025-08-07 | 2025-08-27 | A10150 SS | 38d | 0d | Operador equipo Liviano [2244.88 h]; Volquete 22 m3 [955.74 h]; Volquete 15 m3 [1289.14 h]; Petroleo [7512.57 gln] | 222265.39 | m3k | 1 | Transportes | 1 |  | 1 | 222265.39 |  |
|  | 13 | **MEDIO AMBIENTE** |  |  | 2024-08-20 | 2025-08-29 |  |  |  |  |  |  |  |  |  |  |  |  |  |
| A10850 |  | Rescate camarón - F1 |  | 80d | 2024-08-20 | 2024-11-23 | A10510 SS+15d | 164d | 128d |  |  |  |  |  |  |  |  |  |  |
| A10860 |  | Rescate camarón - F2 |  | 100d | 2025-04-29 | 2025-08-29 | A10690 SS+10d, A10850 | 36d |  |  |  |  |  |  |  |  |  |  |  |
